# 3GPP_Work Plan

Schedule from MS Project, 2000-01-01 to 2004-12-01, A marks actual dates.

## Calendars

- Standard: Mon-Fri 08:00-12:00, 13:00-17:00; Sat-Sun off.

## Resources

| Resource |
| --- |
| NP |
| N1 |
| N2 |
| N3 |
| N4 |
| N5 |
| TP |
| T1 |
| T2 |
| T3 |
| RP |
| R1 |
| R2 |
| R3 |
| R4 |
| SP |
| S1 |
| S2 |
| S3 |
| S4 |
| S5 |
| PCG |
| GP |
| No |
| CN4 |
| ? |
| WG G2 |
| G2 |
| G1 |
| G4 |
| G3 |
| All |
| Generic |
| MLST |
| G5 |
| S3, G2 |

## Schedule

| ID | WBS | Task | Duration | Start | Finish | Complete | Remaining | Baseline start | Baseline finish | Baseline duration | Total slack | Constraint | Resources | Work | Actual work | Text6 | Text9 | Text1 | Text4 | Text7 | Text8 | Text2 | Text5 |
| --- | --- | --- | --- | --- | --- | --- | --- | --- | --- | --- | --- | --- | --- | --- | --- | --- | --- | --- | --- | --- | --- | --- | --- |
| 1 | 1 | VERSION 2003 March 14th | 1d | 2000-01-03 | 2000-01-03 |  |  | 2000-01-03 | 2000-01-03 | 1d | 1129d |  |  |  |  | Rel | 2044 |  |  |  |  |  |  |
| 2 | 2 | "CTRL + a" to display all the 3GPP fields | 1d | 2000-01-03 | 2000-01-03 |  |  | 2000-01-03 | 2000-01-03 | 1d | 1129d |  |  |  |  |  | 1462 |  |  |  |  |  |  |
| 3 | 3 | Content of Rel4 and Rel5 frozen. Rel6 and after not frozen. | 1d | 2000-01-03 | 2000-01-03 |  |  | 2000-01-03 | 2000-01-03 | 1d | 1129d |  |  |  |  | Rel | 2058 |  |  |  |  |  |  |
| 6 | 6 | Evolutions of the transport in the UTRAN | 445d | 2000-07-17 A | 2002-03-29 A | 100% |  | 2000-07-17 | 2002-03-29 | 445d |  |  | RP | 3560h | 3560h | NA |  | ETRAN | Francois Courau | TSG | Joern |  |  |
| 7 | 7 | **Evolutions of the transport in the CN** | 261d | 2002-06-07 A | 2003-06-06 | 50% | 130.5d | 2002-06-07 | 2003-06-06 | 261d | 388d |  | N4 | 3136h | 2088h | NA |  | CNTRSP |  |  | Kimmo | BaAS |  |
| 8 | 7.1 | Preferred Framing Protocol for bearer independent CS architecture | 261d | 2002-06-07 A | 2003-06-06 | 50% | 130.5d | 2002-06-07 | 2003-06-06 | 261d | 388d | finish no earlier than 2003-06-06 | N4 | 2088h | 1044h | Rel-6 |  | PFP | Phli Hodges, Ericsson | TSG |  |  | philip.hodges@ericsson.com.au |
| 9 | 8 | **Improvements of Radio Interface** | 975d? | 2000-06-19 A | 2004-03-12 | 32% | 663.65d? | 2000-06-19 | 2004-03-12 | 975d? | 188d |  | RP | 66888h | 24643.1h | NA |  | RInImp |  | TSG | Tsukasa |  |  |
| 10 | 8.1 | Improvement of inter-frequency and inter-system measurement | 635d | 2001-01-01 A | 2003-06-06 | 5% | 603.25d | 2001-01-01 | 2003-06-06 | 635d | 388d | finish no earlier than 2003-06-06 | R1 | 5080h | 254h | Rel-6 | 1470 | RInImp-IfIsM | Nokia (Antti Toskala) | TSG |  | BaAS |  |
| 11 | 8.2 | **Base station classification** | 603d | 2000-08-14 A | 2002-12-04 A | 100% |  | 2000-08-14 | 2002-12-04 | 603d |  |  | R4 | 9648h | 9648h | Rel-6 |  | RInImp-BSClass |  | TSG |  |  |  |
| 12 | 8.2.1 | FDD Base station classification | 603d | 2000-08-14 A | 2002-12-04 A | 100% |  | 2000-08-14 | 2002-12-04 | 603d |  | finish no earlier than 2002-12-04 | R4 | 4824h | 4824h | Rel-6 | 1476 | RInImp-BSClass-FDD | A. Toskala, Nokia | TSG |  | BaAs |  |
| 13 | 8.4 | Terminal Power Saving features | 791d | 2000-06-19 | 2003-06-30 |  |  | 2000-06-19 | 2003-06-30 | 791d | 372d | finish no earlier than 2003-06-30 | R2 | 6328h |  | Rel-6 | 1507 | RInImp-TPS | M. Park, Samsung | TSG |  | BaAS |  |
| 14 | 8.5 | Multiple Input Multiple Output antennas (MIMO) | 656d | 2001-03-16 A | 2003-09-19 | 40% | 393.6d | 2001-03-16 | 2003-09-19 | 656d | 313d | finish no earlier than 2003-09-19 | R1 | 5248h | 2099.2h | Rel-6 | 2468 | RInImp-MIMO | Howard Huang, Lucent | TSG |  |  |  |
| 15 | 8.6 | Improving Receiver Performance Requirements for the FDD UE | 401d | 2002-03-08 A | 2003-09-19 | 29% | 284.71d | 2002-03-08 | 2003-09-19 | 401d | 313d | finish no earlier than 2003-09-19 | R4 | 3208h | 930.32h | Rel-6 |  | RInImp-UERecPerf | Shimon Moshavi, Intel | TSG |  |  |  |
| 16 | 6.6 | UMTS-850 | 331d? | 2002-12-06 | 2004-03-12 |  |  | 2002-12-06 | 2004-03-12 | 331d? | 188d | finish no earlier than 2004-03-12 | R4 | 2648h |  |  |  | RInImp-UMTS850 | TBD | TSG |  |  |  |
| 17 | 8.7 | FS for the viable deployment of UTRA in additional and diverse spectrum arrangements | 386d | 2001-09-21 A | 2003-03-14 | 75% | 96.5d | 2001-09-21 | 2003-03-14 | 386d | 448d | finish no earlier than 2003-03-14 | R4 | 3088h | 2316h | Rel-6 |  | RInImp-UMTSBands | Peter Ståhlfjäll, Ericsson | TSG | Cesar |  |  |
| 18 | 8.8 | FS on UE antenna efficiency test methods performance requirements (2) | 131d | 2002-03-08 A | 2002-09-06 A | 100% |  | 2002-03-08 | 2002-09-06 | 131d |  | finish no earlier than 2002-09-06 | R4 | 1048h | 1048h | Rel-6 |  | RInImp-UEAnTM2 | Alf Ahlström, Allgon | TSG |  |  |  |
| 19 | 8.9 | FS on Fast Cell Selection (FCS) for HS-DSCH | 521d | 2001-03-16 A | 2003-03-14 | 20% | 416.8d | 2001-03-16 | 2003-03-14 | 521d | 448d | finish no earlier than 2003-03-14 | R1 | 4168h | 833.6h | Rel-6 | 2471 | RInImp-FCS | Rizwan Hassan, Lucent | TSG |  |  |  |
| 20 | 8.10 | FS on Radio link performance enhancements | 810d | 2000-08-14 A | 2003-09-19 | 31% | 558.9d | 2000-08-14 | 2003-09-19 | 810d | 313d | finish no earlier than 2003-09-19 | R1 | 6480h | 2008.8h | Rel-6 | 1506 | RInImp-Rlperf | Antti Toskala, Nokia Networks | TSG |  |  |  |
| 21 | 8.11 | FS on UTRA WideBand Distribution Systems | 525d | 2001-03-12 A | 2003-03-14 | 40% | 315d | 2001-03-12 | 2003-03-14 | 525d | 448d | finish no earlier than 2003-03-14 | R4 | 4200h | 1680h | Rel-6 |  | RInImp-WDS | Andrea Casini, Tekmar Sistemi | TSG |  |  |  |
| 22 | 8.12 | FS on Improvement of inter-frequency and inter-system measurements for 1.28 Mcps TDD | 326d | 2001-12-14 A | 2003-03-14 | 45% | 179.3d | 2001-12-14 | 2003-03-14 | 326d | 448d | finish no earlier than 2003-03-14 | R1 | 2608h | 1173.6h | Rel-6 |  | RInImp-IfIsMLCR | Li Xiao Qiang, SAMSUNG | TSG |  |  |  |
| 23 | 8.13 | FS for the analysis of OFDM for UTRAN enhancements | 265d | 2002-06-10 | 2003-06-13 |  |  | 2002-06-10 | 2003-06-13 | 265d | 383d | finish no earlier than 2003-06-13 | R1 | 2120h |  | Rel-6 |  | RInImp-FSOFDM | Sarah Boumendil, Nortel | TSG |  |  |  |
| 24 | 8.14 | FS on Uplink Enhancements for Dedicated Transport Channels | 201d | 2002-09-06 | 2003-06-13 |  |  | 2002-09-06 | 2003-06-13 | 201d | 383d | finish no earlier than 2003-06-13 | R1 | 1608h |  | Rel-6 |  | RInImp-FSUpDTrCh | Karri Ranta-aho, Nokia | TSG |  |  |  |
| 25 | 8.15 | FS on Analysis on Higher Chip Rates for UTRA TDD evolutions | 201d | 2002-09-06 A | 2003-06-13 | 10% | 180.9d | 2002-09-06 | 2003-06-13 | 201d | 383d | start no earlier than 2002-09-06 | R1 | 1608h | 160.8h | Rel-6 |  | Rin-Imp-FSVHCRTDD | Tim Wilkinson, IPWireless | TSG |  |  |  |
| 26 | 9 | **RAN improvements** | 402d? | 2001-12-14 A | 2003-06-30 | 26% | 298.3d? | 2001-12-14 | 2003-06-30 | 402d? | 372d |  | RP | 13424h | 3462.78h | NA |  | RANimp |  | TSG | Cesar |  |  |
| 27 | 9.1 | Beamforming Enhancements | 386d | 2001-12-14 A | 2003-06-06 | 50% | 193d | 2001-12-14 | 2003-06-06 | 386d | 388d | finish no earlier than 2003-06-06 | R1 | 3088h | 1544h | Rel-6 |  | RANimp-BFE | Jussi Kähtävä, Nokia | TSG |  |  |  |
| 28 | 9.2 | RAB support enhancement | 206d | 2002-09-16 | 2003-06-30 |  |  | 2002-09-16 | 2003-06-30 | 206d | 372d | start no earlier than 2002-09-16 | R2 | 1648h |  | Rel-6 | 624 | RANimp-RABSE | M. Israelsson, A. Krishnarajah, Ericsson | TSG |  | BaAS |  |
| 29 | 9.3 | Improvement of RRM across RNS and RNS/BSS | 218d | 2002-03-25 A | 2003-01-22 | 30% | 152.6d | 2002-03-25 | 2003-01-22 | 218d | 485d | finish no earlier than 2003-01-22 | R3 | 1744h | 523.2h | Rel-6 |  | RANimp-RRM1 | Woonhee Hwang, Nokia |  |  |  |  |
| 30 | 9.4 | FS on the evolution of the UTRAN architecture | 200d | 2002-09-09 A | 2003-06-13 | 5% | 190d | 2002-09-09 | 2003-06-13 | 200d | 383d | start no earlier than 2002-09-09 | R3 | 1600h | 80h | Rel-6 |  | RANimp-FSEvo | Woonhee Hwang, Nokia | TSG |  |  |  |
| 31 | 9.5 | FS for the Early Mobile Handling in UTRAN | 135d | 2002-09-09 A | 2003-03-14 | 45% | 74.25d | 2002-09-09 | 2003-03-14 | 135d | 448d | finish no earlier than 2003-03-14 | R2 | 1080h | 486h | Rel-6 |  | RANimp-FSEarlyUE | Alan Law, Vodafone Ltd | TSG |  |  |  |
| 32 | 7.6 | FS of the improved access to UE measurement data for CRNC to support TDD RRM | 131d? | 2002-12-06 | 2003-06-06 |  |  | 2002-12-06 | 2003-06-06 | 131d? | 388d | finish no earlier than 2003-06-06 | R3 | 1048h |  |  |  |  | Jim Miller, Interdigital |  |  |  |  |

Notes:
- 6: To be deleted at TSG#18 if no input.
- 7: To be deleted at TSG#18 if no input.
- 8: WID approved at CN#16 / 15/11/2003 CN4: target will be Cn#20
- 10: RP-020389
- 13: This is a building block without particular end date
- 14: Status report: RP-020429
- 18: The RInImp-UEAnTM FS was re-opened at TSG RAN#15 upon request from WG4
- 19: RP-020446
- 20: RP-020358
- 22: RP-020374
- 27: RP-020357
- 28: This is a building block without particular end date

| ID | WBS | Task | Duration | Start | Finish | Complete | Remaining | Baseline start | Baseline finish | Baseline duration | Total slack | Constraint | Resources | Work | Actual work | Text1 | Text2 | Text4 | Text5 | Text6 | Text7 | Text8 | Text9 | Text3 |
| --- | --- | --- | --- | --- | --- | --- | --- | --- | --- | --- | --- | --- | --- | --- | --- | --- | --- | --- | --- | --- | --- | --- | --- | --- |
| 33 | 10 | **Emergency call enhancements** | 777d | 2000-09-18 A | 2003-09-09 | 27% | 564.44d | 2000-09-18 | 2003-09-09 | 777d | 321d |  | N1 | 19640h | 5372.88h | EMC1 | CCaR | Mr Rouzbeh, Ericsson | EUSFARO@am1.ericsson.se | Rel-6 | WG | Per | 1652 |  |
| 34 | 10.1 | **For IP & PS based calls** | 777d | 2000-09-18 A | 2003-09-09 | 27% | 564.44d | 2000-09-18 | 2003-09-09 | 777d | 321d |  | N1 | 14104h | 3858.41h | EMC1-PS | CCaR | Mr Rouzbeh, Ericsson | EUSFARO@am1.ericsson.se | Rel-6 |  |  | 1653 |  |
| 35 | 10.1.1 | Service Requirements for IP-based emergency calls | 205d | 2000-09-18 A | 2001-06-29 | 44% | 115d | 2000-09-18 | 2001-06-29 | 205d | 893d | start no earlier than 2000-09-18 | S1 | 1640h | 720h |  | CCaR |  |  |  |  |  | 1314 | 22.976 |
| 36 | 10.1.2 | SIP emergency calls and packet emergency calls signalling flowsl | 756d | 2000-10-17 A | 2003-09-09 | 21% | 597.24d | 2000-10-17 | 2003-09-09 | 756d | 321d | finish no earlier than 2003-09-09 | N1 | 6048h | 1270.08h |  | CCaR | Mr Rouzbeh, Ericsson | EUSFARO@am1.ericsson.se |  |  |  | 1315 | TS 24.228 |
| 37 | 10.1.3 | Stage 2 for emergency calls and packet emergency calls in general | 185d | 2002-08-12 A | 2003-04-25 | 35% | 120.25d | 2002-08-12 | 2003-04-25 | 185d | 418d | finish no earlier than 2003-04-25 | S2 | 1480h | 518h |  | CCaR |  |  |  |  |  | 1316 |  |
| 38 | 24 | **Emergency calls without UICC/SIM in netw. with IMS** | 962d | 2000-01-03 A | 2003-09-09 | 2% | 946.19d | 2000-01-03 | 2003-09-09 | 962d | 321d |  | S2 | 21968h | 360.92h |  |  |  |  | Rel-6 |  | Alain |  |  |
| 39 | 24.1 | Stage 2 | 145d | 2002-10-07 A | 2003-04-25 | 21% | 115d | 2002-10-07 | 2003-04-25 | 145d | 418d | finish no earlier than 2003-04-25 | S2 | 1160h | 240h |  |  |  |  |  |  |  |  |  |
| 40 | 24.2 | Stage 3 work for CN1 | 292d | 2002-07-29 | 2003-09-09 |  |  | 2002-07-29 | 2003-09-09 | 292d | 321d | finish no earlier than 2003-09-09 | N1 | 2336h |  | EMC-NOSIM |  |  |  |  |  |  |  |  |
| 41 | 10.1.4 | Distinction of emergency call types to different emergency services | 197d | 2002-12-09 | 2003-09-09 |  |  | 2002-12-09 | 2003-09-09 | 197d | 321d | finish no earlier than 2003-09-09 | N1 | 1576h |  |  | CCaR |  |  |  |  |  | 1317 |  |
| 42 | 10.1.5 | Stage 3 for emergency calls and packet emergency calls in general | 802d | 2000-08-14 | 2003-09-09 |  |  | 2000-08-14 | 2003-09-09 | 802d | 321d | finish no earlier than 2003-09-09 | N1 | 6416h |  |  | CCaR | Rouzbeh Farhoumand, Ericsson | rouzbeh.farhoumand@ericsson.com |  |  |  | 1646 | TS 24.229 |
| 43 | 10.1.6 | Conformance Test Aspects - Emergency call enhancements | 195d | 2000-01-03 | 2000-09-29 |  |  | 2000-01-03 | 2000-09-29 | 195d | 1088d |  | T1 | 1560h |  |  |  |  |  |  |  |  | 2224 |  |
| 44 | 10.1.7 | Testing Stage 3 for emergency calls and packet emergency calls in general | 195d | 2002-03-01 | 2002-11-28 |  |  | 2002-03-01 | 2002-11-28 | 195d | 524d | finish no earlier than 2002-11-28 | T1 | 1560h |  |  |  |  |  |  |  |  | 2225 |  |
| 45 | 12 | **Location Services enhancements 2** | 845d? | 2000-08-28 A | 2003-11-21 | 24% | 645.56d? | 2000-08-28 | 2003-11-21 | 845d? | 268d |  | S2 | 54040h | 11744.5h | LCS2 |  |  |  | Rel-6 | TSG | Alain |  |  |
| 46 | 12.1 | Improvement on Le interface | 331d | 2002-06-17 A | 2003-09-22 | 59% | 136d | 2002-06-21 | 2002-12-19 | 130d | 312d | start no earlier than 2002-06-17 | S2 | 2648h | 1560h |  |  |  |  |  | TSG |  |  |  |
| 47 | 12.2 | Enhanced support for user privacy and subscriber data handling | 600d | 2001-06-04 A | 2003-09-19 | 5% | 570d | 2001-06-04 | 2002-12-20 | 405d | 313d | start no earlier than 2001-06-04 | S2 | 4800h | 240h |  |  |  |  |  | TSG |  |  |  |
| 48 | 12.3 | Enhanced inter-GMLC interface | 320d | 2002-06-24 A | 2003-09-12 | 56% | 140d | 2002-06-24 | 2003-01-10 | 145d | 318d | start no earlier than 2002-06-24 | S2 | 2560h | 1440h |  |  |  |  |  | TSG |  |  |  |
| 49 | 12.4 | Support of the Presence Service Architecture | 310d | 2002-06-24 A | 2003-08-29 | 8% | 284.8d | 2002-06-24 | 2002-10-25 | 90d | 328d | finish no earlier than 2002-10-25 | S2 | 2480h | 201.6h |  |  |  |  |  | TSG |  |  |  |
| 50 | 12.5 | New area event for triggered location reports | 326d | 2002-06-03 A | 2003-09-01 | 60% | 131d | 2002-06-21 | 2002-12-20 | 131d | 327d | start no earlier than 2002-06-03 | S2 | 2608h | 1560h |  |  |  |  |  | TSG |  |  |  |
| 51 | 12.6 | FS on applicability of GALILEO for LCS | 270d | 2002-09-09 A | 2003-09-19 | 46% | 145d | 2002-09-16 | 2003-03-21 | 135d | 313d | start no earlier than 2002-09-09 | S2 | 2160h | 1000h |  |  |  |  |  |  |  |  |  |
| 52 | 12.7 | **UE positionning** | 805d | 2000-08-28 A | 2003-09-26 | 16% | 677.12d | 2000-08-28 | 2003-06-30 | 741d | 308d |  | RP | 15480h | 2459.12h | LCS2-UEpos |  |  |  | Rel-6 | TSG |  |  |  |
| 53 | 12.7.1 | UE positioning enhancements - other methods | 805d | 2000-08-28 A | 2003-09-26 | 10% | 723.49d | 2000-08-28 | 2003-06-30 | 741d | 308d | finish no earlier than 2003-06-30 | R2 | 6440h | 652.08h | LCS2-UEpos-enh |  | M. Beckmann, Siemens |  |  | TSG |  | 2457 |  |
| 54 | 12.7.2 | FS on Enhancements to OTDOA Positioning using advanced blanking methods | 325d | 2002-07-01 A | 2003-09-26 | 30% | 227d | 2002-07-01 | 2003-06-06 | 245d | 308d | finish no earlier than 2003-06-06 | R2 | 2600h | 784h | LCS2-UEpos-FSBlank |  | David Bartlett, Cambridge Positioning Systems |  |  | TSG |  |  |  |
| 55 | 10.8 | **Uplink TDOA location determination for GSM/GPRS** | 266d | 2002-11-15 A | 2003-11-21 | 3% | 258.98d | 2002-11-15 | 2003-11-21 | 266d | 268d |  | GP | 5544h | 146.32h | UTDOA |  | Gross/Robinson, TruePosition, Inc. |  | Rel-6 | TSG | Paolo |  |  |
| 56 | 10.8.1 | Addition of U-TDOA in the CS domain | 161d | 2002-11-15 A | 2003-06-27 | 7% | 149.73d | 2002-11-15 | 2003-06-27 | 161d | 373d | finish no earlier than 2003-06-27 | GP | 1288h | 90.16h | UTDOA-CS |  |  |  | Rel-6 |  |  |  |  |
| 57 | 10.8.2 | Addition of U-TDOA in the PS domain | 266d | 2002-11-15 | 2003-11-21 |  |  | 2002-11-15 | 2003-11-21 | 266d | 268d | finish no earlier than 2003-11-21 | GP | 2128h |  | UTDOA-PS |  |  |  | Rel-6 |  |  |  |  |

Notes:
- 36: No new spec will be presented, will be covered in CN1 spec24.228.
- 37: covered by TS 23.228
- 38: Per 30/5: This WID was approved in SA#11 as a feature. SA2 work on 23.221, 23.060 and 23.228 is targeted for TSG#13. The stage 3 work (mostly CN1?) is targeted for TSG#15 (March 2002)
- 42: Potentially sub contracted to IETF / covered by TS 24.229
- 44: This task required more supporting companies
- 53: This is a building block without particular end date
- 55: Ongoing

| ID | WBS | Task | Duration | Start | Finish | Complete | Remaining | Baseline start | Baseline finish | Baseline duration | Total slack | Constraint | Resources | Work | Actual work | Text1 | Text4 | Text7 | Text9 | Text5 | Text6 | Text8 | Text2 | Text3 |
| --- | --- | --- | --- | --- | --- | --- | --- | --- | --- | --- | --- | --- | --- | --- | --- | --- | --- | --- | --- | --- | --- | --- | --- | --- |
| 58 | 12.8 | **Open SMLC-SRNC Interface within the UTRAN to support UTRAN Rel4 positioning methods** | 565d? | 2001-01-15 A | 2003-03-14 | 15% | 479.51d? | 2001-01-15 | 2003-03-14 | 565d? | 448d |  | R2 | 10600h | 1919.6h | LCS-Rel4Pos | Meik Kottkamp, Siemens | TSG | 2475 |  |  |  |  |  |
| 59 | 10.9.1 | RAN aspects | 565d? | 2001-01-15 | 2003-03-14 |  |  | 2001-01-15 | 2003-03-14 | 565d? | 448d | start no earlier than 2001-01-15 | R2 | 4520h |  | LCS-Rel4Pos | Meik Kottkamp, Siemens | TSG |  |  |  |  |  |  |
| 60 | 12.8.1 | Stage 2 | 195d | 2001-01-15 A | 2001-10-12 | 59% | 80d | 2001-01-15 | 2001-10-12 | 195d | 818d | start no earlier than 2001-01-15 | S2 | 1560h | 920h |  | Kirk Burroughs, Qualcomm | WG | 2127 |  |  |  |  |  |
| 61 | 14 | **Security enhancements** | 935d | 2000-02-21 A | 2003-09-19 | 32% | 637.44d | 2000-02-21 | 2003-09-19 | 935d | 313d |  | S3 | 31664h | 10907.8h | SEC1 | Peter Howard, Vodafone | TSG |  | Peter.Howard@vodafone.com | NA | Maurice |  |  |
| 62 | 14.1 | **Enhanced HE control of security (including positive authentication reporting)** | 573d | 2001-01-03 A | 2003-03-14 | 24% | 434.2d | 2001-01-03 | 2003-03-14 | 573d | 448d |  | S3 | 11296h | 3606.41h |  | Peter Howard, Vodafone |  | 2026 | Peter.Howard@vodafone.com | Rel-6 |  |  |  |
| 63 | 14.1.1 | Stage 2 | 378d | 2001-01-03 | 2002-06-14 |  |  | 2001-01-03 | 2002-06-14 | 378d | 643d | finish no earlier than 2002-06-14 | S3 | 3024h |  |  |  |  | 2027 |  |  |  |  |  |
| 64 | 14.1.2 | FS on Network impacts | 71d | 2002-12-06 | 2003-03-14 |  |  | 2002-12-06 | 2003-03-14 | 71d | 448d | finish no earlier than 2003-03-14 | N4 | 568h |  |  |  |  | 2028 |  |  |  |  |  |
| 65 | 14.1.3 | **Network domain security** | 195d | 2002-06-17 A | 2003-03-14 | 80% | 39d | 2002-06-17 | 2003-03-14 | 195d | 448d |  | S3 | 3120h | 2496h | SEC1-NDS | Geir M. Køien, Telenor | TSG |  | Geir-myrdahl.koien@telenor.com | Rel-6 |  | Sec |  |
| 66 | 14.1.3.1 | IP network layer security (NDS/IP) | 195d | 2002-06-17 A | 2003-03-14 | 80% | 39d | 2002-06-17 | 2003-03-14 | 195d | 448d | finish no earlier than 2003-03-14 | S3 | 1560h | 1248h | SEC1-NDS-IP |  | WG |  |  | Rel-6 |  |  | TS 33.210 |
| 67 | 14.2 | **Rel-6 MAP application layer security** | 935d | 2000-02-21 A | 2003-09-19 | 38% | 578d | 2000-02-21 | 2003-09-19 | 935d | 313d |  | S3 | 12888h | 4920.87h | SEC1-MAPAL |  | TSG |  |  | Rel-6 |  | Sec |  |
| 68 | 14.2.1 | Main aspects | 510d | 2000-02-21 A | 2002-06-07 | 50% | 255d | 2000-02-21 | 2002-06-07 | 510d | 648d | start no earlier than 2000-02-21 | S3 | 4080h | 2040h | SEC1-MAPAL |  | WG | 1584 |  |  |  | Sec |  |
| 69 | 14.2.2 | Security signalling flows for the Ze interface | 260d | 2002-09-23 A | 2003-09-19 | 15% | 221d | 2002-09-23 | 2003-09-19 | 260d | 313d | finish no earlier than 2002-12-06 | N4 | 2080h | 312h | SEC1-MAPAL |  | TSG | 2025 |  |  |  | Sec |  |
| 70 | 16 | **IMS Phase 2** | 1034d? | 2000-01-03 A | 2003-12-18 | 39% | 631.24d? | 2000-01-03 | 2003-12-18 | 1034d? | 249d |  | S1 | 108624h | 39952h | IMS2 |  |  |  |  | Rel-6 | Alain |  |  |
| 71 | 16.1 | Stage 2 of IMS Phase 2 | 205d | 2002-09-02 A | 2003-06-13 | 54% | 95d | 2002-09-02 | 2003-06-13 | 205d | 383d | finish no earlier than 2003-06-13 | S2 | 1640h | 880h |  |  |  |  |  |  |  |  |  |
| 72 | 16.2 | IMS Stage-3 Enhancements | 261d | 2002-09-20 A | 2003-09-19 | 2% | 255.78d | 2002-09-20 | 2003-09-19 | 261d | 313d | finish no earlier than 2003-09-19 | N1 | 2088h | 41.76h | IMS-CCR-E | Keith Drage, Lucent |  |  | drage@lucent.com |  |  |  |  |
| 73 | 12.3 | **Identity portability in IMS** | 970d? | 2000-01-03 | 2003-09-19 |  |  | 2000-01-03 | 2003-09-19 | 970d? | 313d |  | N1 | 9856h |  |  |  |  |  |  |  |  |  |  |
| 74 | 12.3.1 | No stage 1, no stage 2 (6 months needed for st 2)? | 1d? | 2000-01-03 | 2000-01-03 |  |  | 2000-01-03 | 2000-01-03 | 1d? | 1282d |  | S2 | 8h |  |  |  |  |  |  |  |  |  |  |
| 75 | 12.3.2 | Stage 3 | 261d? | 2002-09-20 | 2003-09-19 |  |  | 2002-09-20 | 2003-09-19 | 261d? | 313d | finish no earlier than 2003-09-19 | N1 | 2088h |  |  |  |  |  |  |  |  |  |  |
| 76 | 16.12 | **IMS Group Management** | 397d? | 2002-03-14 A | 2003-09-19 | 27% | 290.78d? | 2002-03-14 | 2003-09-19 | 397d? | 313d |  | S1 | 7504h | 2007.77h | IMSGM | Juha Kalliokulju (Nokia) | TSG |  | juha.kalliokulju@nokia.com |  |  |  |  |
| 77 | 16.12.1 | Stage 1 - TS on IMS group management | 193d | 2002-03-14 A | 2002-12-09 | 75% | 48.25d | 2002-03-14 | 2002-12-09 | 193d | 517d | finish no earlier than 2002-12-09 | S1 | 1544h | 1158h |  | Juha Kalliokulju (Nokia) | TSG |  | juha.kalliokulju@nokia.com |  |  |  |  |
| 78 | 12.4.2 | Stage 2 | 87d? | 2003-02-27 | 2003-06-27 |  |  | 2003-02-27 | 2003-06-27 | 87d? | 373d | finish no earlier than 2003-06-27 | S2 | 696h |  |  |  |  |  |  |  |  |  |  |
| 79 | 12.4.3 | Stage 3 for IMS Group management (e.g. chat) | 261d? | 2002-09-20 | 2003-09-19 |  |  | 2002-09-20 | 2003-09-19 | 261d? | 313d | finish no earlier than 2003-09-19 | N1 | 2088h |  |  |  |  |  |  |  |  |  |  |
| 80 | 12.5 | **IMS Conferencing** | 261d? | 2002-09-20 A | 2003-09-19 | 19% | 212.55d? | 2002-09-20 | 2003-09-19 | 261d? | 313d |  | N1 | 5288h | 981.53h |  |  |  |  |  |  |  |  |  |
| 81 | 12.5.1 | Stage 2 | 170d? | 2002-11-04 A | 2003-06-27 | 47% | 90d? | 2002-11-04 | 2003-06-27 | 170d? | 373d | finish no earlier than 2003-06-27 | S2 | 1360h | 640h |  |  |  |  |  |  |  |  |  |
| 82 | 12.5.2 | Stage 3 | 261d? | 2002-09-20 | 2003-09-19 |  |  | 2002-09-20 | 2003-09-19 | 261d? | 313d | start no earlier than 2002-09-20 | N1 | 2088h |  |  |  |  |  |  |  |  |  |  |

Notes:
- 61: Added BB UE authentication and rapporteur added.
- 62: Added by P-000575 without any dates. 18/10/00: Change of WI title, added hyperlink rapporteur new end date 03/01. New end date and correct Release to be decided S3#18
- 63: New end date and correct Release to be decided S3#18
- 64: 15/11/2002 CN4: Waiting for input from SA3!
- 65: WID approved for Rel-6 at SA#17
- 66: Should be complete after SA3#27
- 67: TO DELETE: REPLACED BY NDS-MAP and NDS-IP. TO BE DELETED, but replacement NDS-MAP was missing
- 68: ??
- 69: 17 May Requirements under analysis in CN4. End date not yet determined. / 02/08/2002 CN4: CN4 is waiting WID in CN4#17. Revised version of N4-020624 / 15/11/2003 CN4: The first draft will be present in C4#18 target CN#21
- 70: Not yet available: verbally approved at SA15, actual WID to be provided at SA16 by Lucent

| ID | WBS | Task | Duration | Start | Finish | Complete | Remaining | Baseline start | Baseline finish | Baseline duration | Total slack | Constraint | Resources | Work | Actual work | Text1 | Text4 | Text5 | Text7 | Text3 | Text2 | Text9 |
| --- | --- | --- | --- | --- | --- | --- | --- | --- | --- | --- | --- | --- | --- | --- | --- | --- | --- | --- | --- | --- | --- | --- |
| 83 | 12.6 | **PSS alignment to IMS** | 261d? | 2002-09-20 | 2003-09-19 |  |  | 2002-09-20 | 2003-09-19 | 261d? | 313d |  | N1 | 4184h |  |  |  |  |  |  |  |  |
| 84 | 12.6.1 | Stage 2 for PSS - CHECK AT SA2 | 1d? | 2003-01-06 | 2003-01-06 |  |  | 2003-01-06 | 2003-01-06 | 1d? | 497d | start no earlier than 2003-01-06 | S2 | 8h |  |  |  |  |  |  |  |  |
| 85 | 12.6.2 | Stage 3 | 261d? | 2002-09-20 | 2003-09-19 |  |  | 2002-09-20 | 2003-09-19 | 261d? | 313d | start no earlier than 2002-09-20 | N1 | 2088h |  |  |  |  |  |  |  |  |
| 86 | 16.11 | **IMS Messaging** | 397d? | 2002-03-14 A | 2003-09-19 | 54% | 184.58d? | 2002-03-14 | 2003-09-19 | 397d? | 313d |  | S1 | 12560h | 7172.53h | IMSM | Juha Kalliokulju (Nokia) | juha.kalliokulju@nokia.com | TSG |  |  |  |
| 87 | 16.11.1 | TR on support of messaging in the IMS | 193d | 2002-03-14 A | 2002-12-09 A | 100% |  | 2002-03-14 | 2002-12-09 | 193d |  | finish no earlier than 2002-12-09 | S1 | 1544h | 1544h | IMSM-TR | Juha Kalliokulju (Nokia) | juha.kalliokulju@nokia.com | TSG |  |  |  |
| 88 | 12.7.2 | Stage 1 22.340 | 23d? | 2002-11-11 A | 2002-12-11 | 95% | 1.15d? | 2002-11-11 | 2002-12-11 | 23d? | 515d | finish no earlier than 2002-12-11 | S1 | 184h | 174.8h | IMSM-TS | Juha Kalliokulju (Nokia) | juha.kalliokulju@nokia.com | TSG | 22.340 |  |  |
| 89 | 16.11.2 | **CRs to existing 22-series specifications** | 263d? | 2002-03-14 A | 2003-03-17 | 75% | 65.75d? | 2002-03-14 | 2003-03-17 | 263d? | 447d |  | S1 | 4208h | 3156h | IMSM-CR | Juha Kalliokulju (Nokia) | juha.kalliokulju@nokia.com | TSG |  |  |  |
| 90 | 12.7.3.1 | CRs to 22.140 & 22.228 | 263d? | 2002-03-14 A | 2003-03-17 | 75% | 65.75d? | 2002-03-14 | 2003-03-17 | 263d? | 447d | finish no earlier than 2003-03-17 | S1 | 2104h | 1578h | IMSM-CR | Juha Kalliokulju (Nokia) | juha.kalliokulju@nokia.com | TSG | 22.140,22.228 |  |  |
| 91 | 16.11.3 | Stage 2 | 170d | 2002-11-04 A | 2003-06-27 | 44% | 95.2d | 2002-11-04 | 2003-06-27 | 170d | 373d | finish no earlier than 2003-06-27 | S2 | 1360h | 598.4h |  |  |  |  |  |  |  |
| 92 | 12.7.5 | Stage 3 for IMS Messaging | 261d? | 2002-09-20 | 2003-09-19 |  |  | 2002-09-20 | 2003-09-19 | 261d? | 313d | finish no earlier than 2003-09-19 | N1 | 2088h |  |  |  |  |  |  |  |  |
| 93 | 16.7 | **IMS Local services** | 710d? | 2001-01-01 A | 2003-09-19 | 55% | 316.23d? | 2001-01-01 | 2003-09-19 | 710d? | 313d |  | S2 | 10368h | 5192.02h |  |  |  |  | 23.228 |  |  |
| 94 | 16.7.1 | Stage 2 | 325d | 2001-01-01 A | 2002-03-29 A | 100% |  | 2001-01-01 | 2002-03-29 | 325d |  | start no earlier than 2001-01-01 | S2 | 2600h | 2600h |  |  |  |  |  |  |  |
| 95 | 12.8.2 | Stage 3 for IMS Local services | 261d? | 2002-09-20 | 2003-09-19 |  |  | 2002-09-20 | 2003-09-19 | 261d? | 313d | finish no earlier than 2003-09-19 | N1 | 2088h |  |  |  |  |  |  |  |  |
| 96 | 12.9 | **Additional SIP Capabilities support not covered by Rel-5** | 261d? | 2002-09-20 A | 2003-09-19 | 18% | 215.05d? | 2002-09-20 | 2003-09-19 | 261d? | 313d |  | N1 | 5208h | 916.9h |  |  |  |  |  |  |  |
| 97 | 12.9.1 | Stage 2 for add SIP cap (e.g. forking) | 165d? | 2002-11-11 A | 2003-06-27 | 45% | 90d? | 2002-11-11 | 2003-06-27 | 165d? | 373d | start no earlier than 2002-11-11 | S2 | 1320h | 600h |  |  |  |  |  |  |  |
| 98 | 12.9.2 | Stage 3 for Additional SIP Capabilities | 261d? | 2002-09-20 | 2003-09-19 |  |  | 2002-09-20 | 2003-09-19 | 261d? | 313d | finish no earlier than 2003-09-19 | N1 | 2088h |  |  |  |  |  |  |  |  |
| 99 | 12.10 | Review additional SIP Capabilities against IMS | 261d? | 2002-09-20 | 2003-09-19 |  |  | 2002-09-20 | 2003-09-19 | 261d? | 313d | finish no earlier than 2003-09-19 | N1 | 2088h |  |  |  |  |  |  |  |  |
| 100 | 16.5 | **Interworking between IMS and IP networks** | 675d | 2000-08-28 A | 2003-03-28 | 35% | 442.12d | 2000-08-28 | 2003-03-28 | 675d | 438d |  | N3 | 16200h | 5846h | IMS-CCR-IWIP | Nigel Holland, BT | nigel.holland@bt.com | TSG | 23.821, 29.061, 29.162 | BaAS | 2048 |
| 101 | 16.5.1 | Interworking for 3GPP_SIP and IETF_SIP | 675d | 2000-08-28 A | 2003-03-28 | 59% | 276.75d | 2000-08-28 | 2003-03-28 | 675d | 438d | finish no earlier than 2003-03-28 | N3 | 5400h | 3186h |  | Thomas Belling, Siemens |  |  | New TR 2x.abc |  |  |
| 102 | 16.5.2 | Interworking for IPv6 to IPv4 | 675d | 2000-08-28 A | 2003-03-28 | 10% | 607.5d | 2000-08-28 | 2003-03-28 | 675d | 438d | finish no earlier than 2003-03-28 | N3 | 5400h | 540h |  |  |  |  | 29.163 |  |  |
| 103 | 16.8 | **Mm interface (CSCF to external IP multimedia network)** | 389d | 2001-03-14 A | 2002-09-09 | 71% | 112.81d | 2001-03-14 | 2002-09-09 | 389d | 582d |  | N3 | 6224h | 2209.52h |  |  |  |  |  |  |  |
| 104 | 16.8.1 | CN1 part | 389d | 2001-03-14 A | 2002-09-09 | 71% | 112.81d | 2001-03-14 | 2002-09-09 | 389d | 582d | finish no earlier than 2002-09-09 | N1 | 3112h | 2209.52h |  |  |  |  |  |  |  |
| 105 | 16.6 | **Interworking between IMS and CS networks** | 595d | 2000-08-28 A | 2002-12-06 | 60% | 238d | 2000-08-28 | 2002-12-06 | 595d | 518d |  | N3 | 11456h | 6873.6h | IMS-CCR-IWCS | David Sanders, Vodafone | dave.sanders@vf.vodafone.co.uk | TSG | 29.163, 29.061, 24.228, and new CN4 specification | CCaR | 1305 |
| 106 | 16.6.1 | ITU-T Q.1912.SIP (SIP to BICC / ISUP interworking) | 595d | 2000-08-28 A | 2002-12-06 | 60% | 238d | 2000-08-28 | 2002-12-06 | 595d | 518d | finish no earlier than 2002-12-06 | N3 | 4760h | 2856h |  |  |  |  |  |  |  |
| 107 | 16.6.2 | ITU-T dependency on Q.2150.3 (SCTP) | 595d | 2000-08-28 A | 2002-12-06 | 60% | 238d | 2000-08-28 | 2002-12-06 | 595d | 518d | finish no earlier than 2002-12-06 | N3 | 4760h | 2856h |  |  |  |  |  |  |  |

Notes:
- 100: [DAB 14.02.02] - end date pushed back to March 2003
- 101: [DAB - 14.02.02] - Need for new TR underinvestigation by CN3
- 102: [DAB - 14.02.02] - Requirements still not clear from SA2
- 106: [DAB - 17.05.02] - estimated ITU delivery date pushed to Dec. 2002
- 107: [DAB - 17.05.02] - estimated ITU delivery date pushed to Dec. 2002

| ID | WBS | Task | Duration | Start | Finish | Complete | Remaining | Baseline start | Baseline finish | Baseline duration | Total slack | Constraint | Resources | Work | Actual work | Text1 | Text4 | Text5 | Text6 | Text7 | Text8 | Text2 | Text9 | Text3 |
| --- | --- | --- | --- | --- | --- | --- | --- | --- | --- | --- | --- | --- | --- | --- | --- | --- | --- | --- | --- | --- | --- | --- | --- | --- |
| 108 | 16.9 | **Mg interface (BGCF to MGCF - interworking with CS)** | 371d | 2001-04-09 A | 2002-09-09 A | 100% |  | 2001-04-09 | 2002-09-09 | 371d |  |  | N3 | 5936h | 5936h |  |  |  |  |  |  |  |  |  |
| 109 | 16.9.1 | Mg interface (BGCF to MGCF - interworking with CS) | 371d | 2001-04-09 A | 2002-09-09 A | 100% |  | 2001-04-09 | 2002-09-09 | 371d |  | finish no earlier than 2002-06-07 | N1 | 2968h | 2968h |  |  |  |  |  |  |  |  |  |
| 110 | 16.10 | Mn interface (IM-MGW to MGCF) enhancements | 200d | 2002-09-02 A | 2003-06-06 | 30% | 140d | 2002-09-02 | 2003-06-06 | 200d | 388d | finish no earlier than 2003-06-06 | N4 | 1600h | 480h | IMS-CCR-Mn | Peter Schmitt, Siemens |  |  |  |  |  |  |  |
| 111 | 12.16 | Mp (MRFC - MRFP) interface protocol definitions | 175d? | 2002-10-07 A | 2003-06-06 | 17% | 145.25d? | 2002-10-07 | 2003-06-06 | 175d? | 388d | finish no earlier than 2003-06-06 | N4 | 1400h | 238h | IMS-CCR-Mp | David Sanders, Vodafone |  |  |  |  |  |  |  |
| 112 | 12.17 | Study of subscriber and operators relationship in IMS and related ISIM requirements for Rel 6” | 20d? | 2002-11-15 A | 2002-12-12 | 75% | 5d? | 2002-11-15 | 2002-12-12 | 20d? | 514d | finish no earlier than 2002-12-12 | S1 | 160h | 120h |  | Juha Kalliokulju (Nokia) | juha.kalliokulju@nokia.com |  |  |  |  |  |  |
| 113 | 12.18 | Lawful Interception in the 3GPP Rel-6 architecture | 269d? | 2002-12-09 | 2003-12-18 |  |  | 2002-12-09 | 2003-12-18 | 269d? | 249d | finish no earlier than 2003-12-18 | S3 | 2152h |  |  | Berthold Wilhelm |  |  |  |  |  |  |  |
| 114 | 16.4 | Radio optimisation impacts on PS domain architecture | 465d | 2001-12-10 A | 2003-09-19 | 63% | 170d | 2001-12-10 | 2003-09-19 | 465d | 160d | finish no earlier than 2003-04-25 | S2 | 3720h | 2360h |  |  |  | Rel-6 | TSG | Alain |  |  |  |
| 115 | 16.3 | **Interoperability and Commonality between IMS using different "IP-connectivity Networks"** | 257d | 2002-09-16 A | 2003-09-09 | 28% | 184.56d | 2002-09-16 | 2003-09-09 | 257d | 321d |  | N1 | 5632h | 1587.54h | IMSCOOP | Keith Drage, Lucent | drage@lucent.com | Rel-6 |  | Alain |  |  |  |
| 116 | 16.3.1 | Stage 2 | 210d | 2002-09-16 A | 2003-07-04 | 60% | 84d | 2002-09-16 | 2003-07-04 | 210d | 368d | finish no earlier than 2003-02-20 | S2 | 1680h | 1008h |  | Balazs Beternyi, Nokia |  |  |  |  |  |  |  |
| 117 | 16.3.2 | Stage 3 | 237d | 2002-10-14 | 2003-09-09 |  |  | 2002-10-14 | 2003-09-09 | 237d | 321d | finish no earlier than 2003-09-09 | N1 | 1896h |  |  |  |  |  |  |  |  |  |  |
| 118 | 17 | **Support of Push Services** | 708d | 2001-01-03 A | 2003-09-19 | 78% | 157.65d | 2001-01-03 | 2003-09-19 | 708d | 313d |  | S1 | 10974.6h | 4856.8h | PUSH | Yoshinori Kitada, NTT Comware |  | Rel-6 | TSG | Alain | CCaR | 1365 |  |
| 119 | 17.1 | Stage 1 | 378d | 2001-01-03 A | 2002-06-14 | 95% | 18.9d | 2001-01-03 | 2002-06-14 | 378d | 643d | finish no earlier than 2002-06-14 | S1 | 3024h | 2872.8h |  |  |  |  |  |  |  |  |  |
| 120 | 17.2 | TR on feasibility study | 178d | 2001-01-03 A | 2001-09-07 A | 100% |  | 2001-01-03 | 2001-09-07 | 178d |  | finish no earlier than 2001-09-07 | S2 | 1424h | 1424h |  |  |  |  |  |  |  |  |  |
| 121 | 17.3 | Stage 2 | 225d | 2002-11-11 A | 2003-09-19 | 31% | 155d | 2002-11-11 | 2003-09-19 | 225d | 313d | finish no earlier than 2003-05-23 | S2 | 1800h | 560h |  |  |  |  |  |  |  |  |  |
| 122 | 18 | **Multimedia Messaging (MMS) enhancements** | 217d? | 2002-08-15 A | 2003-06-13 | 11% | 193.64d? | 2002-08-15 | 2003-06-13 | 217d? | 383d |  | T2 | 9360h | 1481.71h | MMS6 | Josef Laumen, Siemens | Josef.Laumen@SAL.SIEMENS.DE | Rel-6 | TSG | Friedhelm | Mes |  |  |
| 123 | 18.1 | **Definition of service requirements** | 151d? | 2002-11-15 A | 2003-06-13 | 50% | 75.5d? | 2002-11-15 | 2003-06-13 | 151d? | 383d |  | S1 | 2416h | 1208h |  | Josef Laumen, Siemens | Josef.Laumen@SAL.SIEMENS.DE |  |  |  |  |  | 22.140 |
| 124 | 16.1.1 | Definition of service requirements charging | 151d? | 2002-11-15 A | 2003-06-13 | 50% | 75.5d? | 2002-11-15 | 2003-06-13 | 151d? | 383d | finish no earlier than 2003-06-13 | S1 | 1208h | 604h |  | Josef Laumen, Siemens | Josef.Laumen@SAL.SIEMENS.DE |  |  |  |  |  | 22.140 |
| 125 | 18.2 | Technical realization | 217d | 2002-08-15 A | 2003-06-13 | 5% | 206.15d | 2002-08-15 | 2003-06-13 | 217d | 383d | finish no earlier than 2003-06-13 | T2 | 1736h | 86.8h |  | Josef Laumen, Siemens | Josef.Laumen@SAL.SIEMENS.DE |  |  |  |  |  | 23.140 |
| 126 | 18.3 | OMA dependencies | 217d | 2002-08-15 | 2003-06-13 |  |  | 2002-08-15 | 2003-06-13 | 217d | 383d | finish no earlier than 2003-06-13 | T2 | 1736h |  |  |  |  |  |  |  |  |  |  |
| 127 | 18.4 | MMS formats and codecs | 217d | 2002-08-15 | 2003-06-13 |  |  | 2002-08-15 | 2003-06-13 | 217d | 383d | finish no earlier than 2003-06-13 | S4 | 1736h |  |  |  |  |  |  |  |  |  | 26.140 |
| 128 | 19 | **Rel-6 MExE enhancements** | 331d | 2002-03-08 A | 2003-06-13 | 95% | 16.68d | 2002-03-08 | 2003-06-13 | 331d | 383d |  | T2 | 7904h | 7505.79h | MEXE6 |  |  | Rel-6 | TSG | Friedhelm | Ter |  |  |
| 129 | 19.1 | MExE Rel-6 Improvements and Investigations | 331d | 2002-03-08 A | 2003-06-13 | 90% | 33.1d | 2002-03-08 | 2003-06-13 | 331d | 383d | finish no earlier than 2003-06-13 | T2 | 2648h | 2383.2h | MEXE6-ENHANC | Lars Brenk (TTPCom) | lsb_ttpcom@HOTMAIL.COM |  | TSG |  | Ter |  | 22.057, 23.057 |
| 130 | 19.2 | MExE Run-Time Independent Framework Feasibility Study | 326d | 2002-03-08 A | 2003-06-06 A | 100% |  | 2002-03-08 | 2003-06-06 | 326d |  | finish no earlier than 2003-06-06 | T2 | 2608h | 2608h | MEXE6-RTIF | Aaron Cohen (Intel) | Aaron.Cohen@intel.com |  | TSG |  | Ter |  | 22.857 |
| 131 | 21 | Subscription Management | 715d | 2000-12-29 A | 2003-09-25 | 30% | 500.5d | 2000-12-29 | 2003-09-25 | 715d | 156d | finish no earlier than 2003-09-25 | S5 | 5720h | 1716h | SM | Michael Eder (Nokia) | michael.eder@nokia.com | Rel-6 | TSG | Adrian |  |  | 32.140, 32.141 |

Notes:
- 110: 17th May 2002, CN4; Will be handled in Rel-6 / 02/08/2002 CN4: WID approved at CN4#15 (N4-020997) / 01/09/2002 KK: WID approved at CN#17 (NP-020494) / 15/11/2002CN4: Target will be CN#20 (NP-020600)
- 111: 27/11/2002 KK: WID approved at CN#18 (NP-020601) / 27/11/2002CN4: Target will be CN#20
- 118: AS: Changed from FS to actual support of Push
- 120: Stage 2 on hold, waiting for requirements.

| ID | WBS | Task | Duration | Start | Finish | Complete | Remaining | Baseline start | Baseline finish | Baseline duration | Total slack | Constraint | Resources | Work | Actual work | Text1 | Text4 | Text6 | Text7 | Text8 | Text9 | Text5 |
| --- | --- | --- | --- | --- | --- | --- | --- | --- | --- | --- | --- | --- | --- | --- | --- | --- | --- | --- | --- | --- | --- | --- |
| 132 | 22 | **Support of Presence Capability** | 610d | 2001-03-19 A | 2003-07-18 | 73% | 166.93d | 2001-03-19 | 2003-06-04 | 578d | 358d |  | S1 | 16224h | 11784.1h | PRESNC | Mark Cataldo, Motorola | Rel-6 | TSG | Michael | 11004 |  |
| 133 | 22.1 | Stage 1 | 610d | 2001-03-19 A | 2003-07-18 | 95% | 30.5d | 2001-03-19 | 2001-07-18 | 88d | 358d | finish no earlier than 2003-07-18 | S1 | 4880h | 4636h |  |  |  |  |  | 11005 |  |
| 134 | 22.2 | Stage 2 | 268d | 2001-09-12 A | 2002-09-20 A | 100% |  | 2001-09-12 | 2002-09-20 | 268d |  | finish no earlier than 2002-09-20 | S2 | 2144h | 2144h |  |  |  | TSG |  |  |  |
| 135 | 22.3 | Stage 3 | 303d | 2002-04-08 A | 2003-06-04 | 55% | 136.35d | 2002-04-08 | 2003-06-04 | 303d | 390d | finish no earlier than 2003-06-04 | N1 | 2424h | 1333.2h |  | Keith Drage, Lucent |  |  |  |  | drage@lucent.com |
| 136 | 22.4 | Security issues | 79d | 2002-08-26 A | 2002-12-12 | 20% | 63.2d | 2002-08-26 | 2002-12-12 | 79d | 514d | finish no earlier than 2002-12-12 | S3 | 632h | 126.4h |  |  |  |  |  |  |  |
| 137 | 22.5 | USIM issues | 79d | 2002-03-04 | 2002-06-20 |  |  | 2002-03-04 | 2002-06-20 | 79d | 639d | start no earlier than 2002-03-04 | T3 | 632h |  |  |  |  |  |  |  |  |
| 138 | 22.6 | UE issues | 79d | 2002-03-04 | 2002-06-20 |  |  | 2002-03-04 | 2002-06-20 | 79d | 639d | start no earlier than 2002-03-04 | T2 | 632h |  |  |  |  |  |  |  |  |
| 139 | 25 | **Enhanced A/Gb feasibility study** | 51d? | 2002-08-30 A | 2002-11-08 | 75% | 12.75d? | 2002-08-30 | 2002-11-08 | 51d? | 538d |  | GP | 4080h | 3162h | AGbEnFS | J-L Carrizo, Vodafone | TBD | TSG | Paolo |  | jose-luis.carrizo@vodafone.co.uk |
| 140 | 25.1 | **Feasibility study on A/Gb enhancements** | 51d? | 2002-08-30 A | 2002-11-08 | 75% | 12.75d? | 2002-08-30 | 2002-11-08 | 51d? | 538d |  | G2 | 3672h | 2856h | AGbEnFS-FS |  |  | TSG |  |  |  |
| 141 | 25.1.1 | Requirements for the support of conversational services | 51d | 2002-08-30 A | 2002-11-08 A | 100% |  | 2002-08-30 | 2002-11-08 | 51d |  | finish no earlier than 2002-11-08 | GP | 408h | 408h |  |  |  |  |  |  |  |
| 142 | 20.1.2 | Identification of the different building blocks for the provision of conversational services on the existing A/Gb protocol stack | 51d? | 2002-08-30 A | 2002-11-08 A | 100% |  | 2002-08-30 | 2002-11-08 | 51d? |  | finish no earlier than 2002-11-08 | GP | 408h | 408h |  |  |  |  |  |  |  |
| 143 | 20.1.3 | Outline of impact and feasibility of these building blocks and their different solutions | 51d? | 2002-08-30 A | 2002-11-08 A | 100% |  | 2002-08-30 | 2002-11-08 | 51d? |  | finish no earlier than 2002-11-08 | GP | 408h | 408h |  |  |  |  |  |  |  |
| 144 | 25.1.2 | Identification of the different building blocks for the provision of conversational services on the existing A/Gb protocol stack | 51d | 2002-08-30 | 2002-11-08 |  |  | 2002-08-30 | 2002-11-08 | 51d | 538d | finish no earlier than 2002-11-08 | G2 | 408h |  |  |  |  |  |  |  |  |
| 145 | 25.1.3 | Outline of impact and feasibility of these building blocks and their different solutions | 51d | 2002-08-30 | 2002-11-08 |  |  | 2002-08-30 | 2002-11-08 | 51d | 538d | finish no earlier than 2002-11-08 | G2 | 408h |  |  |  |  |  |  |  |  |
| 146 | 25.1.4 | Impact on 3GPP architecture and requirement to co-ordinatge with other TSGs (CN, SA) | 51d | 2002-08-30 A | 2002-11-08 A | 100% |  | 2002-08-30 | 2002-11-08 | 51d |  | finish no earlier than 2002-11-08 | GP | 408h | 408h |  |  |  |  |  |  |  |
| 147 | 25.1.5 | Standardisation effort | 51d | 2002-08-30 A | 2002-11-08 A | 100% |  | 2002-08-30 | 2002-11-08 | 51d |  | finish no earlier than 2002-11-08 | GP | 408h | 408h |  |  |  |  |  |  |  |
| 148 | 25.1.6 | Dependency to other features | 51d | 2002-08-30 A | 2002-11-08 A | 100% |  | 2002-08-30 | 2002-11-08 | 51d |  | finish no earlier than 2002-11-08 | GP | 408h | 408h |  |  |  |  |  |  |  |
| 149 | 26 | **Flexible Layer One for GERAN** | 910d? | 2000-01-03 A | 2003-06-27 | 31% | 623.63d? | 2000-01-03 | 2003-06-27 | 910d? | 373d |  | GP | 58255h | 16325.4h | FLOGER | Benoist Sébire | TBD |  | Paolo |  | benoist.sebire@nokia.com |
| 150 | 26.1 | **Realisation of a Flexible Layer One** | 910d | 2000-01-03 A | 2003-06-27 | 40% | 546d | 2000-01-03 | 2003-06-27 | 910d | 373d |  | GP | 29488h | 11795.2h | FLOGER-Real | Benoist Sébire |  |  |  |  | benoist.sebire@nokia.com |
| 151 | 26.1.1 | Technical Report | 311d | 2002-04-19 A | 2003-06-27 | 40% | 186.6d | 2002-04-19 | 2003-06-27 | 311d | 373d | finish no earlier than 2003-06-27 | GP | 2488h | 995.2h |  |  |  |  |  |  |  |
| 152 | 26.1.2 | Architecture in 45.001 and 43.051 | 311d | 2002-04-19 A | 2003-06-27 | 40% | 186.6d | 2002-04-19 | 2003-06-27 | 311d | 373d | finish no earlier than 2003-06-27 | G1 | 2488h | 995.2h |  |  |  |  |  |  |  |
| 153 | 26.1.3 | Multiplexing in 45.002 | 311d | 2002-04-19 A | 2003-06-27 | 40% | 186.6d | 2002-04-19 | 2003-06-27 | 311d | 373d | finish no earlier than 2003-06-27 | G1 | 2488h | 995.2h |  |  |  |  |  |  |  |
| 154 | 26.1.4 | Channel Coding in 45.003 | 311d | 2002-04-19 A | 2003-06-27 | 40% | 186.6d | 2002-04-19 | 2003-06-27 | 311d | 373d | finish no earlier than 2003-06-27 | G1 | 2488h | 995.2h |  |  |  |  |  |  |  |
| 155 | 26.1.5 | Performance Requirements in 45.005 | 910d | 2000-01-03 A | 2003-06-27 | 40% | 546d | 2000-01-03 | 2003-06-27 | 910d | 373d | finish no earlier than 2003-06-27 | G1 | 7280h | 2912h |  |  |  |  |  |  |  |
| 156 | 26.1.6 | Radio subsystem link control in 45.008 | 311d | 2002-04-19 A | 2003-06-27 | 40% | 186.6d | 2002-04-19 | 2003-06-27 | 311d | 373d | finish no earlier than 2003-06-27 | G1 | 2488h | 995.2h |  |  |  |  |  |  |  |
| 157 | 26.1.7 | Requirements in 44.004 | 311d | 2002-04-19 A | 2003-06-27 | 40% | 186.6d | 2002-04-19 | 2003-06-27 | 311d | 373d | finish no earlier than 2003-06-27 | G2 | 2488h | 995.2h |  |  |  |  |  |  |  |

Notes:
- 132: A Sultan merged "Presence Service Enhancements" (UID31028, PRES1) to this feature as no answer was provided on why Presence and Presence Encmts had same target completion date
- 136: LSs handled in SA3. WID approved SA#17 Contribution at S3#25 & following e-mail discussion.
- 139: Closed
- 149: Nokia, Ericsson, Siemens, Telia
- 150: Started

| ID | WBS | Task | Duration | Start | Finish | Complete | Remaining | Baseline start | Baseline finish | Baseline duration | Total slack | Constraint | Resources | Work | Actual work | Text1 | Text4 | Text5 | Text3 | Text6 | Text8 | Text9 | Text7 |
| --- | --- | --- | --- | --- | --- | --- | --- | --- | --- | --- | --- | --- | --- | --- | --- | --- | --- | --- | --- | --- | --- | --- | --- |
| 158 | 26.2 | **Signalling and protocol support for a Flexible Layer One** | 311d | 2002-04-19 A | 2003-06-27 | 30% | 217.7d | 2002-04-19 | 2003-06-27 | 311d | 373d |  | G2 | 7464h | 2239.2h | FLOGER-SigPro | Benoist Sébire | benoist.sebire@nokia.com |  |  |  |  |  |
| 159 | 26.2.1 | Modifications to RLC/MAC in 44.060 and 44.160 | 311d | 2002-04-19 A | 2003-06-27 | 30% | 217.7d | 2002-04-19 | 2003-06-27 | 311d | 373d | finish no earlier than 2003-06-27 | G2 | 2488h | 746.4h |  |  |  |  |  |  |  |  |
| 160 | 26.2.2 | Modifications to RRC in 44.118 and 44.018 | 311d | 2002-04-19 A | 2003-06-27 | 30% | 217.7d | 2002-04-19 | 2003-06-27 | 311d | 373d | finish no earlier than 2003-06-27 | G2 | 2488h | 746.4h |  |  |  |  |  |  |  |  |
| 161 | 26.3 | **Security for a Flexible Layer One** | 256d | 2002-04-19 | 2003-04-11 |  |  | 2002-04-19 | 2003-04-11 | 256d | 428d |  | S3, G2 | 4063.04h |  | FLOGER-SecFLO | Benoist Sébire | benoist.sebire@nokia.com |  |  |  |  |  |
| 162 | 26.3.1 | Ciphering in 44.160,44.118, 44.060 and 44.018 | 256d | 2002-04-19 | 2003-04-11 |  |  | 2002-04-19 | 2003-04-11 | 256d | 428d | finish no earlier than 2003-04-11 | S3, G2 | 2048h |  |  |  |  |  |  |  |  |  |
| 163 | 26.4 | **GERAN MS Conformance test for the Flexible Layer One** | 155.5d | 2002-11-22 | 2003-06-27 |  |  | 2002-11-22 | 2003-06-27 | 155.5d | 373d |  | G4; G5 | 4976h |  | FLOGER-Msconf | Benoist Sébire | benoist.sebire@nokia.com |  |  |  |  |  |
| 164 | 26.4.1 | MS Test in 51.010 | 155.5d | 2002-11-22 | 2003-06-27 |  |  | 2002-11-22 | 2003-06-27 | 155.5d | 373d | finish no earlier than 2003-06-27 | G4; G5 | 2488h |  |  |  |  |  |  |  |  |  |
| 165 | 21.5 | GERAN BTS Conformance test for the Flexible Layer One | 1d? | 2000-01-03 | 2000-01-03 |  |  | 2000-01-03 | 2000-01-03 | 1d? | 1282d |  | G3 | 8h |  | FLOGER-BTSconf | Benoist Sébire | benoist.sebire@nokia.com |  |  |  |  |  |
| 166 | 26.5 | **GERAN BTS Conformance test for the Flexible Layer One** | 311d | 2002-04-19 | 2003-06-27 |  |  | 2002-04-19 | 2003-06-27 | 311d | 373d |  | G3 | 4976h |  | FLOGER-BTSconf | Benoist Sébire | benoist.sebire@nokia.com |  |  |  |  |  |
| 167 | 26.5.1 | BTS Test in 51.021 | 311d | 2002-04-19 | 2003-06-27 |  |  | 2002-04-19 | 2003-06-27 | 311d | 373d | finish no earlier than 2003-06-27 | G3 | 2488h |  |  |  |  |  |  |  |  |  |
| 168 | 27 | Uplink TDOA feasibility study | 151d | 2001-11-30 A | 2002-06-28 A | 100% |  | 2001-11-30 | 2002-06-28 | 151d |  | finish no earlier than 2002-06-28 | GP | 1208h | 1208h | TDOAF | Bob Gross, TruePosition, Inc. | rlgross@trueposition.com | 45.811 | Rel-6 | Paolo |  |  |
| 169 | 28 | **Multimedia Broadcast and Multicast Service** | 616d | 2001-05-11 A | 2003-09-19 | 19% | 496.34d | 2001-05-11 | 2003-09-19 | 616d | 313d |  | S1 | 42601.6h | 7608.18h | MBMS |  |  |  | Rel-6 | Michael |  |  |
| 170 | 28.1 | Stage 1 | 232d | 2001-05-11 A | 2002-04-01 | 99% | 2.32d | 2001-05-11 | 2002-04-01 | 232d | 697d | finish no earlier than 2002-04-01 | S1 | 1856h | 1837.44h |  |  |  | 22.146, 22.101 |  |  | 11003 |  |
| 171 | 28.2 | **Stage 2** | 520d | 2001-09-24 A | 2003-09-19 | 71% | 148.57d | 2001-09-24 | 2003-09-19 | 520d | 313d |  | S2 | 8360h | 4324.8h |  |  |  |  |  |  |  | TSG |
| 172 | 28.2.1 | TR on Architectural Study | 240d | 2001-09-24 A | 2002-08-23 A | 100% |  | 2001-09-24 | 2002-08-23 | 240d |  | finish no earlier than 2002-08-23 | S2 | 1920h | 1920h |  |  |  |  |  |  |  |  |
| 173 | 28.2.2 | Stage 2 Specification Work | 285d | 2002-08-19 A | 2003-09-19 | 47% | 150d | 2002-08-19 | 2003-09-19 | 285d | 313d | finish no earlier than 2003-06-06 | S2 | 2280h | 1080h |  |  |  |  |  |  |  |  |
| 174 | 28.3 | Introduction of MBMS in RAN | 379d | 2002-01-01 A | 2003-06-13 | 15% | 322.15d | 2002-01-01 | 2003-06-13 | 379d | 383d | finish no earlier than 2003-06-13 | R2 | 3032h | 454.8h | MBMS-RAN | Dimitris Koulakiotis, Nokia |  |  |  |  | 2481 | TSG |
| 175 | 28.4 | Support of the MBMS in CN protocols | 321d | 2002-06-18 A | 2003-09-09 | 2% | 314.58d | 2002-06-18 | 2003-09-09 | 321d | 321d | finish no earlier than 2003-09-09 | N1 | 2568h | 51.36h |  |  |  |  |  |  |  | TSG |
| 176 | 28.5 | Security Aspects of Multimedia Broadcast/Multicast Service (MBMS) | 175d | 2002-07-01 A | 2003-02-28 | 20% | 140d | 2002-07-01 | 2003-02-28 | 175d | 458d | finish no earlier than 2003-02-28 | S3 | 1400h | 280h | MBMS | Escott, Adrian, Hutchison 3G UK | adrian.escott@hutchison3g.com |  |  |  |  | TSG |
| 177 | 28.6 | **Support of MBMS in GERAN** | 216d | 2002-08-30 A | 2003-06-27 | 3% | 209.13d | 2002-08-30 | 2003-06-27 | 216d | 373d |  | GP | 20736h | 659.78h | MBMS-GERAN |  |  |  | Rel-6 |  |  | TSG |
| 178 | 28.6.1 | Impact on the logical and physical channels | 216d | 2002-08-30 A | 2003-06-27 | 5% | 205.2d | 2002-08-30 | 2003-06-27 | 216d | 373d | finish no earlier than 2003-06-27 | GP | 1728h | 86.4h |  |  |  |  |  |  |  |  |
| 179 | 28.6.2 | Simultaneous support of MBMS services | 216d | 2002-08-30 | 2003-06-27 |  |  | 2002-08-30 | 2003-06-27 | 216d | 373d | finish no earlier than 2003-06-27 | G1 | 1728h |  |  |  |  |  |  |  |  |  |
| 180 | 28.6.3 | Simultaneous support of MBMS and non-MBMS services | 216d | 2002-08-30 | 2003-06-27 |  |  | 2002-08-30 | 2003-06-27 | 216d | 373d | finish no earlier than 2003-06-27 | G1 | 1728h |  |  |  |  |  |  |  |  |  |
| 181 | 28.6.4 | Re-synchronisation at cell change | 216d | 2002-08-30 | 2003-06-27 |  |  | 2002-08-30 | 2003-06-27 | 216d | 373d | finish no earlier than 2003-06-27 | G2 | 1728h |  |  |  |  |  |  |  |  |  |
| 182 | 28.6.5 | Decision making process between point-to-point or pont-to-multipoint configurations | 216d | 2002-08-30 A | 2003-06-27 | 5% | 205.2d | 2002-08-30 | 2003-06-27 | 216d | 373d | finish no earlier than 2003-06-27 | GP | 1728h | 86.4h |  |  |  |  |  |  |  |  |
| 183 | 28.6.6 | MBMS channel allocations procedures to multiple MSs | 216d | 2002-08-30 A | 2003-06-27 | 5% | 205.2d | 2002-08-30 | 2003-06-27 | 216d | 373d | finish no earlier than 2003-06-27 | GP | 1728h | 86.4h |  |  |  |  |  |  |  |  |
| 184 | 28.6.7 | Changes to the Gb interface | 216d | 2002-08-30 A | 2003-06-27 | 5% | 205.2d | 2002-08-30 | 2003-06-27 | 216d | 373d | finish no earlier than 2003-06-27 | GP | 1728h | 86.4h |  |  |  |  |  |  |  |  |
| 185 | 28.6.8 | GERAN specific changes to the Iu-ps interface | 216d | 2002-08-30 A | 2003-06-27 | 5% | 205.2d | 2002-08-30 | 2003-06-27 | 216d | 373d | finish no earlier than 2003-06-27 | GP | 1728h | 86.4h |  |  |  |  |  |  |  |  |
| 186 | 28.6.9 | Interaction between MBMS and Iu-flex | 216d | 2002-08-30 A | 2003-06-27 | 5% | 205.2d | 2002-08-30 | 2003-06-27 | 216d | 373d | finish no earlier than 2003-06-27 | GP | 1728h | 86.4h |  |  |  |  |  |  |  |  |
| 187 | 28.6.10 | Security aspects | 216d | 2002-08-30 A | 2003-06-27 | 5% | 205.2d | 2002-08-30 | 2003-06-27 | 216d | 373d | finish no earlier than 2003-06-27 | GP | 1728h | 86.4h |  |  |  |  |  |  |  |  |
| 188 | 28.6.11 | MS conformance tests | 216d | 2002-08-30 | 2003-06-27 |  |  | 2002-08-30 | 2003-06-27 | 216d | 373d | finish no earlier than 2003-06-27 | G5 | 1728h |  |  |  |  |  |  |  |  |  |

Notes:
- 158: Started
- 161: Started
- 163: Not started
- 165: Not started
- 169: Title renamed at SA#13
- 170: This may or may not be a separate stage 1. In the meantime, CRs are proposed for 22.101
- 176: WID approved SA#17

| ID | WBS | Task | Duration | Start | Finish | Complete | Remaining | Baseline start | Baseline finish | Baseline duration | Total slack | Constraint | Resources | Work | Actual work | Text1 | Text6 | Text7 | Text8 | Text3 | Text4 | Text5 |
| --- | --- | --- | --- | --- | --- | --- | --- | --- | --- | --- | --- | --- | --- | --- | --- | --- | --- | --- | --- | --- | --- | --- |
| 189 | 29 | **Speech Recognition and Speech Enabled Services** | 972d? | 2000-01-03 A | 2003-09-23 | 16% | 819.98d? | 2000-01-03 | 2003-09-23 | 972d? | 311d |  | S1 | 9096h | 1422.61h | SRSES | Rel-6 | TSG | Michael |  |  |  |
| 190 | 24.1 | Why Stage 1 work on DSR, Stage 2 does not work and SA4 runs a codec competition? | 1d? | 2000-01-03 | 2000-01-03 |  |  | 2000-01-03 | 2000-01-03 | 1d? | 1282d |  | S2 | 8h |  |  |  |  |  |  |  |  |
| 191 | 29.1 | Speech Enabled Services Based on Distributed Speech Recognition (DSR) | 115d | 2001-10-08 A | 2002-03-15 | 85% | 17.25d | 2001-10-08 | 2002-03-15 | 115d | 708d | finish no earlier than 2002-03-15 | S1 | 920h | 782h | DSR |  | TSG |  | 22.941, 23.207, 22.243 | D Williams, QUALCOMM, Inc. | Dwilliams@qualcomm.com |
| 192 | 29.2 | Stage 2 | 152d | 2003-02-24 | 2003-09-23 |  |  | 2003-02-24 | 2003-09-23 | 152d | 311d | start no earlier than 2003-02-24 | S2 | 1216h |  |  |  |  |  |  |  |  |
| 193 | 29.3 | SDP protocols extension to include DSR | 183d | 2002-09-23 | 2003-06-04 |  |  | 2002-09-23 | 2003-06-04 | 183d | 390d | finish no earlier than 2003-06-04 | N1 | 1464h |  |  |  |  |  |  |  |  |
| 194 | 24.5 | Codec Work to Support Speech Recognition Framework for Automated Voice Services | 174d? | 2002-10-15 | 2003-06-13 |  |  | 2002-10-15 | 2003-06-13 | 174d? | 383d | finish no earlier than 2003-06-13 | S4 | 1392h |  | SRSES-Codec |  | WG |  |  | David Pearce, Motorola |  |
| 195 | 30 | **Generic User Profile** | 437d | 2001-10-08 A | 2003-06-10 | 38% | 270.75d | 2001-10-08 | 2003-06-10 | 437d | 386d |  | S1 | 18143.8h | 6902.36h | GUP | Rel-6 | TSG | Michael |  |  |  |
| 196 | 30.1 | Stage 1 - Requirements | 306d | 2001-10-08 A | 2002-12-09 | 75% | 76.5d | 2001-10-08 | 2002-12-09 | 306d | 517d | finish no earlier than 2002-12-09 | S1 | 2448h | 1836h |  |  |  |  | 22.240, 22.228 | Paul Amery (Orange) | paul.amery@orange.co.uk |
| 197 | 30.2 | Stage 2 - Data description framework | 372d | 2001-10-08 A | 2003-03-11 | 40% | 223.2d | 2001-10-08 | 2003-03-11 | 372d | 451d | finish no earlier than 2003-03-11 | T2 | 2976h | 1190.4h |  |  | WG |  | 23.241 |  |  |
| 198 | 30.3 | Stage 2 - Architecture - ASK SA2 | 355d | 2002-01-28 A | 2003-06-06 | 77% | 80d | 2002-01-28 | 2003-06-06 | 355d | 388d | finish no earlier than 2003-06-06 | S2 | 2840h | 2200h |  |  |  |  | 23.240 | Nacho Uzquiano (Telefonica) | uzquiano_ji@tsm.es |
| 199 | 30.4 | Stage 3 - Common objects | 437d | 2001-10-08 A | 2003-06-10 | 5% | 415.15d | 2001-10-08 | 2003-06-10 | 437d | 386d | finish no earlier than 2003-06-10 | T2 | 3496h | 174.8h |  |  | WG |  | 24.241 |  |  |
| 200 | 30.5 | Stage 3 - Network | 146.98d | 2002-11-18 | 2003-06-10 |  |  | 2002-11-18 | 2003-06-10 | 146.98d | 386d | finish no earlier than 2003-06-10 | N4 | 1175.84h |  |  |  |  |  | 29.240 |  |  |
| 201 | 30.6 | Security Aspects | 214d | 2002-07-16 A | 2003-05-09 | 10% | 192.6d | 2002-07-16 | 2003-05-09 | 214d | 408d | finish no earlier than 2003-05-09 | S3 | 1712h | 171.2h |  |  | WG |  | 33.102, 33.203, 33.210 | Owen, Bradley | bvowen@lucent.com |
| 202 | 31 | **Digital Rights Management** | 380d? | 2001-10-08 A | 2003-03-21 | 35% | 248.43d? | 2001-10-08 | 2003-03-21 | 380d? | 443d |  | S1 | 8688h | 3008.19h | DRM | Rel-6 | TSG | Michael |  |  |  |
| 203 | 31.1 | Requirements | 179d | 2001-10-08 A | 2002-06-13 | 95% | 8.95d | 2001-10-08 | 2002-06-13 | 179d | 644d | finish no earlier than 2002-06-13 | S1 | 1432h | 1360.4h |  |  |  |  |  | Nicholas Wood, Openwave Systems | nicholas.wood@openwave.com |
| 204 | 26.2 | Monitoring of Stages 2 and 3 progress (actual work to be done by OMA) | 155d? | 2002-08-19 | 2003-03-21 |  |  | 2002-08-19 | 2003-03-21 | 155d? | 443d | start no earlier than 2002-08-19 | S1 | 1240h |  |  |  |  |  |  |  |  |
| 205 | 31.3 | Security | 186d | 2002-06-17 A | 2003-03-03 | 40% | 111.6d | 2002-06-17 | 2003-03-03 | 186d | 457d | finish no earlier than 2003-03-03 | S3 | 1488h | 595.2h |  |  |  |  |  |  |  |
| 206 | 31.4 | Codec Aspects | 186d | 2002-06-17 | 2003-03-03 |  |  | 2002-06-17 | 2003-03-03 | 186d | 457d | finish no earlier than 2003-03-03 | S4 | 1488h |  |  |  |  |  |  |  |  |
| 207 | 32 | **FS on WLAN-UMTS Interworking** | 905d? | 2000-01-03 A | 2003-06-20 | 72% | 252.39d? | 2000-01-03 | 2003-06-20 | 905d? | 378d |  | S1 | 25240h | 18200.8h | WLAN | Rel-6 | TSG | Michael |  | Fredric Paint, Telenor | frederic.paint@telenor.com |
| 208 | 32.1 | Technical Report | 900d? | 2000-01-03 A | 2003-06-13 | 95% | 45d? | 2000-01-03 | 2002-05-13 | 616d? | 383d | finish no earlier than 2003-06-13 | S1 | 7200h | 6840h | WLAN-TR |  |  |  | 22.934, 22.101, 22.105 | Fredric Paint, Telenor | frederic.paint@telenor.com |
| 209 | 27.2 | CRs to implement WLAN | 900d? | 2000-01-03 A | 2003-06-13 | 55% | 405d? | 2000-01-03 | 2002-05-13 | 616d? | 383d | finish no earlier than 2003-06-13 | S1 | 7200h | 3960h | WLAN-CR |  |  |  | 22.934, 22.101, 22.105, 22.115 | Fredric Paint, Telenor | frederic.paint@telenor.com |
| 210 | 32.2 | WLAN Interworking – Architecture Definition | 325d | 2002-03-25 A | 2003-06-20 | 72% | 90d | 2002-03-25 | 2003-06-20 | 325d | 378d | finish no earlier than 2003-03-21 | S2 | 2600h | 1880h |  |  | TSG |  |  |  |  |
| 211 | 32.3 | Security | 125d | 2002-09-30 A | 2003-03-21 | 30% | 87.5d | 2002-09-30 | 2003-03-21 | 125d | 443d | finish no earlier than 2003-03-21 | S3 | 1000h | 300h |  |  | TSG |  | 21.133, 33.106, 33.107, 33.108, 33.200, 33.203, 33.210 | Lopez-Soria, Luis, Ericsson | luis.lopez-soria@ece.ericsson.se |
| 212 | 33 | **Priority Service** | 208d | 2002-05-30 A | 2003-03-17 | 80% | 41.42d | 2002-05-30 | 2003-03-17 | 208d | 447d |  | S1 | 3248h | 2601.2h | PRIOR | Rel-6 |  | Michael |  |  |  |
| 213 | 33.1 | Feasibility Study | 1d | 2002-06-14 A | 2002-06-14 | 98% | 0.02d | 2002-06-14 | 2002-06-14 | 1d | 643d | finish no earlier than 2002-06-14 | S1 | 8h | 7.84h | PRIOR-FS |  |  | Michael | 22.950 | Biplab K. Pramanik, Telcordia Technologies | bpramani@telcordia.com |
| 214 | 33.2 | Stage 1 - Requirements | 208d | 2002-05-30 A | 2003-03-17 | 80% | 41.6d | 2002-05-30 | 2003-03-17 | 208d | 447d | finish no earlier than 2003-03-17 | S1 | 1664h | 1331.2h | PRIOR-SR |  |  | Michael |  | James J. Garrahan, Telcordia Technologies | bpramani@telcordia.com |

Notes:
- 200: 17 May no activity in CN4 / 02/08/2002 CN4: No activity in CN4
- 201: WID approved SA#17. SA WG3 progress slow, depends on progress in other groups.
- 202: Foreseen start and completion dates introduced by MCC (no indication at all on the WID)
- 205: SA3 acknowledge role in WI at SA3#20. Active contribution S3#24, S3#25. S3 WID approved SA#17
- 211: Active contribution S3#24, S3#25. WID approved SA#17

| ID | WBS | Task | Duration | Start | Finish | Predecessors | Complete | Remaining | Baseline start | Baseline finish | Baseline duration | Total slack | Constraint | Resources | Work | Actual work | Text1 | Text6 | Text8 | Text3 | Text7 | Text5 | Text4 | Text2 | Text9 |
| --- | --- | --- | --- | --- | --- | --- | --- | --- | --- | --- | --- | --- | --- | --- | --- | --- | --- | --- | --- | --- | --- | --- | --- | --- | --- |
| 215 | 34 | **Network Sharing** | 240d? | 2003-01-20 A | 2003-12-19 |  | 70% | 72d? | 2001-11-14 | 2002-06-14 | 153d | 248d |  | S1 | 3824h | 2250.8h | NTShar | Rel-6 | Michael |  |  |  |  |  |  |
| 216 | 34.1 | **Technical Report** | 240d? | 2003-01-20 A | 2003-12-19 |  | 70% | 72d? | 2001-11-14 | 2002-06-14 | 153d | 248d |  | S1 | 1920h | 918h | NTShar-TR | Rel6 | Michael | 22.951 |  |  |  |  |  |
| 217 | 29.1.1 | New: CRs to implement Network Sharing | 240d? | 2003-01-20 A | 2003-12-19 |  | 70% | 72d? |  |  |  | 248d | finish no earlier than 2003-12-19 |  |  |  | NTShar-CR | Rel6 |  | 22.011, 22.101, 22.115, 22.129 |  |  |  |  |  |
| 218 | 35 | **QoS Improvements** | 245d | 2002-07-15 A | 2003-06-20 |  | 63% | 90d | 2002-07-15 | 2003-06-20 | 245d | 378d |  | S2 | 3920h | 2480h | QoS1 | NA | Alain |  | TSG |  |  |  |  |
| 219 | 35.1 | FS on Dynamic Policy control enhancements for end-to-end QoS | 245d | 2002-07-15 A | 2003-06-20 |  | 63% | 90d | 2002-07-15 | 2003-06-20 | 245d | 378d | finish no earlier than 2003-06-20 | S2 | 1960h | 1240h | QoS1 | Rel-6 |  |  | TSG | Claire Mousset, Nortel |  |  |  |
| 220 | 36 | **Support for subscriber certificates** | 189d | 2002-02-25 A | 2002-11-14 |  | 49% | 97.2d | 2002-02-25 | 2002-11-14 | 189d | 534d |  | S3 | 2856h | 1387.2h | SEC1-SC | Rel-6 | Maurice | 33.102 | TSG | valtteri.niemi@nokia.com | Valtteri Niemi, Nokia |  |  |
| 221 | 36.1 | Stage 1 | 144d | 2002-02-25 A | 2002-09-12 |  | 40% | 86.4d | 2002-02-25 | 2002-09-12 | 144d | 579d | finish no earlier than 2002-09-12 | S3 | 1152h | 460.8h |  |  |  |  |  |  |  |  |  |
| 222 | 36.2 | Architecture review | 24d | 2002-10-14 A | 2002-11-14 A |  | 100% |  | 2002-10-14 | 2002-11-14 | 24d |  | finish no earlier than 2002-11-14 | S2 | 192h | 192h |  |  |  |  |  |  |  |  |  |
| 223 | 38 | **Rel-6 OSA enhancements** | 899d? | 2000-07-11 A | 2003-12-19 |  | 38% | 556.14d? | 2000-07-11 | 2003-12-19 | 899d? | 248d |  | S1 | 44913.6h | 18866.2h | OSA3 | Rel-6 | Adrian | 22.127, 29.198, 29.998 | TSG | Chelo.Abarca@alcatel.fr | Chelo ABARCA (Alcatel) |  |  |
| 224 | 38.1 | Support of a Generic Network Interface Function (Stage 1) | 212.1d | 2002-02-27 A | 2003-01-06 A |  | 100% |  | 2002-02-27 | 2003-01-06 | 212.1d |  | finish no earlier than 2003-01-06 | S1 | 1696.79h | 1696.79h |  |  |  | 22.127 | TSG |  |  |  |  |
| 225 | 38.2 | Support of a Generic Network Interface Function (Stage 3) | 462d | 2002-02-14 A | 2003-12-19 |  | 15% | 392.7d | 2002-02-14 | 2003-12-19 | 462d | 248d | finish no earlier than 2003-12-19 | N5 | 3696h | 554.4h |  |  |  | 29.198, 29.998 | TSG | Chelo.Abarca@alcatel.fr | Chelo ABARCA (Alcatel) |  |  |
| 226 | 38.11 | User Data Management / User data security management (Stage 1) | 212.1d | 2002-02-27 A | 2003-01-06 A |  | 100% |  | 2002-02-27 | 2003-01-06 | 212.1d |  | finish no earlier than 2003-01-06 | S1 | 1696.79h | 1696.79h |  |  |  | 22.127 | TSG |  |  |  |  |
| 227 | 38.12 | User Data Management / User data security management (Stage 3) | 462d | 2002-03-14 A | 2003-12-19 |  | 15% | 392.7d | 2002-03-14 | 2003-12-19 | 462d | 248d | finish no earlier than 2003-12-19 | N5 | 3696h | 554.4h |  |  |  | 29.198, 29.998 | TSG | Chelo.Abarca@alcatel.fr | Chelo ABARCA (Alcatel) |  |  |
| 228 | 37.1.2 | Access to User Profile | 145d | 2001-06-01 A | 2001-12-20 |  | 90% | 14.5d | 2001-06-01 | 2001-12-20 | 145d | 769d | finish no earlier than 2001-12-20 | S1 | 1160h | 1044h | OSA1-UP |  |  |  | TSG |  |  |  |  |
| 229 | 32.6 | Retrieval of Visited Network capabilities | 297d? | 2002-10-31 A | 2003-12-19 |  | 15% | 252.45d? | 2002-10-31 | 2003-12-19 | 297d? | 248d | finish no earlier than 2003-12-19 | N5 | 2376h | 356.4h |  |  |  | 29.198, 29.998 | TSG | Chelo.Abarca@alcatel.fr | Chelo ABARCA (Alcatel) |  |  |
| 230 | 32.7 | Access to IP Session information | 297d? | 2002-10-31 A | 2003-12-19 |  | 15% | 252.45d? | 2002-10-31 | 2003-12-19 | 297d? | 248d | finish no earlier than 2003-12-19 | N5 | 2376h | 356.4h |  |  |  | 29.198, 29.998 | TSG | Chelo.Abarca@alcatel.fr | Chelo ABARCA (Alcatel) |  |  |
| 231 | 32.8 | Multi Media Messaging function | 297d? | 2002-10-31 A | 2003-12-19 |  | 15% | 252.45d? | 2002-10-31 | 2003-12-19 | 297d? | 248d | finish no earlier than 2003-12-19 | N5 | 2376h | 356.4h |  |  |  | 29.198, 29.998 | TSG | Chelo.Abarca@alcatel.fr | Chelo ABARCA (Alcatel) |  |  |
| 232 | 32.9 | Enhanced user privacy in LCS | 297d? | 2002-10-31 A | 2003-12-19 |  | 15% | 252.45d? | 2002-10-31 | 2003-12-19 | 297d? | 248d | finish no earlier than 2003-12-19 | N5 | 2376h | 356.4h |  |  |  | 29.198, 29.998 | TSG | Chelo.Abarca@alcatel.fr | Chelo ABARCA (Alcatel) |  |  |
| 233 | 32.10 | Policy management extensions | 297d? | 2002-10-31 A | 2003-12-19 |  | 15% | 252.45d? | 2002-10-31 | 2003-12-19 | 297d? | 248d | finish no earlier than 2003-12-19 | N5 | 2376h | 356.4h |  |  |  | 29.198, 29.998 | TSG | Chelo.Abarca@alcatel.fr | Chelo ABARCA (Alcatel) |  |  |
| 234 | 32.11 | Presence and Availability Management (from the PRESNC WI) | 297d? | 2002-10-31 A | 2003-12-19 |  | 15% | 252.45d? | 2002-10-31 | 2003-12-19 | 297d? | 248d | finish no earlier than 2003-12-19 | N5 | 2376h | 356.4h |  |  |  | 29.198, 29.998 | TSG | Chelo.Abarca@alcatel.fr | Chelo ABARCA (Alcatel) |  |  |
| 235 | 32.12 | Information Services | 297d? | 2002-10-31 A | 2003-12-19 |  | 15% | 252.45d? | 2002-10-31 | 2003-12-19 | 297d? | 248d | finish no earlier than 2003-12-19 | N5 | 2376h | 356.4h |  |  |  | 29.198, 29.998 | TSG | Chelo.Abarca@alcatel.fr | Chelo ABARCA (Alcatel) |  |  |
| 236 | 32.13 | Information Transfer | 297d? | 2002-10-31 A | 2003-12-19 |  | 15% | 252.45d? | 2002-10-31 | 2003-12-19 | 297d? | 248d | finish no earlier than 2003-12-19 | N5 | 2376h | 356.4h |  |  |  | 29.198, 29.998 | TSG | Chelo.Abarca@alcatel.fr | Chelo ABARCA (Alcatel) |  |  |
| 237 | 38.13 | Security | 202d | 2002-03-14 A | 2002-12-20 A |  | 100% |  | 2002-03-14 | 2002-12-20 | 202d |  | finish no earlier than 2002-12-20 | S3 | 1616h | 1616h |  |  |  |  | TSG |  |  |  |  |
| 238 | 38.14 | **Retrieval of Terminal capabilities** | 634d | 2000-07-11 A | 2002-12-13 |  | 86% | 88.34d | 2000-07-11 | 2002-12-13 | 634d | 513d |  | S2 | 8648h | 7443.06h | OSA1-TC |  |  |  | TSG |  |  | Ser | 1433 |
| 239 | 38.14.1 | Stage 1 | 132d | 2000-07-11 A | 2001-01-10 A |  | 100% |  | 2000-07-11 | 2001-01-10 | 132d |  | finish no earlier than 2001-01-10 | S1 | 1056h | 1056h |  |  |  | 22.127 | TSG |  | Jörg Swetina, SIEMENS AG | Ser | 1434 |
| 240 | 38.14.2 | Stages 2 and 3 | 321d | 2001-09-21 A | 2002-12-13 A | 239 | 100% |  | 2001-09-21 | 2002-12-13 | 321d |  | finish no earlier than 2002-12-13 | N5 | 2568h | 2568h |  |  |  | 29.198, 29.998 | TSG | Ard.Jan.Moerdijk@eln.ericsson.se | Ard-Jan MOERDIJK (Ericsson) | Ser | 1436 |
| 241 | 38.14.3 | Provisionning of the terminal capabilities | 175d | 2001-04-02 A | 2001-11-30 |  | 50% | 87.5d | 2001-04-02 | 2001-11-30 | 175d | 783d | finish no earlier than 2001-11-30 | T2 | 1400h | 700h |  |  |  | 23.057 | TSG |  |  |  | 2122 |

Notes:
- 220: Approved at SA#14. This may require BBs from CN1, CN4, SA5 and T3
- 221: Contribution received S3#24, S3#25
- 223: TSG approval target 9/03->12/03. New Rapp.
- 225: TSG approval target 9/03->12/03. New Rapp.
- 227: TSG approval target 9/03->12/03. New Rapp.
- 229: TSG approval target 9/03->12/03. New Rapp.
- 230: TSG approval target 9/03->12/03. New Rapp.
- 231: TSG approval target 9/03->12/03. New Rapp.
- 232: TSG approval target 9/03->12/03. New Rapp.
- 233: TSG approval target 9/03->12/03. New Rapp.
- 234: TSG approval target 9/03->12/03. New Rapp.
- 235: TSG approval target 9/03->12/03. New Rapp.
- 236: TSG approval target 9/03->12/03. New Rapp.
- 237: Contribution at S3#25
- 241: According to T2 SWG1 M. Cataldo this is automatically supported by the MExE support of UAProf therefore 100% complete

| ID | WBS | Task | Duration | Start | Finish | Complete | Remaining | Baseline start | Baseline finish | Baseline duration | Total slack | Constraint | Resources | Work | Actual work | Text1 | Text6 | Text7 | Text8 | Text4 | Text5 | Text3 |
| --- | --- | --- | --- | --- | --- | --- | --- | --- | --- | --- | --- | --- | --- | --- | --- | --- | --- | --- | --- | --- | --- | --- |
| 242 | 33 | **Handling of early UEs** | 190d? | 2002-10-07 A | 2003-06-27 | 46% | 103.14d? | 2002-10-07 | 2003-06-27 | 190d? | 373d |  | S2 | 2920h | 1334.86h | LATE_UE | Rel-6 | WG | Alain |  |  |  |
| 243 | 33.1 | Feasibility Study | 50d? | 2002-10-07 A | 2002-12-13 A | 100% |  | 2002-10-07 | 2002-12-13 | 50d? |  | finish no earlier than 2002-12-13 | S2 | 400h | 400h |  |  | WG |  |  |  |  |
| 244 | 33.2 | Stage 2 | 125d? | 2003-01-06 A | 2003-06-27 | 24% | 95d? | 2003-01-06 | 2003-06-27 | 125d? | 373d | start no earlier than 2003-01-06 | S2 | 1000h | 240h |  |  | WG |  |  |  |  |
| 245 | 39 | **Addition of frequency bands to GSM** | 386d | 2002-06-28 A | 2003-12-19 | 6% | 361.64d | 2002-06-28 | 2003-12-19 | 386d | 248d |  | GP | 9680h | 610.87h | TAPS | Rel-6 |  | Paolo | Torben Themsen |  |  |
| 246 | 39.1 | **Addition of frequency bands to GSM – Changes to core specs** | 26d | 2002-11-15 A | 2002-12-20 A | 100% |  | 2002-11-15 | 2002-12-20 | 26d |  |  | G1 | 416h | 416h | TAPS-Specs | Rel-6 | TSG |  | Torben Themsen |  |  |
| 247 | 39.1.1 | Changes to core specs | 26d | 2002-11-15 A | 2002-12-20 A | 100% |  | 2002-11-15 | 2002-12-20 | 26d |  | finish no earlier than 2002-12-20 | G1 | 208h | 208h |  |  |  |  |  |  |  |
| 248 | 39.2 | **Addition of frequency bands to GSM – Changes for conformance tests** | 386d | 2002-06-28 | 2003-12-19 |  |  | 2002-06-28 | 2003-12-19 | 386d | 248d |  | G4 | 6176h |  | TAPS-Conf |  |  |  | Torben Themsen |  |  |
| 249 | 39.2.1 | 51.010-1 Add testing | 386d | 2002-06-28 | 2003-12-19 |  |  | 2002-06-28 | 2003-12-19 | 386d | 248d | finish no earlier than 2003-12-19 | G4 | 3088h |  |  |  |  |  |  |  |  |
| 250 | 40 | **Seamless support of streaming services in A/Gb mode** | 1035d? | 2000-01-03 A | 2003-12-19 | 55% | 468.91d? | 2000-01-03 | 2003-12-19 | 1035d? | 248d |  | GP | 34008h | 14708.1h | SSStrea | Rel-6 |  | Paolo | José Luis Carrizo Martínez, Vodafone |  |  |
| 251 | 40.1 | **Identification of requirements for streaming** | 1d? | 2003-06-27 A | 2003-06-27 | 40% | 0.6d? | 2003-06-27 | 2003-06-27 | 1d? | 373d |  | G1 | 16h | 11.2h |  |  |  |  |  |  |  |
| 252 | 35.1.1 | Requirements | 1d? | 2003-06-27 A | 2003-06-27 | 40% | 0.6d? | 2003-06-27 | 2003-06-27 | 1d? | 373d | start no earlier than 2003-06-27 | G1 | 8h | 3.2h |  |  |  |  |  |  |  |
| 253 | 40.2 | **Performance study of cell change mechanisms** | 910d? | 2000-01-03 A | 2003-06-27 | 60% | 364d? | 2000-01-03 | 2003-06-27 | 910d? | 373d |  | G1 | 29120h | 13196.8h |  |  |  |  |  |  |  |
| 254 | 35.2.1 | Performance of NACC | 910d? | 2000-01-03 A | 2003-06-27 | 60% | 364d? | 2000-01-03 | 2003-06-27 | 910d? | 373d | finish no earlier than 2003-06-27 | G1 | 7280h | 4368h |  |  |  |  |  |  |  |
| 255 | 35.2.2 | Performance of cell change in DTM for the PS domain | 910d? | 2000-01-03 A | 2003-06-27 | 60% | 364d? | 2000-01-03 | 2003-06-27 | 910d? | 373d | finish no earlier than 2003-06-27 | G1 | 7280h | 4368h |  |  |  |  |  |  |  |
| 256 | 35.2.3 | Handover | 910d? | 2000-01-03 A | 2003-06-27 | 60% | 364d? | 2000-01-03 | 2003-06-27 | 910d? | 373d | finish no earlier than 2003-06-27 | G1 | 7280h | 4368h |  |  |  |  |  |  |  |
| 257 | 40.3 | **Reduction of service interruption times and packet loss during mobility procedures** | 1d? | 2003-06-27 A | 2003-06-27 | 20% | 0.8d? | 2003-06-27 | 2003-06-27 | 1d? | 373d |  | G2 | 40h | 8h |  |  |  |  |  |  |  |
| 258 | 35.3.1 | Optimisations of existing mechanisms/procedures | 1d? | 2003-06-27 A | 2003-06-27 | 20% | 0.8d? | 2003-06-27 | 2003-06-27 | 1d? | 373d | start no earlier than 2003-06-27 | G2 | 8h | 1.6h |  |  |  |  |  |  |  |
| 259 | 35.3.2 | Inter-system NACC | 1d? | 2003-06-27 A | 2003-06-27 | 20% | 0.8d? | 2003-06-27 | 2003-06-27 | 1d? | 373d | start no earlier than 2003-06-27 | G2 | 8h | 1.6h |  |  |  |  |  |  |  |
| 260 | 35.3.3 | PS Handover (within GERAN and between GERAN and UTRAN) | 1d? | 2003-06-27 A | 2003-06-27 | 20% | 0.8d? | 2003-06-27 | 2003-06-27 | 1d? | 373d | start no earlier than 2003-06-27 | G2 | 8h | 1.6h |  |  |  |  |  |  |  |
| 261 | 35.3.4 | Dependency to other features | 1d? | 2003-06-27 A | 2003-06-27 | 20% | 0.8d? | 2003-06-27 | 2003-06-27 | 1d? | 373d | start no earlier than 2003-06-27 | G2 | 8h | 1.6h |  |  |  |  |  |  |  |
| 262 | 40.5 | **MS conformance testing** | 1d? | 2003-12-19 | 2003-12-19 |  |  | 2003-12-19 | 2003-12-19 | 1d? | 248d |  | G4 | 16h |  |  |  |  |  |  |  |  |
| 263 | 35.4.1 | MS conformance tests | 1d? | 2003-12-19 | 2003-12-19 |  |  | 2003-12-19 | 2003-12-19 | 1d? | 248d | start no earlier than 2003-12-19 | G4 | 8h |  |  |  |  |  |  |  |  |
| 264 | 35.5 | GERAN A/Gb mode security enhancements | 261d? | 2002-12-09 | 2003-12-08 |  |  | 2002-12-09 | 2003-12-08 | 261d? | 257d | finish no earlier than 2003-12-08 | S3 | 2088h |  |  |  |  |  | Peter Howard, Vodafone | peter.howard@vodafone.com |  |
| 265 | 41 | Performance characterisation of default codecs for PS conversational multimedia application | 203d | 2002-09-11 A | 2003-06-20 | 5% | 192.85d | 2002-09-11 | 2003-06-20 | 203d | 225d | finish no earlier than 2003-06-20 | S4 | 1624h | 81.2h | CODCAR | Rel-6 | TSG | Paolo | Pasi Ojala (Nokia) |  | TR 26.9yz |
| 266 | 42 | Study of Feature Interactions Requirements | 82d | 2002-11-08 A | 2003-03-03 | 20% | 65.6d | 2002-11-08 | 2003-03-03 | 82d | 304d | start no earlier than 2002-11-08 | S1 | 656h | 131.2h | FINTER | Rel6 |  | Michael |  |  | TR 21.xyz |
| 267 | 43 | Study on Privacy Capability | 82d | 2002-11-08 A | 2003-03-03 | 15% | 69.7d | 2002-11-08 | 2003-03-03 | 82d | 304d | start no earlier than 2002-11-08 | S1 | 656h | 98.4h | PrivCap | Rel-6 |  | Michael | Liz Daniel, Lucent |  | TR 21.xyz |

Notes:
- 246: Ready
- 248: Not started
- 251: Started
- 253: Started
- 257: Started
- 262: Not started

| ID | WBS | Task | Duration | Start | Finish | Complete | Remaining | Baseline start | Baseline finish | Baseline duration | Total slack | Constraint | Resources | Work | Actual work | Text1 | Text3 | Text4 | Text5 | Text6 | Text7 | Text8 | Text2 | Text9 |
| --- | --- | --- | --- | --- | --- | --- | --- | --- | --- | --- | --- | --- | --- | --- | --- | --- | --- | --- | --- | --- | --- | --- | --- | --- |
| 268 | 44 | **Rel-6 OAM&P** | 337d? | 2002-06-12 A | 2003-09-25 | 15% | 285.34d? | 2002-06-12 | 2003-09-25 | 337d? | 309d |  | S5 | 20808h | 3000.51h | OAM | 32-series | Michael TRUSS (Motorola) | Michael.Truss@MOTOROLA.COM | Rel-6 | TSG | Adrian |  |  |
| 269 | 44.1 | Rel6 Principles, high level Requirements and Architecture | 271d | 2002-09-12 A | 2003-09-25 | 10% | 243.9d | 2002-09-12 | 2003-09-25 | 271d | 309d | finish no earlier than 2003-09-25 | S5 | 2168h | 216.8h | OAM-AR | 32.101, 32.102 | Michael TRUSS (Motorola) | Michael.Truss@MOTOROLA.COM |  | TSG |  | BCaM |  |
| 270 | 44.2 | Rel6 Performance Management | 271d | 2002-09-12 A | 2003-09-25 | 15% | 230.35d | 2002-09-12 | 2003-09-25 | 271d | 309d | finish no earlier than 2003-09-25 | S5 | 2168h | 325.2h | OAM-PM | 32.41x, 52.402 | Christian TOCHE (Nortel Networks) | toche@NORTELNETWORKS.COM |  | TSG |  | BCaM |  |
| 271 | 44.3 | **Rel6 User Equipment Management** | 301d? | 2002-08-01 A | 2003-09-25 | 7% | 281.11d? | 2002-08-01 | 2003-09-25 | 301d? | 309d |  | S5 | 8912h | 588.85h | OAM-UEM | 32.150, 27.150 (T2), 32.802 | John Mudge (Vodafone) | john.mudge@vf.vodafone.co.uk |  | TSG |  |  |  |
| 272 | 39.3.1 | UEM requirements and architecture; Stages 1 and 2 | 271d? | 2002-09-12 A | 2003-09-25 | 10% | 243.9d? | 2002-09-12 | 2003-09-25 | 271d? | 309d | finish no earlier than 2003-09-25 | S5 | 2168h | 216.8h |  | 32.150 (SA5) | John Mudge (Vodafone) | john.mudge@vf.vodafone.co.uk |  | TSG |  |  |  |
| 273 | 39.3.2 | UEM protocol specification; Stage 3 | 271d? | 2002-09-12 A | 2003-09-25 | 5% | 257.45d? | 2002-09-12 | 2003-09-25 | 271d? | 309d | finish no earlier than 2003-09-25 | T2 | 2168h | 108.4h |  | 27.150 (T2) |  |  |  | TSG |  |  |  |
| 274 | 39.3.3 | Release 6 User Equipment Management: Security aspects | 301d? | 2002-08-01 A | 2003-09-25 | 5% | 285.95d? | 2002-08-01 | 2003-09-25 | 301d? | 309d | finish no earlier than 2003-09-25 | S3 | 2408h | 120.4h | OAM-UEM-SEC |  | Peter Howard (Vodafone) | peter.howard@vodafone.com |  | TSG |  |  |  |
| 275 | 44.4 | Rel6 Network Infrastructure Management | 271d | 2002-09-12 A | 2003-09-25 | 5% | 257.45d | 2002-09-12 | 2003-09-25 | 271d | 309d | finish no earlier than 2003-09-25 | S5 | 2168h | 108.4h | OAM-NIM | 32.6xy, 32.3xy | Thomas TOVINGER (Ericsson) | Thomas.Tovinger@emw.ericsson.se |  | TSG |  |  |  |
| 276 | 44.5 | Rel6 Trace Management | 337d | 2002-06-12 A | 2003-09-25 | 50% | 168.5d | 2002-06-12 | 2003-09-25 | 337d | 309d | finish no earlier than 2003-09-25 | S5 | 2696h | 1348h | OEM-Trace | 32.42x, 52.008 | Christian TOCHE (Nortel Networks) | toche@NORTELNETWORKS.COM |  | TSG |  |  |  |
| 277 | 40 | **Charging Management** | 221d? | 2002-11-21 A | 2003-09-25 | 12% | 193.78d? | 2002-11-21 | 2003-09-25 | 221d? | 309d |  | S5 | 8264h | 1017.73h | CH | 32.2xy | Karl-Heinz NENNER (T-Mobile) | karl-heinz.nenner@t-mobile.de | Rel-6 | TSG | Adrian |  |  |
| 278 | 40.1 | Charging Management for Bearer level | 220d? | 2002-11-22 A | 2003-09-25 | 5% | 209d? | 2002-11-22 | 2003-09-25 | 220d? | 309d | finish no earlier than 2003-09-25 | S5 | 1760h | 88h | CH-BC |  | Benni ALEXANDER (Nokia) |  |  | TSG |  |  |  |
| 279 | 40.2 | Charging Management for the IMS | 220d? | 2002-11-22 A | 2003-09-25 | 5% | 209d? | 2002-11-22 | 2003-09-25 | 220d? | 309d | finish no earlier than 2003-09-25 | S5 | 1760h | 88h | CH-IC |  | Ariel SHARON (Lucent) |  |  | TSG |  |  |  |
| 280 | 40.3 | Charging Management for the Service domain | 220d? | 2002-11-22 A | 2003-09-25 | 5% | 209d? | 2002-11-22 | 2003-09-25 | 220d? | 309d | finish no earlier than 2003-09-25 | S5 | 1760h | 88h | CH-SC |  | Gerald GÖRMER (Siemens) |  |  | TSG |  |  |  |
| 281 | 40.4 | Overall architectural aspects of IP flow based bearer level charging | 152d? | 2002-11-21 A | 2003-06-20 | 44% | 85d? | 2002-11-21 | 2003-06-20 | 152d? | 378d | finish no earlier than 2003-06-20 | S2 | 1216h | 536h |  |  |  |  |  |  |  |  |  |
| 282 | 13 | **Rel-6 UICC/USIM enhancements and interworking** | 778d | 2000-09-25 A | 2003-09-17 | 58% | 325.78d | 2000-09-25 | 2003-09-17 | 778d | 315d |  | T3 | 24200h | 12454.3h | USAT1 |  |  |  | NA |  | Claus | Ter | 1800 |
| 283 | 13.1 | **UICC API** | 391d | 2002-03-20 A | 2003-09-17 | 25% | 292.05d | 2002-03-20 | 2003-09-17 | 391d | 315d |  | T3 | 6912h | 1749.19h | USAT1-API |  |  |  | NA |  |  | Ter | 1802 |
| 284 | 13.1.1 | Java API Test specification | 133d | 2002-03-20 A | 2002-09-20 | 90% | 13.3d | 2002-03-20 | 2002-09-20 | 133d | 573d | finish no earlier than 2002-09-20 | T3 | 1064h | 957.6h |  |  | Mario Pérez (Microelectrónica Española) |  |  |  |  |  |  |
| 285 | 13.1.2 | Java API Test specification (TS 43.019 Rel-5) | 340d | 2002-05-30 | 2003-09-17 |  |  | 2002-05-30 | 2003-09-17 | 340d | 315d | finish no earlier than 2003-09-17 | T3 | 2720h |  |  |  | Mario Pérez (Microelectrónica Española) |  | Rel-5 |  |  |  |  |
| 286 | 41.2 | **Rel-6 USIM toolkit enhancements** | 525d | 2000-09-25 A | 2002-09-27 | 80% | 106.64d | 2000-09-25 | 2002-09-27 | 525d | 568d |  | T3 | 14160h | 8886.88h |  |  |  |  | NA |  | Claus |  |  |
| 287 | 41.2.1 | **C SIM API** | 525d | 2000-09-25 A | 2002-09-27 | 80% | 106.64d | 2000-09-25 | 2002-09-27 | 525d | 568d |  | T3 | 9960h | 7936.88h | USAT1-API-MULTOS |  |  |  | Rel-6 | TSG |  | Ter | 2031 |
| 288 | 41.2.1.1 | Specification | 525d | 2000-09-25 A | 2002-09-27 A | 100% |  | 2000-09-25 | 2002-09-27 | 525d |  | finish no earlier than 2002-09-27 | T3 | 4200h | 4200h |  |  | Neil Livingston – Aspects Software |  |  | TSG |  | Ter | 2032 |
| 289 | 41.2.1.2 | Test specification | 195d | 2001-01-01 A | 2001-09-28 | 25% | 146.25d | 2001-01-01 | 2001-09-28 | 195d | 828d | finish no earlier than 2001-09-28 | T3 | 1560h | 390h |  |  | Neil Livingston – Aspects Software |  |  | TSG |  | Ter | 2033 |
| 290 | 42 | Enhanced Tandem Free Operation | 160d | 2002-11-11 | 2003-06-20 |  |  | 2002-11-11 | 2003-06-20 | 160d | 225d | finish no earlier than 2003-06-20 | S4 | 1280h |  | eTFO |  | Andrew Harrison, Nortel Networks |  | Rel-6 | WG | Paolo |  |  |
| 291 | 43 | **Packet Switched Streaming Services Rel-6** | 86d? | 2002-11-18 A | 2003-03-17 | 80% | 17.2d? | 2002-11-11 | 2003-06-20 | 160d | 447d |  | S4 | 1376h | 1100.8h | PSSrel6 |  | Olle Franceschi (Ericsson) |  | Rel-6 | WG | Paolo |  |  |
| 292 | 43.1 | New: Stage 1 | 86d? | 2002-11-18 A | 2003-03-17 | 80% | 17.2d? |  |  |  | 447d | finish no earlier than 2003-03-17 | S1 | 688h | 550.4h |  | 22.233 |  |  |  | TSG |  |  |  |
| 293 | 44 | AMR-WB extension for high audio quality | 160d | 2002-11-11 | 2003-06-20 |  |  | 2002-11-11 | 2003-06-20 | 160d | 225d | finish no earlier than 2003-06-20 | S4 | 1280h |  | AMRWB+ |  | Janne Vainio (Nokia) |  | Rel-6 | WG | Paolo |  |  |
| 294 | 45 | Single Antenna Receiver Interference Cancellation (SAIC) | 161d? | 2002-11-15 A | 2003-06-27 | 20% | 128.8d? | 2002-11-15 | 2003-06-27 | 161d? | 220d | finish no earlier than 2003-06-27 | G1 | 1288h | 257.6h | SAIC |  | Marc Grant, Cingular Wireless |  | Rel-6 | TSG |  |  |  |

Notes:
- 272: created 25/11/02
- 273: created 25/11/02
- 274: created 15/01/03
- 275: Changed WID
- 277: Changed WID
- 278: Changed WID
- 279: Changed WID
- 280: Changed WID
- 283: 8/3/2001: test spec is based on R99 core spec, so deleted from Workplan
- 288: 30/12/2000: completion amount updated
- 292: 2nd resp SA4
- 294: Ongoing

| ID | WBS | Task | Duration | Start | Finish | Complete | Remaining | Baseline start | Baseline finish | Baseline duration | Total slack | Constraint | Resources | Work | Actual work | Text1 | Text4 | Text6 | Text7 | Text8 | Text9 | Text3 | Text2 |
| --- | --- | --- | --- | --- | --- | --- | --- | --- | --- | --- | --- | --- | --- | --- | --- | --- | --- | --- | --- | --- | --- | --- | --- |
| 295 | 46 | **Support of Conversational Services in A/Gb mode via the PS domain** | 321d? | 2003-02-07 | 2004-04-30 |  |  | 2003-02-07 | 2004-04-30 | 321d? | 153d |  | GP | 17096h |  | SCSAGB | David Bladsjö, Ericsson | Rel-6 | TSG |  |  |  |  |
| 296 | 46.1 | Creation of a TR | 211d? | 2003-02-07 | 2003-11-28 |  |  | 2003-02-07 | 2003-11-28 | 211d? | 263d | finish no earlier than 2003-11-28 | GP | 1688h |  | SCSAGB-TR | David Bladsjö, Ericsson |  | TSG |  |  |  |  |
| 297 | 46.2 | Stage 2 | 321d? | 2003-02-07 | 2004-04-30 |  |  | 2003-02-07 | 2004-04-30 | 321d? | 153d | finish no earlier than 2004-04-30 | GP | 2568h |  | SCSAGB-Stage2 | David Bladsjö, Ericsson |  | TSG |  |  |  |  |
| 298 | 46.3 | Radio Channel Support | 321d? | 2003-02-07 | 2004-04-30 |  |  | 2003-02-07 | 2004-04-30 | 321d? | 153d | finish no earlier than 2004-04-30 | GP | 2568h |  | SCSAGB-RCS | David Bladsjö, Ericsson |  | TSG |  |  |  |  |
| 299 | 46.4 | Definition of radio resource management functionality | 160.5d? | 2003-02-07 | 2003-09-19 |  |  | 2003-02-07 | 2003-09-19 | 160.5d? | 313.5d | finish no earlier than 2003-09-19 | GP; G2 | 2568h |  | SCSAGB-RRM | David Bladsjö, Ericsson |  | TSG |  |  |  |  |
| 300 | 46.5 | PS Handover | 321d? | 2003-02-07 | 2004-04-30 |  |  | 2003-02-07 | 2004-04-30 | 321d? | 153d | finish no earlier than 2004-04-30 | GP | 2568h |  | SCSAGB-PSH | David Bladsjö, Ericsson |  | TSG |  |  |  |  |
| 301 | 46.6 | Modifications to FLO | 160.5d? | 2003-02-07 | 2003-09-19 |  |  | 2003-02-07 | 2003-09-19 | 160.5d? | 313.5d | finish no earlier than 2003-09-19 | GP; G2 | 2568h |  | SCSAGB-FLO | David Bladsjö, Ericsson |  | TSG |  |  |  |  |
| 302 | 47 | Enhancement of dialled service for CAMEL | 136d? | 2003-03-14 | 2003-09-19 |  |  |  |  |  | 313d | finish no earlier than 2003-09-19 | N2 | 1088h |  |  | Craig Bishop, Samsung Electronics Research Institute | Rel-6 |  | Andrijana |  |  |  |
| 303 | 45 | ----- Rel-4 features listed below ----- | 1d | 2000-01-03 | 2000-01-03 |  |  | 2000-01-03 | 2000-01-03 | 1d | 1282d |  |  |  |  |  |  | Rel-4 |  |  |  |  |  |
| 304 | 15 | **Miscelleneous UE Conformance Testing Activities** | 958d | 2001-04-02 A | 2004-12-01 | 50% | 483.11d | 2001-04-02 | 2003-03-03 | 501d | 0d |  | T1 | 36360h | 18023.9h | MISTST1 |  | NA |  | Lidia | 1861 |  |  |
| 305 | 15.1 | Optimisation of Test Time, RF Aspects (FDD) | 508d | 2001-09-24 A | 2003-09-03 | 70% | 152.4d | 2001-09-24 | 2003-03-03 | 376d | 325d | finish no earlier than 2003-09-03 | T1 | 4064h | 2844.8h | MISTST1-OpFDD |  | Rel Indep | TSG |  | 1862 | 34.121 |  |
| 306 | 15.2 | Optimisation of Test Time, RF Aspects (TDD) | 508d | 2001-09-24 A | 2003-09-03 | 70% | 152.4d | 2001-09-24 | 2003-03-03 | 376d | 325d | finish no earlier than 2003-09-03 | T1 | 4064h | 2844.8h | MISTST1-OpTDD |  | Rel Indep | TSG |  | 1863 | 34.122 |  |
| 307 | 15.3 | Extensions to R99 Test cases | 139.4w | 2001-04-02 A | 2003-12-02 | 70% | 41.82w | 2001-04-02 | 2002-12-02 | 87.2w | 261d | finish no earlier than 2003-12-02 | T1 | 5576h | 3903.2h | MISTST1-Ext |  |  | TSG |  | 1907 | 34.123 pts 1,2 |  |
| 308 | 15.4 | Extension to R99 Test cases - TTCN | 439d | 2002-06-28 A | 2004-03-03 | 50% | 219.5d | 2002-06-28 | 2003-03-03 | 177d | 195d | finish no earlier than 2004-03-03 | T1 | 3512h | 1756h |  |  |  | TSG |  |  |  |  |
| 309 | 15.5 | Creation of R99 TCs for TDD - prose | 719d | 2001-10-01 A | 2004-07-01 | 50% | 359.5d | 2001-10-01 | 2002-09-27 | 260d | 109d | finish no earlier than 2004-07-01 | T1 | 5752h | 2876h | MISTST1-TDD |  |  | TSG |  |  | 34.123-1 |  |
| 310 | 15.6 | Creation of R99 TCs for TDD - TTCN | 587d | 2002-09-03 | 2004-12-01 |  |  | 2002-09-03 | 2003-03-03 | 130d | 0d | finish no earlier than 2004-12-01 | T1 | 4696h |  |  |  |  | TSG |  |  |  |  |
| 311 | 15.7 | Review all other work items for impact on new or exiting 34 series specs. | 25.8w | 2002-07-02 | 2002-12-27 |  |  | 2002-07-02 | 2002-12-27 | 25.8w | 503d | finish no earlier than 2002-12-27 | T1 | 1032h |  | MISTST1 |  |  |  |  | 1908 | 34.121,122,123,125 |  |
| 312 | 46 | **Facsimile** | 89d | 2000-02-22 A | 2000-06-23 A | 100% |  | 2000-02-22 | 2000-06-23 | 89d |  |  | S1 | 4376h | 4376h | FAX |  | Rel-4 | TSG | Alain | 1340 |  |  |
| 313 | 46.1 | **Real Time Fax** | 89d | 2000-02-22 A | 2000-06-23 A | 100% |  | 2000-02-22 | 2000-06-23 | 89d |  |  | S2 | 3664h | 3664h | FAX-RT |  |  |  |  | 1341 |  | CCaR |
| 314 | 46.1.1 | Terminal capabilities, AT commands | 89d | 2000-02-22 A | 2000-06-23 A | 100% |  | 2000-02-22 | 2000-06-23 | 89d |  | finish no earlier than 2000-06-23 | T2 | 712h | 712h |  |  |  |  |  | 1808 | 21.904, 27.007 | CCaR |
| 315 | 46.1.2 | Signalling aspects (e.g. ICM) | 89d | 2000-02-22 A | 2000-06-23 A | 100% |  | 2000-02-22 | 2000-06-23 | 89d |  | start no earlier than 2000-02-22 | N1 | 712h | 712h |  |  |  |  |  | 1343 |  | CCaR |
| 316 | 46.1.3 | Service provision | 89d | 2000-02-22 A | 2000-06-23 A | 100% |  | 2000-02-22 | 2000-06-23 | 89d |  | finish no earlier than 2000-06-23 | N3 | 712h | 712h |  |  |  |  |  | 1648 | 23.146 | CCaR |
| 317 | 46.1.4 | Review whether service/stage 1 aspects need to be aligned | 51d | 2000-04-14 A | 2000-06-23 A | 100% |  | 2000-04-14 | 2000-06-23 | 51d |  | finish no earlier than 2000-12-14 | S1 | 408h | 408h |  |  |  |  |  | 1345 |  | CCaR |
| 318 | 46.1.5 | Review whether architecture/stage 2 aspects need to be aligned | 51d | 2000-04-14 A | 2000-06-23 A | 100% |  | 2000-04-14 | 2000-06-23 | 51d |  | finish no earlier than 2000-12-14 | S2 | 408h | 408h |  |  |  |  |  | 1346 |  | CCaR |
| 319 | 47 | Transparent End-to-End PS mobile streaming application | 253d | 2000-04-03 A | 2001-03-21 A | 100% |  | 2000-04-03 | 2001-03-21 | 253d |  | finish no earlier than 2000-12-29 | S4 | 2024h | 2024h | PSTREAM |  | Rel-4 | TSG | Paolo | 1539 | 26.233, 26.234 |  |

Notes:
- 296: Started
- 297: Not Started
- 298: Not Started
- 299: Not Started
- 300: Not Started
- 301: Not Started
- 305: It is believed that the current R99 test spec. can be optimised for faster overall test times
- 306: It is believed that the current R99 test spec. can be optimised for faster overall test times
- 307: Further test coverage of the R99 specification to cover supplementry services
- 311: Can't start until most core specs are stable
- 313: postponed from R99 to R00, SP-000169

| ID | WBS | Task | Type | Duration | Start | Finish | Predecessors | Complete | Remaining | Baseline start | Baseline finish | Baseline duration | Total slack | Constraint | Resources | Work | Actual work | Text1 | Text2 | Text3 | Text4 | Text5 | Text6 | Text7 | Text8 | Text9 |
| --- | --- | --- | --- | --- | --- | --- | --- | --- | --- | --- | --- | --- | --- | --- | --- | --- | --- | --- | --- | --- | --- | --- | --- | --- | --- | --- |
| 320 | 48 | **Multimedia Messaging** |  | 277d | 2000-02-22 A | 2001-03-14 |  | 99% | 0d | 2000-02-22 | 2001-03-14 | 277d | 0d |  | T2 | 12208h | 10661.6h | MMS | Mes | 22.140, 23.140 | Josef Laumen, Siemens | Josef.Laumen@SAL.SIEMENS.DE | Rel-4 | TSG | Friedhelm | 1818 |
| 321 | 48.1 | Definition of service requirements |  | 72d | 2000-02-22 A | 2000-05-31 A |  | 100% |  | 2000-02-22 | 2000-05-31 | 72d |  | start no earlier than 2000-02-22 | S1 | 576h | 576h | MMS | Mes |  |  |  |  |  |  | 136 |
| 322 | 48.2 | Review of definition of service requirements |  | 205d | 2000-06-01 A | 2001-03-14 A | 321 | 100% |  | 2000-06-01 | 2001-03-14 | 205d |  | finish no earlier than 2000-09-08 | T2 | 1640h | 1640h |  | Mes | 22.140, 23.140 | Josef Laumen, Siemens |  |  | TSG |  | 1819 |
| 323 | 48.3 | **Technical Realisation** |  | 243d | 2000-04-10 A | 2001-03-14 A |  | 100% |  | 2000-04-10 | 2001-03-14 | 243d |  |  | T2 | 7776h | 7776h |  | Mes | 22.140, 23.140 | Josef Laumen, Siemens | Josef.Laumen@SAL.SIEMENS.DE |  | TSG |  | 1820 |
| 324 | 48.3.1 | Review of definition of reference Achitecture model |  | 243d | 2000-04-10 A | 2001-03-14 A |  | 100% |  | 2000-04-10 | 2001-03-14 | 243d |  | finish no earlier than 2001-03-14 | T2 | 1944h | 1944h |  | Mes | 22.140, 23.140 | Josef Laumen, Siemens | Josef.Laumen@SAL.SIEMENS.DE |  | TSG |  | 1821 |
| 325 | 48.3.2 | "Fulfill Requirements of Stage 1" |  | 243d | 2000-04-10 A | 2001-03-14 A |  | 100% |  | 2000-04-10 | 2001-03-14 | 243d |  | finish no earlier than 2001-03-14 | T2 | 1944h | 1944h |  | Mes | 22.140, 23.140 | Josef Laumen, Siemens | Josef.Laumen@SAL.SIEMENS.DE |  | TSG |  | 1822 |
| 326 | 48.3.3 | Definition of MMS primitives in Stage 2 |  | 243d | 2000-04-10 A | 2001-03-14 A |  | 100% |  | 2000-04-10 | 2001-03-14 | 243d |  | finish no earlier than 2001-03-14 | T2 | 1944h | 1944h |  | Mes | 22.140, 23.140 | Josef Laumen, Siemens | Josef.Laumen@SAL.SIEMENS.DE |  | TSG |  | 1823 |
| 327 | 49 | **Transcoder-Free Operation** |  | 325d | 2000-01-03 A | 2001-03-30 |  | 99% | 0d | 2000-01-03 | 2001-03-30 | 325d | 0d |  | N4 | 13040h | 10440h | TrFO | Cod |  |  |  | Rel-4 |  | Kimmo | 1541 |
| 328 | 49.1 | **OoBTC solution** |  | 325d | 2000-01-03 A | 2001-03-30 A |  | 100% |  | 2000-01-03 | 2001-03-30 | 325d |  |  | N4 | 8440h | 8440h | TRFO-OOBTC | Cod |  | Tosshiyuki Tamura, NEC | tamurato@elsf.ncos.nec.co.jp |  | WG |  | 112 |
| 329 | 49.1.1 | implementation in UTRAN |  | 145d | 2000-09-11 A | 2001-03-30 A |  | 100% |  | 2000-09-11 | 2001-03-30 | 145d |  | finish no earlier than 2001-03-30 | R3 | 1160h | 1160h | TRFO-OOBTC-UTRAN |  | 25.401, 25.410, 25.413, 25.415, 23.153 | Alexander Vesely, Siemens | alexander.vesely@SIEMENS.AT |  | TSG |  | 1512 |
| 330 | 49.1.2 | Impact on architecture, Principles and Terminology |  | 210d | 2000-01-03 A | 2000-10-20 A |  | 100% |  | 2000-01-03 | 2000-10-20 | 210d |  | finish no earlier than 2000-10-20 | S2 | 1680h | 1680h |  | Cod |  |  |  |  |  |  | 896 |
| 331 | 49.1.3 | Codec Negotiation between UE and MSC |  | 125d | 2000-08-14 A | 2001-02-02 A |  | 100% |  | 2000-08-14 | 2001-02-02 | 125d |  | finish no earlier than 2001-02-02 | N1 | 1000h | 1000h |  | Cod | 24.008, 23.009, 23.108, (29.002) | Andrew Howell / Motorola |  |  | TSG |  | 1657 |
| 332 | 49.1.4 | Codec Negotiation inter MSC |  | 125d | 2000-07-03 A | 2000-12-22 A |  | 100% |  | 2000-07-03 | 2000-12-22 | 125d |  | finish no earlier than 2000-12-22 | N4 | 1000h | 1000h |  | Cod |  |  |  |  |  |  | 115 |
| 333 | 49.1.5 | Bearer establishment inter MSC |  | 125d | 2000-07-03 A | 2000-12-22 A |  | 100% |  | 2000-07-03 | 2000-12-22 | 125d |  | finish no earlier than 2000-12-22 | N4 | 1000h | 1000h |  | Cod | 23.153 |  |  |  | TSG |  | 894 |
| 334 | 49.2 | **Speech Transcoder: Location and Control at the UMTS Core Network Border** |  | 125d | 2000-04-10 A | 2000-09-29 A |  | 100% |  | 2000-04-10 | 2000-09-29 | 125d |  |  | S2 | 2000h | 2000h | TRFO-STLC | Cod |  |  |  |  | WG |  | 905 |
| 335 | 49.2.1 | Transcoder at Edge |  | 125d | 2000-04-10 A | 2000-09-29 A |  | 100% |  | 2000-04-10 | 2000-09-29 | 125d |  | finish no earlier than 2000-09-29 | NP | 1000h | 1000h |  | Cod |  |  |  |  |  |  | 124 |
| 336 | 50 | **GERAN improvements 1 (Gb over IP)** |  | 225d | 2000-05-09 A | 2001-03-19 A |  | 100% |  | 2000-05-09 | 2001-03-19 | 225d |  |  | GP | 6472h | 6472h | GEIMP1 |  |  |  |  | Rel-4 | TSG | Paolo | 2310 |
| 337 | 50.1 | **Gb over IP (Ip-fication of Gb)** |  | 225d | 2000-05-09 A | 2001-03-19 A |  | 100% |  | 2000-05-09 | 2001-03-19 | 225d |  |  | GP | 4672h | 4672h | GbIP |  |  |  |  |  | TSG | Paolo | 2311 |
| 338 | 50.1.1 | Concept |  | 134d | 2000-05-09 A | 2000-11-10 A |  | 100% |  | 2000-05-09 | 2000-11-10 | 134d |  |  | GP | 1072h | 1072h |  |  |  |  |  |  | TSG |  | 2312 |
| 339 | 50.1.2 | Changes to 08.16, 08.18 |  | 225d | 2000-05-09 A | 2001-03-19 A |  | 100% |  | 2000-05-09 | 2001-03-19 | 225d |  |  | GP | 1800h | 1800h |  |  |  |  |  |  | TSG |  | 2313 |
| 340 | 51 | **GERAN improvements 2 (NACC)** |  | 815d | 2000-11-06 A | 2003-12-19 |  | 80% | 159.32d | 2000-11-06 | 2003-12-19 | 815d | 248d |  | GP | 24616h | 13616h | GEIMP2 |  |  |  |  | Rel-4 | TSG | Paolo | 2314 |
| 341 | 51.1 | **Gb enhancements** |  | 155d | 2000-11-06 A | 2001-06-08 A |  | 100% |  | 2000-11-06 | 2001-06-08 | 155d |  |  | GP | 7440h | 7440h | Gben |  |  |  |  |  | TSG | Paolo | 2315 |
| 342 | 51.1.1 | **Intra BSC NACC (Network Assisted Cell Change)** |  | 155d | 2000-11-06 A | 2001-06-08 A |  | 100% |  | 2000-11-06 | 2001-06-08 | 155d |  |  | GP | 6200h | 6200h |  |  |  |  |  |  | TSG |  | 2316 |
| 343 | 51.1.1.1 | Concept |  | 155d | 2000-11-06 A | 2001-06-08 A |  | 100% |  | 2000-11-06 | 2001-06-08 | 155d |  | finish no earlier than 2001-06-08 | GP | 1240h | 1240h |  |  |  |  |  |  | TSG |  | 2420 |
| 344 | 51.1.1.2 | Changes in 03.64 |  | 155d | 2000-11-06 A | 2001-06-08 A |  | 100% |  | 2000-11-06 | 2001-06-08 | 155d |  | finish no earlier than 2001-06-08 | GP | 1240h | 1240h |  |  |  |  |  |  | TSG |  | 2317 |
| 345 | 51.1.1.3 | Changes in 04.60 |  | 155d | 2000-11-06 A | 2001-06-08 A |  | 100% |  | 2000-11-06 | 2001-06-08 | 155d |  | finish no earlier than 2001-06-08 | GP | 1240h | 1240h |  |  |  |  |  |  | TSG |  | 2318 |
| 346 | 51.1.1.4 | Changes in 44.008 |  | 155d | 2000-11-06 A | 2001-06-08 A |  | 100% |  | 2000-11-06 | 2001-06-08 | 155d |  | finish no earlier than 2001-06-08 | GP | 1240h | 1240h |  |  |  |  |  |  | TSG |  | 2319 |
| 347 | 51.2 | Start Testing | milestone | 0d | 2001-06-04 | 2001-06-04 |  |  |  | 2001-06-04 | 2001-06-04 | 0d | 913d | start no earlier than 2001-06-04 |  |  |  |  |  |  |  |  |  |  |  |  |

Notes:
- 325: e.g. minimum set of media formats, media format conversion, personalization of MMS.
- 327: Lead given to CN4 from CN / [DAB 28/11/00]
- 329: moved according to NP-000575
- 330: e.g. study cascading TrFO/TFO/TrFO
- 331: the link to NP-000085has been deleted because refering to a R99 status sheet / One common set of codec negotiation procedures will be specified as in ID1656.
- 332: Bearer establishment inter MSC. TS 23.153 R99 part complete. capabilities moved to annex + list of open issues
- 333: Bearer establishment inter MSC. TS 23.153 R99 part complete. capabilities moved to annex. / See NP-000127 / Open issues: / Handling of Conference Calls; / Handling of Multi Party Supplementary Services; / Handling of Handover UMTS to GSM; / Handling of Sending a ...
- 334: WI description and Tdoc S2-99352 / Speech Transcoder: Location and Control at the UMTS Core Network Border
- 335: WI description and Tdoc S2-99352...

| ID | WBS | Task | Type | Duration | Start | Finish | Predecessors | Complete | Remaining | Baseline start | Baseline finish | Baseline duration | Total slack | Free slack | Constraint | Resources | Work | Actual work | Text1 | Text6 | Text7 | Text8 | Text9 | Text4 | Text2 | Text3 | Text5 |
| --- | --- | --- | --- | --- | --- | --- | --- | --- | --- | --- | --- | --- | --- | --- | --- | --- | --- | --- | --- | --- | --- | --- | --- | --- | --- | --- | --- |
| 348 | 51.3 | **MS conformance test for Intra BSC NACC** |  | 536d | 2001-11-30 A | 2003-12-19 |  | 50% | 268d | 2001-11-30 | 2003-12-19 | 536d | 248d |  |  | GP | 10656h | 5328h | GEIMP2-Msconf |  |  |  |  |  |  |  |  |
| 349 | 51.3.1 | Changes in 51.010 |  | 398d | 2001-11-30 A | 2003-12-19 |  | 50% | 199d | 2001-11-30 | 2003-12-19 | 398d | 248d |  | finish no earlier than 2003-12-19 | G5; G4 | 6368h | 3184h |  |  |  |  |  |  |  |  |  |
| 350 | 52 | **GERAN improvements 4 (Delayed TBF)** |  | 105d | 2001-01-15 A | 2001-06-08 A |  | 100% |  | 2001-01-15 | 2001-06-08 | 105d |  |  |  | GP | 3960h | 3960h | GEIMP4 | Rel-4 | TSG | Paolo | 2324 |  |  |  |  |
| 351 | 52.1 | **Gb enhancements 2** |  | 105d | 2001-01-15 A | 2001-06-08 A |  | 100% |  | 2001-01-15 | 2001-06-08 | 105d |  |  |  | GP | 3120h | 3120h | GEIMP4-Gben2 |  | TSG |  | 2325 |  |  |  |  |
| 352 | 52.1.1 | stage 2 |  | 105d | 2001-01-15 A | 2001-06-08 A |  | 100% |  | 2001-01-15 | 2001-06-08 | 105d |  |  | finish no earlier than 2001-06-08 | GP | 840h | 840h |  |  |  |  | 2429 |  |  |  |  |
| 353 | 52.1.2 | **Stage 3 (changes in 44.060)** |  | 60d | 2001-01-15 A | 2001-04-06 A |  | 100% |  | 2001-01-15 | 2001-04-06 | 60d |  |  |  | G2 | 1440h | 1440h |  |  | TSG |  | 2421 |  |  |  |  |
| 354 | 52.1.2.1 | Definition of enhanced countdown procedure |  | 60d | 2001-01-15 A | 2001-04-06 A |  | 100% |  | 2001-01-15 | 2001-04-06 | 60d |  |  | finish no earlier than 2001-04-06 | G2 | 480h | 480h |  |  | TSG |  | 2327 |  |  |  |  |
| 355 | 52.1.2.2 | Definition of enhanced TBF release procedure |  | 60d | 2001-01-15 A | 2001-04-06 A |  | 100% |  | 2001-01-15 | 2001-04-06 | 60d |  |  | finish no earlier than 2001-04-06 | G2 | 480h | 480h |  |  | TSG |  | 2328 |  |  |  |  |
| 356 | 52.1.2.3 | Definition of USF=FREE type polling mechanism on PDCH |  | 60d | 2001-01-15 A | 2001-04-06 A |  | 100% |  | 2001-01-15 | 2001-04-06 | 60d |  |  | finish no earlier than 2001-04-06 | G2 | 480h | 480h |  |  | TSG |  | 2329 |  |  |  |  |
| 357 | 53 | **Low Chip Rate TDD option** |  | 880d | 2000-07-19 A | 2003-12-02 |  | 76% | 208.03d | 2000-07-19 | 2003-09-25 | 832d | 261d |  |  | R1 | 25872h | 19687.3h | LCRTDD | Rel-4 | TSG | Tsukasa | 1222 | G. Yang, CWTS |  |  |  |
| 358 | 53.1 | Physical layer |  | 183d | 2000-07-19 A | 2001-03-30 A |  | 100% |  | 2000-07-19 | 2001-03-30 | 183d |  |  | finish no earlier than 2001-03-30 | R1 | 1464h | 1464h | LCRTDD-Phys |  | TSG |  | 1223 | G. Yang, CWTS |  |  |  |
| 359 | 53.2 | Layer 2 and layer 3 protocol aspects |  | 183d | 2000-07-19 A | 2001-03-30 A |  | 100% |  | 2000-07-19 | 2001-03-30 | 183d |  |  | finish no earlier than 2001-03-30 | R2 | 1464h | 1464h | LCRTDD-L23 |  | TSG |  | 1224 | Y. Liu, CWTS | BaAS |  |  |
| 360 | 53.3 | RF radio transmission/reception, system performance requirements and conformance testing |  | 165d | 2000-08-14 A | 2001-03-30 A |  | 100% |  | 2000-08-14 | 2001-03-30 | 165d |  |  | finish no earlier than 2001-03-30 | R4 | 1320h | 1320h | LCRTDD-RF |  | TSG |  | 1225 | D. Zhang, CWTS | BaAS |  |  |
| 361 | 53.4 | UE radio access capability |  | 165d | 2000-08-14 A | 2001-03-30 A |  | 100% |  | 2000-08-14 | 2001-03-30 | 165d |  |  | finish no earlier than 2001-03-30 | R2 | 1320h | 1320h | LCRTDD-UErac |  | TSG |  | 1227 | Y. Liu, CWTS | BaAS |  |  |
| 362 | 53.5 | Iub/Iur protocol aspects |  | 165d | 2000-08-14 A | 2001-03-30 A |  | 100% |  | 2000-08-14 | 2001-03-30 | 165d |  |  | finish no earlier than 2001-03-30 | R3 | 1320h | 1320h | LCRTDD-IubIur |  | TSG |  | 1228 | Y. Liu, CWTS | BaAS |  |  |
| 363 | 53.6 | **Low chiprate TDD interworking with GERAN** |  | 101d | 2000-09-01 A | 2001-01-19 A | 362 | 100% |  | 2000-09-01 | 2001-01-19 | 101d |  |  |  |  |  |  |  |  |  | Paolo | 2262 |  |  |  |  |
| 364 | 53.6.1 | Handover and Cell Selection / Reselection to UTRA 1.28 Mcps TDD |  | 101d | 2000-09-01 A | 2001-01-19 A |  | 100% |  | 2000-09-01 | 2001-01-19 | 101d |  |  | finish no earlier than 2001-01-19 |  |  |  |  |  |  |  | 2263 |  |  |  |  |
| 365 | 53.7 | Start Testing | milestone | 0d | 2001-09-03 | 2001-09-03 | 363 |  |  | 2001-09-03 | 2001-09-03 | 0d | 571.11d | 10d | start no earlier than 2001-09-03 | MLST |  |  |  |  |  |  | 1911 |  |  |  |  |
| 366 | 53.8 | **Conformance Test Aspects - Low Chip Rate TDD** |  | 577d | 2001-09-17 A | 2003-12-02 | 365 | 52% | 276.89d | 2001-09-17 | 2003-09-25 | 529d | 261d |  |  | T1 | 12088h | 6287.31h |  |  |  |  | 2103 |  |  | 0% |  |
| 367 | 53.8.1 | Testing Layer 2 and layer 3 protocol aspects |  | 468d | 2001-09-17 A | 2003-07-02 |  | 60% | 187.2d | 2001-09-17 | 2002-12-02 | 316d | 370d |  | finish no earlier than 2003-07-02 | T1 | 3744h | 2246.4h |  |  | TSG |  | 2217 |  |  | 34.123-1, 34.123-2 |  |
| 368 | 53.8.2 | Testing Layer 2 and layer 3 protocol aspects - TTCN |  | 261d | 2002-12-03 | 2003-12-02 |  |  |  | 2002-12-03 | 2003-09-25 | 213d | 261d |  | finish no earlier than 2003-12-02 | T1 | 2088h |  |  |  | TSG |  |  |  |  | 34.123-3 |  |
| 369 | 53.8.3 | Testing RF Radio Transmission and Reception |  | 205d | 2001-09-17 A | 2002-06-28 A |  | 100% |  | 2001-09-17 | 2002-06-28 | 205d |  |  | finish no earlier than 2002-06-28 | T1 | 1640h | 1640h |  |  | TSG |  | 2218 |  |  |  |  |
| 370 | 54 | **Enable bearer independent CS architecture** |  | 565d | 2000-01-03 A | 2002-03-01 |  | 80% | 114.5d | 2000-01-03 | 2002-03-01 | 565d | 718d |  |  | S2 | 20176h | 13788h | CSSPLIT | Rel-4 | TSG | Kimmo |  | Alexander Milinski, Siemens |  |  |  |
| 371 | 54.1 | **Enable bearer-independent call control** |  | 424d | 2000-01-03 A | 2001-08-16 |  | 99% | 0d | 2000-01-03 | 2001-08-16 | 424d | 0d |  |  | N4 | 12336h | 8944h |  |  | WG |  | 1323 | Heinz-Peter Keutman, Ericsson | CCaR |  | Heinz-Peter.Keutmann@eed.ericsson.se |
| 372 | 54.1.1 | Architecture and Stage 2 description |  | 180d | 2000-01-03 A | 2000-09-08 A |  | 100% |  | 2000-01-03 | 2000-09-08 | 180d |  |  | finish no earlier than 2000-09-08 | S2 | 1440h | 1440h |  |  |  |  | 1516 |  | CCaR | 23.002 |  |
| 373 | 54.1.2 | Standardisation of protocols (control & user planes) over Nb interface |  | 64d | 2001-01-02 A | 2001-03-30 A |  | 100% |  | 2001-01-02 | 2001-03-30 | 64d |  |  | finish no earlier than 2001-03-30 | N3 | 512h | 512h |  |  | TSG |  | 1325 |  | CCaR |  |  |
| 374 | 54.1.3 | Standardisation of protocols over reference points between MSC server and Gateway MSC server |  | 130d | 2000-09-25 A | 2001-03-23 A |  | 100% |  | 2000-09-25 | 2001-03-23 | 130d |  |  | finish no earlier than 2001-03-23 | N4 | 1040h | 1040h |  |  | TSG |  | 1326 |  | CCaR |  |  |
| 375 | 54.1.4 | Standardisation of detailed stage 2 description |  | 180d | 2000-07-17 A | 2001-03-23 A |  | 100% |  | 2000-07-17 | 2001-03-23 | 180d |  |  | finish no earlier than 2001-03-23 | N4 | 1440h | 1440h |  |  | TSG |  | 1616 |  |  |  |  |

Notes:
- 348: Started
- 367: duration set to 6 months (was 0)
- 369: duration set to 6 months (was 0), finish date set
- 371: DAB 12.12.01 should be 100% hence closed
- 372: R00 stage 2 at least 80 % complete in TSGS #8 21.-23.6.2000

| ID | WBS | Task | Type | Duration | Start | Finish | Predecessors | Complete | Remaining | Baseline start | Baseline finish | Baseline duration | Total slack | Free slack | Constraint | Resources | Work | Actual work | Text2 | Text7 | Text9 | Text1 | Text3 | Text6 | Text8 | Text4 | Text5 |
| --- | --- | --- | --- | --- | --- | --- | --- | --- | --- | --- | --- | --- | --- | --- | --- | --- | --- | --- | --- | --- | --- | --- | --- | --- | --- | --- | --- |
| 376 | 54.1.5 | **Bearer control between MSC server and MGW** |  | 250d | 2000-09-01 A | 2001-08-16 A |  | 100% |  | 2000-09-01 | 2001-08-16 | 250d |  |  |  | N4 | 4512h | 4512h | CCaR | TSG | 1327 |  |  |  |  |  |  |
| 377 | 54.1.5.1 | stage 3 - protocol issues |  | 250d | 2000-09-01 A | 2001-08-16 A |  | 100% |  | 2000-09-01 | 2001-08-16 | 250d |  |  | finish no earlier than 2001-08-16 | N4 | 2000h | 2000h | CCaR | TSG | 1328 |  |  |  |  |  |  |
| 378 | 54.1.5.2 | stage 3 - parameter value issues |  | 64d | 2001-01-02 A | 2001-03-30 A |  | 100% |  | 2001-01-02 | 2001-03-30 | 64d |  |  | finish no earlier than 2001-03-30 | N3 | 512h | 512h | CCaR |  | 1329 |  |  |  |  |  |  |
| 379 | 54.2 | Lawful interception |  | 155d | 2000-08-21 A | 2001-03-23 A |  | 100% |  | 2000-08-21 | 2001-03-23 | 155d |  |  | finish no earlier than 2001-03-23 | S3 | 1240h | 1240h | CCaR |  | 1331 |  |  |  |  |  |  |
| 380 | 54.3 | Start Testing | milestone | 0d | 2001-03-05 | 2001-03-05 |  |  |  | 2001-03-05 | 2001-03-05 | 0d | 718d | 0d | start no earlier than 2001-03-05 | MLST |  |  |  |  | 1918 |  |  |  |  |  |  |
| 381 | 54.4 | Conformance Test Aspects - Enable bearer independent CS architecture |  | 260d | 2001-03-05 | 2002-03-01 | 380 |  |  | 2001-03-05 | 2002-03-01 | 260d | 718d |  |  | T1 | 2080h |  |  |  |  | CSSPLIT-TEST | 0% |  |  |  |  |
| 382 | 55 | **MExE enhancements Rel-4** |  | 802d | 2000-01-03 A | 2003-01-28 |  | 88% | 96.68d | 2000-01-03 | 2003-01-28 | 802d | 481d |  |  | T2 | 22768h | 20426.6h | Ter | TSG | 1445 | MEXE |  | Rel-4 | Friedhelm |  |  |
| 383 | 55.1 | **MExE Security Analysis Activity** |  | 474d | 2000-02-22 A | 2001-12-14 A |  | 100% |  | 2000-02-22 | 2001-12-14 | 474d |  |  |  | S3 | 8464h | 8464h | Ter | TSG | 1447 | MEXE-SEC |  |  |  | Colin Blanchard, BT | colin.blanchard@bt.com |
| 384 | 55.1.1 | Stage 3 |  | 370d | 2000-07-17 A | 2001-12-14 A |  | 100% |  | 2000-07-17 | 2001-12-14 | 370d |  |  | finish no earlier than 2001-12-14 | S3 | 2960h | 2960h | Ter |  | 2045 | MEXE1-SEC |  |  |  |  |  |
| 385 | 55.1.2 | Terminal aspects |  | 214d | 2000-02-22 A | 2000-12-15 A |  | 100% |  | 2000-02-22 | 2000-12-15 | 214d |  |  | finish no earlier than 2000-12-15 | T2 | 1712h | 1712h | Ter |  | 1448 |  |  |  |  |  |  |
| 386 | 55.2 | **MExE Rel4 Improvements and Investigations** |  | 250d | 2000-01-03 A | 2000-12-15 |  | 99% | 0d | 2000-01-03 | 2000-12-15 | 250d | 0d |  |  | T2 | 6480h | 6320h | Ter | TSG | 1810 | MEXE-ENHANC | 22.057, 23.057 |  |  | Mark CATALDO, Motorola | mcatald1@MOTOROLA.COM |
| 387 | 55.2.1 | 3rd MExE classmark |  | 250d | 2000-01-03 A | 2000-12-15 A |  | 100% |  | 2000-01-03 | 2000-12-15 | 250d |  |  | finish no earlier than 2000-12-15 | T2 | 2000h | 2000h | Ter | TSG | 1812 |  | 22.057, 23.057 |  |  | Mark CATALDO, Motorola | mcatald1@MOTOROLA.COM |
| 388 | 55.2.2 | FS on Secure download mechanism and capabilities to support SDR concepts |  | 225d | 2000-02-07 A | 2000-12-15 A |  | 100% |  | 2000-02-07 | 2000-12-15 | 225d |  |  | finish no earlier than 2000-12-15 | T2 | 1800h | 1800h | Ter | TSG | 1814 |  | 22.057, 23.057 |  |  | Mark CATALDO, Motorola | mcatald1@MOTOROLA.COM |
| 389 | 55.2.3 | FS on Support of MP3/MPEG4 content |  | 225d | 2000-02-07 A | 2000-12-15 A |  | 100% |  | 2000-02-07 | 2000-12-15 | 225d |  |  | finish no earlier than 2000-12-15 | T2 | 1800h | 1800h | Ter | TSG | 1815 |  | 22.057, 23.057 |  |  | Mark CATALDO, Motorola | mcatald1@MOTOROLA.COM |
| 390 | 55.3 | DELETE: Conformance testing of MExE capability (Feasibility study) |  | 176d | 2002-05-28 | 2003-01-28 |  |  |  | 2002-05-28 | 2003-01-28 | 176d | 481d |  | finish no earlier than 2003-01-28 | T1 | 1408h |  |  | TSG |  |  |  | Rel-4 |  |  |  |
| 391 | 56 | **Tandem Free aspects for 3G and between 2G and 3G systems** |  | 344d | 2000-02-22 A | 2001-06-15 A |  | 100% |  | 2000-02-22 | 2001-06-15 | 344d |  |  |  | S4 | 9696h | 9696h | Cod |  | 1631 | TFO |  | Rel-4 | Paolo |  |  |
| 392 | 56.1 | **Tandem Free AMR** |  | 344d | 2000-02-22 A | 2001-06-15 A |  | 100% |  | 2000-02-22 | 2001-06-15 | 344d |  |  |  | S4 | 6944h | 6944h | Cod |  | 1632 | TFO-AMR |  |  |  |  |  |
| 393 | 56.1.1 | Specification |  | 284d | 2000-02-22 A | 2001-03-23 A |  | 100% |  | 2000-02-22 | 2001-03-23 | 284d |  |  | start no earlier than 2000-02-22 | S4 | 2272h | 2272h | Cod |  | 130 |  | 28.062 |  |  |  |  |
| 394 | 56.1.2 | **Impact on:** |  | 115d | 2001-01-08 A | 2001-06-15 A |  | 100% |  | 2001-01-08 | 2001-06-15 | 115d |  |  |  | NP | 1920h | 1920h | Cod |  | 907 |  |  |  |  |  |  |
| 395 | 56.1.2.1 | CN |  | 60d | 2001-03-26 A | 2001-06-15 A |  | 100% |  | 2001-03-26 | 2001-06-15 | 60d |  |  | finish no earlier than 2001-06-15 | NP | 480h | 480h | Cod |  | 131 |  |  |  |  |  |  |
| 396 | 56.1.2.2 | GERAN |  | 65d | 2001-01-08 A | 2001-04-06 A |  | 100% |  | 2001-01-08 | 2001-04-06 | 65d |  |  | finish no earlier than 2001-04-06 | GP | 520h | 520h | Cod |  | 132 |  |  |  |  |  |  |
| 397 | 57 | **Advanced Speech Call Items enhancements_REL-4** |  | 334d | 2000-12-03 A | 2002-03-14 A |  | 100% |  | 2000-12-03 | 2002-03-14 | 334d |  |  |  | N1 | 5925.6h | 5925.6h |  | TSG | 2230 | ASCI |  | Rel-4 | Per | Sonia Garapaty | sonia.garapaty@nortelnetworks.com |
| 398 | 57.1 | Stage 2 |  | 326.7d | 2000-12-03 A | 2002-03-14 A |  | 100% |  | 2000-12-03 | 2002-03-14 | 326.7d |  |  | finish no earlier than 2002-03-14 | N4 | 2613.6h | 2613.6h |  | WG | 2232 |  | 23.067, 24.067 |  | Kimmo | Vivien Perlic, Sagem |  |
| 399 | 57.2 | Stages 2 and 3 on A interface |  | 80d | 2000-12-03 A | 2001-03-23 A |  | 100% |  | 2000-12-03 | 2001-03-23 | 80d |  |  | finish no earlier than 2001-03-23 | N1 | 640h | 640h |  | WG | 2231 |  | 44.068, 44.069, 24.008 |  | Per | Sonia Garapaty | sonia.garapaty@nortelnetworks.com |

Notes:
- 379: Requirements capture: S3#14 (Aug 00), Feature specification: S3#15 (Sep 00), Definition of architecture. Should be included in general LI work mentioned above.
- 383: Presentation to S3 of threats and countermeasures analysis: S3#15, Feature specification: S3#16. S3#18: WID updated
- 384: Analysis undertaken by T2. No additional analysis needed for Rel-4
- 387: Additional features for MExE R2000
- 391: RAN and CN to verify no problems for GSM terminals roaming in 3G R99
- 392: RAN and CN to verify UMTS_AMR_2 support
- 394: "Implementation" changed to "Impact on:" by A. Sultan (for better wording)
- 395: RAN and CN to verify UMTS_AMR_2 support
- 396: End date Modified from June to March to have it in Rel4
- 397: Approved in TSGN_10
- 398: CN4#11 30/11/02: no inputs received in CN4

| ID | WBS | Task | Duration | Start | Finish | Complete | Remaining | Baseline start | Baseline finish | Baseline duration | Total slack | Constraint | Resources | Work | Actual work | Text1 | Text6 | Text8 | Text9 | Text5 | Text7 | Text3 | Text2 |
| --- | --- | --- | --- | --- | --- | --- | --- | --- | --- | --- | --- | --- | --- | --- | --- | --- | --- | --- | --- | --- | --- | --- | --- |
| 400 | 58 | **700 MHz spectrum support** | 775d | 2000-01-03 A | 2002-12-20 | 99% | 0d | 2000-01-03 | 2002-12-20 | 775d | 0d |  | GP | 25000h | 18800h | 700SS | Rel-4 | Paolo | 2403 |  |  |  |  |
| 401 | 58.1 | **GERAN support for the 700 MHz band** | 275d | 2000-01-03 A | 2001-01-19 A | 100% |  | 2000-01-03 | 2001-01-19 | 275d |  |  | GP | 8800h | 8800h |  |  |  | 2404 |  |  |  |  |
| 402 | 58.1.1 | Signalling support | 275d | 2000-01-03 A | 2001-01-19 A | 100% |  | 2000-01-03 | 2001-01-19 | 275d |  | finish no earlier than 2001-01-19 | GP | 2200h | 2200h |  |  |  | 2405 |  |  |  |  |
| 403 | 58.1.2 | Physical layer definitions | 275d | 2000-01-03 A | 2001-01-19 A | 100% |  | 2000-01-03 | 2001-01-19 | 275d |  | finish no earlier than 2001-01-19 | GP | 2200h | 2200h |  |  |  | 2406 |  |  |  |  |
| 404 | 58.1.3 | Receiver performance and RF budget | 275d | 2000-01-03 A | 2001-01-19 A | 100% |  | 2000-01-03 | 2001-01-19 | 275d |  | finish no earlier than 2001-01-19 | GP | 2200h | 2200h |  |  |  | 2407 |  |  |  |  |
| 405 | 58.2 | **GERAN MS Conformance test for 700 MHz band** | 175d | 2001-04-02 A | 2001-11-30 A | 100% |  | 2001-04-02 | 2001-11-30 | 175d |  |  | GP | 2800h | 2800h |  |  |  | 2408 |  |  |  |  |
| 406 | 58.2.1 | MS test | 175d | 2001-04-02 A | 2001-11-30 A | 100% |  | 2001-04-02 | 2001-11-30 | 175d |  | finish no earlier than 2001-11-30 | GP | 1400h | 1400h |  |  |  | 2409 |  |  |  |  |
| 407 | 58.3 | **GERAN BTS Conformance test for 700 MHz band** | 450d | 2001-04-02 A | 2002-12-20 A | 100% |  | 2001-04-02 | 2002-12-20 | 450d |  |  | GP | 7200h | 7200h |  |  | Paolo | 2410 |  |  |  |  |
| 408 | 58.3.1 | BTS test | 450d | 2001-04-02 A | 2002-12-20 A | 100% |  | 2001-04-02 | 2002-12-20 | 450d |  | finish no earlier than 2002-12-20 | GP | 3600h | 3600h |  |  |  | 2411 |  |  |  |  |
| 409 | 59 | Operator Determined Barring for Packet Oriented Services | 208d | 2000-06-01 A | 2001-03-19 A | 100% |  | 2000-06-01 | 2001-03-19 | 208d |  | finish no earlier than 2001-03-19 | NP | 1664h | 1664h | ODB | Rel-4 |  | 2463 | tamurato@nsf.ncos.nec.co.jp | TSG |  |  |
| 410 | 60 | **UMTS QoS Architecture for PS Domain** | 758d | 2000-01-03 A | 2002-11-27 | 61% | 295.18d | 2000-01-03 | 2002-11-27 | 758d | 525d |  | S2 | 54256h | 20605.3h | QoSPS | Rel-4 |  |  | Ina.widegren@era.ericsson.se | TSG |  |  |
| 411 | 60.1 | Architecture | 153d | 2000-06-05 A | 2001-01-03 A | 100% |  | 2000-06-05 | 2001-01-03 | 153d |  | finish no earlier than 2001-01-03 | S2 | 1224h | 1224h |  |  |  |  |  | TSG | 23.107 |  |
| 412 | 60.2 | Charging and OAM&P for QoS Management | 201d | 2001-09-21 A | 2002-06-28 A | 100% |  | 2001-09-21 | 2002-06-28 | 201d |  | finish no earlier than 2002-06-28 | S5 | 1608h | 1608h | QoSPS-OAM |  |  |  | Albert.Yuhan@voicestream.com; Michael.Truss@MOTOROLA.COM | TSG | 32-series |  |
| 413 | 60.3 | **RAB Quality of Service (re)Negotiation over Iu** | 155d | 2000-08-21 A | 2001-03-23 | 99% | 0d | 2000-08-21 | 2001-03-23 | 155d | 0d |  | R3 | 3648h | 2501.6h | QoSPS-MAPEND-RABQoS |  |  | 1681 |  | TSG | 25.413 |  |
| 414 | 60.3.1 | RAB Quality of Service Negotiation over Iu | 155d | 2000-08-21 A | 2001-03-23 A | 100% |  | 2000-08-21 | 2001-03-23 | 155d |  | finish no earlier than 2001-03-23 | R3 | 1240h | 1240h | QoSPS-MAPEND-RABQoS-Negot |  |  | 1991 |  | TSG |  |  |
| 415 | 60.3.2 | RAB Quality of Service Negotiation over Iu during relocation | 16d | 2001-03-02 A | 2001-03-23 A | 100% |  | 2001-03-02 | 2001-03-23 | 16d |  | start no earlier than 2001-03-02 | R3 | 128h | 128h | QoSPS-MAPEND-RABQoS-NegotReloc |  |  | 2456 |  | TSG |  |  |
| 416 | 60.3.3 | RAB Quality of Service Re-Negotiation over Iu | 130d | 2000-09-25 A | 2001-03-23 A | 100% |  | 2000-09-25 | 2001-03-23 | 130d |  | finish no earlier than 2001-03-23 | R3 | 1040h | 1040h | QoSPS-MAPEND-RABQoS-ReNegot |  |  | 1992 |  | TSG |  |  |
| 417 | 60.4 | **GERAN QoS Aspects - Handovers: maintenance of real-time QoS while moving between cells in the PLMN including inter-SGSN and SRNS relocation or possibly other mechanisms** | 500d | 2000-01-03 A | 2001-11-30 | 99% | 0d | 2000-01-03 | 2001-11-30 | 500d | 0d |  | GP | 14440h | 10544h | GERQoS |  | Paolo | 1553 |  | TSG |  | QoS |
| 418 | 60.4.1 | **Handover Concept for the PS domain** | 500d | 2000-01-03 A | 2001-11-30 | 99% | 0d | 2000-01-03 | 2001-11-30 | 500d | 0d |  | GP | 10440h | 6544h |  |  |  | 2306 |  | TSG |  |  |
| 419 | 60.4.1.1 | Stable RT handover report 25.936 including header removal | 13d | 2000-01-03 A | 2000-01-19 A | 100% |  | 2000-01-03 | 2000-01-19 | 13d |  | start no earlier than 2000-01-03 | GP | 104h | 104h |  |  |  | 2309 |  | TSG |  |  |
| 420 | 60.4.1.2 | Update of stage 2 | 292d | 2000-01-03 A | 2001-02-13 A | 100% |  | 2000-01-03 | 2001-02-13 | 292d |  | finish no earlier than 2001-02-13 | GP | 2336h | 2336h |  |  |  | 2307 |  | TSG |  |  |
| 421 | 60.4.1.3 | Update of relevant stage 3 specs -> RRC | 500d | 2000-01-03 A | 2001-11-30 A | 100% |  | 2000-01-03 | 2001-11-30 | 500d |  | finish no earlier than 2001-11-30 | G2 | 4000h | 4000h |  |  |  | 2308 |  | TSG |  |  |
| 422 | 60.5 | **GERAN MS Conformance test for inter-system and intra-system Packet data real-time Handover** | 324d | 2001-08-31 | 2002-11-27 |  |  | 2001-08-31 | 2002-11-27 | 324d | 525d |  | G4; R3 | 25920h |  | GERQoS-Mstest |  |  |  |  | TSG |  |  |
| 423 | 60.5.1 | **Handover for the PS domain** | 324d | 2001-08-31 | 2002-11-27 |  |  | 2001-08-31 | 2002-11-27 | 324d | 525d |  | G4; R3 | 20736h |  |  |  |  |  |  | TSG |  |  |
| 424 | 60.5.1.1 | Stable RT handover report 25.936 including header removal | 324d | 2001-08-31 | 2002-11-27 |  |  | 2001-08-31 | 2002-11-27 | 324d | 525d | finish no earlier than 2002-11-27 | G4; R3 | 5184h |  |  |  |  |  |  | TSG |  |  |
| 425 | 60.5.1.2 | Update of stage 2 | 324d | 2001-08-31 | 2002-11-27 |  |  | 2001-08-31 | 2002-11-27 | 324d | 525d | finish no earlier than 2002-11-27 | G4; R3 | 5184h |  |  |  |  |  |  | TSG |  |  |
| 426 | 60.5.1.3 | Update of relevant stage 3 specs | 324d | 2001-08-31 | 2002-11-27 |  |  | 2001-08-31 | 2002-11-27 | 324d | 525d | finish no earlier than 2002-11-27 | G4; R3 | 5184h |  |  |  |  |  |  | TSG |  |  |
| 427 | 60.6 | PS-domain handover for real-time services | 155d | 2000-08-28 A | 2001-03-30 A | 100% |  | 2000-08-28 | 2001-03-30 | 155d |  | finish no earlier than 2001-03-30 | R3 | 1240h | 1240h | QoSPS-PSdoRTS |  |  | 1685 |  | TSG |  | QoS |
| 428 | 60.7 | RAB QoS Renegotiation at Relocation | 58d | 2001-01-03 | 2001-03-23 |  |  | 2001-01-03 | 2001-03-23 | 58d | 963d | finish no earlier than 2001-03-23 | R3 | 464h |  |  |  |  |  |  | TSG | 25.851, 25.946 |  |
| 429 | 61 | small Technical Enhancements and Improvements for Rel4 | 325d | 2000-01-03 A | 2001-03-30 A | 100% |  | 2000-01-03 | 2001-03-30 | 325d |  |  | Generic | 2600h | 2600h | TEI4 | Rel-4 |  | 1993 |  | TSG |  |  |

Notes:
- 409: Completed WI missing from the P-plan Added for tracking / Text4: oshiyuki Tamura
- 410: Text4: Ina Widegren, Ericsson
- 412: Text4: Albert YUHAN (VoiceStream Wireless), Michael TRUSS (Motorola)
- 413: Text4: A. Molander, Ericsson
- 414: Text4: A. Molander, Ericsson
- 416: Text4: S. Irwin, Motorola
- 422: Still exist? To be clarified by GERAN4/5
- 427: Text4: A. Lansisalmi, Nokia
- 429: "Joker" WI, to be used for a Rel 4 CR not related to any feature and with very limited impact on the system

| ID | WBS | Task | Duration | Start | Finish | Complete | Remaining | Baseline start | Baseline finish | Baseline duration | Total slack | Constraint | Resources | Work | Actual work | Text1 | Text4 | Text6 | Text7 | Text8 | Text2 | Text9 | Text3 | Text5 |
| --- | --- | --- | --- | --- | --- | --- | --- | --- | --- | --- | --- | --- | --- | --- | --- | --- | --- | --- | --- | --- | --- | --- | --- | --- |
| 430 | 62 | **Rel-4 Evolutions of the transport in the UTRAN** | 525d | 2000-08-21 A | 2002-08-23 | 69% | 162.5d | 2000-08-21 | 2002-08-23 | 525d | 593d |  | RP | 8600h | 6501.38h | ETRAN | Francois Courau | NA | TSG | Joern |  |  |  |  |
| 431 | 62.1 | QoS optimisation for AAL2 connections over Iub and Iur interfaces | 160d | 2000-08-21 A | 2001-03-30 A | 100% |  | 2000-08-21 | 2001-03-30 | 160d |  | finish no earlier than 2001-03-30 | R3 | 1280h | 1280h | ETRAN-QoSAAL2 | T. Yoshimura, Japan Telecom | Rel-4 | TSG |  | BaAS | 12 |  |  |
| 432 | 62.2 | Transport bearer modification procedure on Iub, Iur, and Iu | 130d | 2000-10-02 A | 2001-03-30 A | 100% |  | 2000-10-02 | 2001-03-30 | 130d |  | finish no earlier than 2001-03-30 | R3 | 1040h | 1040h | ETRAN-MigrMod | T. Yoshimura, Japan Telecom | Rel-4 | TSG |  |  | 1995 |  |  |
| 433 | 62.3 | **Conformance Test Aspects of Rel-4 evolutions of the transport in UTRAN** | 130d | 2002-02-25 | 2002-08-23 |  |  | 2002-02-25 | 2002-08-23 | 130d | 593d |  | T1 | 2080h |  |  |  |  |  |  |  | 1834 |  |  |
| 434 | 62.3.1 | Testing RAB support enhancements | 130d | 2002-02-25 | 2002-08-23 |  |  | 2002-02-25 | 2002-08-23 | 130d | 593d | finish no earlier than 2002-08-23 | T1 | 1040h |  | CT-RABS? |  |  |  |  |  | 2208 | 34.108, 34. 121, 34.122, 34.123 pts 1,2, 34.123 pt 3 |  |
| 435 | 63 | **Rel-4 Evolutions of the transport in the CN** | 215d | 2000-05-29 A | 2001-03-23 A | 100% |  | 2000-05-29 | 2001-03-23 | 215d |  |  | N4 | 7968h | 7968h | CNTRSP |  | NA |  | Kimmo | BaAS |  |  |  |
| 436 | 63.1 | **IP Transport of CN protocols (e.g., CAP, MAP)** | 77d | 2000-12-07 A | 2001-03-23 A | 100% |  | 2000-12-07 | 2001-03-23 | 77d |  |  | N4 | 2808h | 2808h | SS7IP |  | Rel-4 |  |  | BaAS | 859 |  |  |
| 437 | 63.1.1 | **Stage 3** | 77d | 2000-12-07 A | 2001-03-23 A | 100% |  | 2000-12-07 | 2001-03-23 | 77d |  |  | N4 | 2192h | 2192h |  |  |  |  |  |  | 1679 |  |  |
| 438 | 63.1.1.1 | CAP | 77d | 2000-12-07 A | 2001-03-23 A | 100% |  | 2000-12-07 | 2001-03-23 | 77d |  | finish no earlier than 2001-03-23 | N2 | 616h | 616h |  |  |  | WG |  |  | 2018 |  |  |
| 439 | 63.1.1.2 | MAP | 77d | 2000-12-07 A | 2001-03-23 A | 100% |  | 2000-12-07 | 2001-03-23 | 77d |  | finish no earlier than 2001-03-23 | N4 | 616h | 616h |  |  |  |  |  |  | 2019 |  |  |
| 440 | 63.1.1.3 | BSSAP+ | 43d | 2001-01-15 A | 2001-03-14 A | 100% |  | 2001-01-15 | 2001-03-14 | 43d |  | finish no earlier than 2001-03-14 | N1 | 344h | 344h | SS7IP-BSSAP+ |  |  | WG |  | Loc | 2253 |  |  |
| 441 | 63.2 | **FS on Transport and control separation in the PS CN domain** | 215d | 2000-05-29 A | 2001-03-23 A | 100% |  | 2000-05-29 | 2001-03-23 | 215d |  |  | S2 | 3440h | 3440h |  | Juan-Antonio Ibanez, Ericsson Deutschland | Rel-4 | TSG |  | BaAS | 1513 |  | Juan-Antonio.Ibanez@eed.ericsson.se |
| 442 | 63.2.1 | Architectural impacts | 215d | 2000-05-29 A | 2001-03-23 A | 100% |  | 2000-05-29 | 2001-03-23 | 215d |  | finish no earlier than 2001-03-23 | S2 | 1720h | 1720h |  |  |  | WG |  | BaAS | 1615 |  |  |
| 443 | 64 | **Rel-4 Improvements of Radio Interface** | 700d | 2000-07-10 A | 2003-03-14 | 83% | 117.46d | 2000-07-10 | 2003-03-14 | 700d | 448d |  | RP | 28624h | 23247.4h | RInImp |  | NA | TSG | Tsukasa |  |  |  |  |
| 444 | 64.1 | UTRA repeater specification (master) | 183d | 2000-07-10 A | 2001-03-21 A | 100% |  | 2000-07-10 | 2001-03-21 | 183d |  | finish no earlier than 2001-03-21 | R4 | 1464h | 1464h | RInImp-REP | T. Kummetz, Mikom; Alf Ahlström, Allgon | Rel-4 | TSG |  |  | 1509 |  |  |
| 445 | 64.2 | DSCH power control improvement in soft handover | 140d | 2000-09-11 A | 2001-03-23 A | 100% |  | 2000-09-11 | 2001-03-23 | 140d |  | finish no earlier than 2001-03-23 | R1 | 1120h | 1120h | RInImp-DSCHsho | A. Toskala, Nokia | Rel-4 | TSG |  |  | 1994 |  |  |
| 446 | 64.3 | UMTS 1800 | 320d | 2000-09-25 A | 2001-12-14 A | 100% |  | 2000-09-25 | 2001-12-14 | 320d |  | finish no earlier than 2001-12-14 | R4 | 2560h | 2560h | RInImp-UMTS18 | H. Benn, Motorola | Rel indep | TSG |  |  | 1996 |  |  |
| 447 | 64.4 | UMTS 1900 | 195d | 2001-03-19 A | 2001-12-14 A | 100% |  | 2001-03-19 | 2001-12-14 | 195d |  | finish no earlier than 2001-12-14 | R4 | 1560h | 1560h | RInImp-UMTS19 | Howard Benn, Motorola | Rel indep | TSG | Cesar |  | 2467 |  |  |
| 448 | 64.5 | FS on High Speed downlink packet access | 155d | 2000-08-21 A | 2001-03-23 A | 100% |  | 2000-08-21 | 2001-03-23 | 155d |  | finish no earlier than 2001-03-23 | R2 | 1240h | 1240h | RInImp-HSDPA | A. Ghosh, Motorola |  | TSG |  |  | 1219 |  |  |
| 449 | 64.6 | FS on improved common DL channel for Cell-FACH state | 340d | 2000-09-11 A | 2001-12-28 A | 100% |  | 2000-09-11 | 2001-12-28 | 340d |  | finish no earlier than 2001-12-28 | R2 | 2720h | 2720h | RInImp-DLCFACH | J. Kwak, GBT |  | TSG |  |  | 1510 |  |  |
| 450 | 64.7 | **Conformance Test Spec. Rel-4 improvements in Radio Interface** | 375d | 2001-10-08 A | 2003-03-14 | 64% | 134.62d | 2001-10-08 | 2003-03-14 | 375d | 448d |  | T1 | 12360h | 7923.08h |  |  |  |  |  |  |  |  |  |
| 451 | 64.7.1 | Testing Improved usage of downlink resource in FDD for CCTrCHs of dedicated type | 140d | 2002-02-18 | 2002-08-30 |  |  | 2002-02-18 | 2002-08-30 | 140d | 588d | finish no earlier than 2002-08-30 | T1 | 1120h |  |  |  |  |  |  |  | 2212 |  |  |
| 452 | 64.7.2 | Testing Terminal Power saving features | 140d | 2002-02-18 | 2002-08-30 |  |  | 2002-02-18 | 2002-08-30 | 140d | 588d | finish no earlier than 2002-08-30 | T1 | 1120h |  |  |  |  |  |  |  | 2213 |  |  |
| 453 | 64.7.3 | Testing DSCH power control improvement in soft handover | 140d | 2002-02-18 | 2002-08-30 |  |  | 2002-02-18 | 2002-08-30 | 140d | 588d | finish no earlier than 2002-08-30 | T1 | 1120h |  |  |  | Rel-4 |  |  |  | 2214 |  |  |
| 454 | 64.7.4 | Testing UMTS 1800 | 180d | 2001-10-08 A | 2002-06-14 A | 100% |  | 2001-10-08 | 2002-06-14 | 180d |  | finish no earlier than 2002-06-14 | T1 | 1440h | 1440h |  |  | Rel indep | TSG |  |  | 2215 | 34.108, 34,121, 34.122, 34.123-1 |  |
| 455 | 64.7.5 | Testing UMTS 1900 | 180d | 2001-10-08 A | 2002-06-14 A | 100% |  | 2001-10-08 | 2002-06-14 | 180d |  | finish no earlier than 2002-06-14 | T1 | 1440h | 1440h |  |  | Rel indep | TSG |  |  | 2215 | 34.108, 34,121, 34.122, 34.123-1 |  |
| 456 | 64.7.6 | Testing UMTS 1800 - TTCN | 195d | 2002-06-17 A | 2003-03-14 A | 100% |  | 2002-06-17 | 2003-03-14 | 195d |  | finish no earlier than 2003-03-14 | T1 | 1560h | 1560h |  |  | Rel indep | TSG |  |  |  | 34.123-3 |  |
| 457 | 64.7.7 | Testing UMTS 1900 - TTCN | 195d | 2002-06-17 A | 2003-03-14 A | 100% |  | 2002-06-17 | 2003-03-14 | 195d |  | finish no earlier than 2003-03-14 | T1 | 1560h | 1560h |  |  | Rel indep | TSG |  |  |  | 34.123-3 |  |

Notes:
- 434: Requires supporting companies
- 435: WI formulation assigned to N4
- 436: AS: corrected to Rel4 as stated at SA#10
- 441: Rel4 added
- 449: Stopped at RAN#14
- 451: start/finish dates set / Not started yet due to lack of supporting companies
- 452: start/finish dates set / Not started yet due to lack of supporting companies
- 453: start/finish dates set / Not started yet due to lack of supporting companies
- 454: finish date set
- 455: finish date set
- 456: finish date set
- 457: finish date set

| ID | WBS | Task | Type | Duration | Start | Finish | Predecessors | Complete | Remaining | Baseline start | Baseline finish | Baseline duration | Total slack | Free slack | Constraint | Resources | Work | Actual work | Text1 | Text6 | Text7 | Text8 | Text2 | Text4 | Text9 | Text3 | Text5 |
| --- | --- | --- | --- | --- | --- | --- | --- | --- | --- | --- | --- | --- | --- | --- | --- | --- | --- | --- | --- | --- | --- | --- | --- | --- | --- | --- | --- |
| 458 | 65 | **Rel-4 RAN improvements** |  | 928d? | 2000-08-14 A | 2004-03-03 |  | 17% | 769.16d? | 2000-08-14 | 2003-09-30 | 817d | 195d |  |  | RP | 28576h | 4218.95h | RANimp | NA | TSG | Cesar |  |  |  |  |  |
| 459 | 65.1 | Node B synchronisation for TDD |  | 160d | 2000-08-14 A | 2001-03-23 A |  | 100% |  | 2000-08-14 | 2001-03-23 | 160d |  |  | finish no earlier than 2001-03-23 | R1 | 1280h | 1280h | RANimp-NBsync | Rel-4 | TSG |  | BaAS | S. Oestreich, Siemens | 655 |  |  |
| 460 | 65.2 | RAB support enhancement for Rel-4 |  | 155d | 2000-08-21 A | 2001-03-23 A |  | 100% |  | 2000-08-21 | 2001-03-23 | 155d |  |  | finish no earlier than 2001-03-23 | R2 | 1240h | 1240h | RANimp-RABSE | Rel-4 | TSG |  |  | M. Israelsson, A. Krishnarajah, Ericsson | 2206 |  |  |
| 461 | 65.3 | Start Testing | milestone | 0d | 2001-12-03 | 2001-12-03 |  |  |  | 2001-12-03 | 2001-12-03 | 0d | 207d | 21d | start no earlier than 2001-12-03 | MLST |  |  |  |  |  |  |  |  | 1912 |  |  |
| 462 | 65.4 | **Conformance Test Aspects - Rel-4 RAN Improvements** |  | 567d? | 2002-01-01 A | 2004-03-03 | 461 | 2% | 553.97d? | 2002-01-01 | 2003-09-30 | 456d | 195d |  |  | T1 | 18632h | 428.26h |  |  |  |  |  |  | 2102 | 0% |  |
| 463 | 65.4.1 | Testing Radio access bearer support enhancments |  | 175d | 2002-01-01 | 2002-09-02 |  |  |  | 2002-01-01 | 2002-09-02 | 175d | 587d |  | finish no earlier than 2002-09-02 | T1 | 1400h |  |  |  |  |  |  |  | 2222 |  |  |
| 464 | 65.4.2 | Testing RAB support enhancements-Robust Header Compression |  | 332d | 2002-05-28 | 2003-09-03 |  |  |  | 2002-05-28 | 2003-03-03 | 200d | 325d |  | finish no earlier than 2003-09-03 | T1 | 2656h |  | RABimp-RoCH | Rel-4 | TSG |  |  |  | 2461 | 34.123-1, -2 |  |
| 465 | 65.4.3 | Testing RAB support enhancements-Robust Header Compression - TTCN |  | 397d | 2002-05-28 | 2003-12-03 |  |  |  | 2002-05-28 | 2003-06-30 | 285d | 260d |  | finish no earlier than 2003-12-03 | T1 | 3176h |  |  | Rel-4 | TSG |  |  |  |  | 34.123-3 |  |
| 466 | 65.4.4 | Testing of Extended Robut Header Compression |  | 270d | 2002-09-18 A | 2003-09-30 |  | 15% | 229.5d | 2002-09-18 | 2003-09-30 | 270d | 306d |  | finish no earlier than 2003-09-30 | T1 | 2160h | 324h | Ext-RoHC | Rel-4 | TSG |  |  |  |  | 34.123-1, -2 |  |
| 467 | 65.4.5 | Testing of Extended Robut Header Compression - TTCN |  | 325d | 2002-09-18 | 2003-12-16 |  |  |  | 2002-09-18 | 2003-09-30 | 270d | 251d |  | finish no earlier than 2003-12-16 | T1 | 2600h |  |  | Rel-4 | TSG |  |  |  |  | 34.123-3 |  |
| 468 | 69.4.6 | New: NEW: General changes to TS34.121 corresponding to release 4 |  | 263d? | 2003-03-03 | 2004-03-03 |  |  |  |  |  |  | 195d |  | finish no earlier than 2004-03-03 | T1 | 2104h |  | RANimp-test | Rel-4 | WG |  |  |  |  | 34.108, 34.121 |  |
| 469 | 66 | **Rel-4 Emergency call enhancements** |  | 627d | 2000-01-03 A | 2002-05-28 |  | 64% | 227.72d | 2000-01-03 | 2002-05-28 | 627d | 656d |  |  | N1 | 7936h | 5161.18h | EMC1 | NA | WG | Per | CCaR | Mr Rouzbeh, Ericsson | 1652 |  | EUSFARO@am1.ericsson.se |
| 470 | 66.1 | **For CS based calls** |  | 627d | 2000-01-03 A | 2002-05-28 |  | 64% | 227.72d | 2000-01-03 | 2002-05-28 | 627d | 656d |  |  | N1 | 3600h | 2400h | EMC1-CS | Rel-4 | TSG |  | CCaR | Mr Rouzbeh, Ericsson | 1654 |  | EUSFARO@am1.ericsson.se |
| 471 | 66.1.1 | Distinction in CS domain of emergency call types to different emergency services |  | 40d | 2000-05-01 A | 2000-06-23 A |  | 100% |  | 2000-05-01 | 2000-06-23 | 40d |  |  | finish no earlier than 2000-06-23 | S1 | 320h | 320h |  |  |  |  | CCaR |  | 1320 |  |  |
| 472 | 66.1.2 | Distinction in CS domain of emergency calls to different emergency types |  | 22d | 2000-08-28 A | 2000-09-26 A |  | 100% |  | 2000-08-28 | 2000-09-26 | 22d |  |  | finish no earlier than 2000-09-22 | N1 | 176h | 176h |  |  |  |  |  |  | 1999 |  |  |
| 473 | 66.1.3 | Conformance Test Aspects - Emergency call enhancements |  | 150d | 2000-01-03 | 2000-07-28 |  |  |  | 2000-01-03 | 2000-07-28 | 150d | 1133d |  |  | T1 | 1200h |  |  |  |  |  |  |  | 2224 |  |  |
| 474 | 66.1.4 | Testing CS based emergency calls |  | 67d | 2002-02-25 A | 2002-05-28 A |  | 100% |  | 2002-02-25 | 2002-05-28 | 67d |  |  | finish no earlier than 2002-05-28 | T1 | 536h | 536h |  |  | TSG |  |  |  | 2226 | 34.123-1 |  |
| 475 | 66.1.5 | Testing CS based emergency calls - TTCN |  | 134d | 2001-11-22 A | 2002-05-28 A |  | 100% |  | 2001-11-22 | 2002-05-28 | 134d |  |  | finish no earlier than 2002-05-28 | T1 | 1072h | 1072h |  |  | TSG |  |  |  |  | 34.123-3 |  |
| 476 | 67 | **Rel-4 Terminal interfaces** |  | 314d | 2000-01-03 A | 2001-03-15 |  | 99% | 0d | 2000-01-03 | 2001-03-15 | 314d | 0d |  |  | T2 | 15651.6h | 10635.6h | TI | NA |  | Friedhelm | Ter |  | 1826 |  |  |
| 477 | 67.1 | **AT commands enhancements** |  | 313d | 2000-01-03 A | 2001-03-14 A |  | 100% |  | 2000-01-03 | 2001-03-14 | 313d |  |  |  | T2 | 5008h | 5008h | TI-ATC | Rel-4 |  |  | Ter |  | 1827 | 27.007 |  |
| 478 | 67.1.1 | Specification of AT commands for new services |  | 313d | 2000-01-03 A | 2001-03-14 A |  | 100% |  | 2000-01-03 | 2001-03-14 | 313d |  |  | finish no earlier than 2001-03-14 | T2 | 2504h | 2504h |  |  |  |  | Ter |  | 1828 | 27.007 |  |
| 479 | 67.2 | **Wide Area Data Synchronisation** |  | 313d | 2000-01-03 A | 2001-03-14 |  | 99% | 0d | 2000-01-03 | 2001-03-14 | 313d | 0d |  |  | T2 | 5655.2h | 3151.2h | TI-WADS | NA |  |  | Ter |  | 1829 |  |  |
| 480 | 67.2.1 | Continues evolution of Synchronisation protocol |  | 313d | 2000-01-03 A | 2001-03-14 A |  | 100% |  | 2000-01-03 | 2001-03-14 | 313d |  |  | finish no earlier than 2001-03-14 | T2 | 2504h | 2504h | TI-SYNC-EVOL | Rel-4 |  |  | Ter |  | 1830 | 27.903, 27.103 |  |
| 481 | 67.3 | Terminal local model |  | 218d | 2000-05-16 A | 2001-03-15 A |  | 100% |  | 2000-05-16 | 2001-03-15 | 218d |  |  | finish no earlier than 2001-03-15 | T2 | 1744h | 1744h | TLM | Rel-4 | TSG |  | Ter | Olga Tomé, Ericsson | 1832 | 23.227 | Olga.Tome@ECS.ERICSSON.SE |

Notes:
- 460: 29 Nov 2000: split into ROHC and non-ROHC part; 5 Mar 2001: splitting off of ROHC for Rel-4 agreed by R2
- 461: UID changed
- 463: duration set to 6 months (was 0) / Task not started due to lack of supporting companies
- 464: UID changed
- 465: UID changed
- 470: WI approved in TSG_10 / CN1#15: ID 2101 REMOVE-Emergency call recalling capability enhancement, no contributions
- 472: Calls to different emergency services such as ambulance, fire brigade, police, etc. can be routed to respective different emergency centres. / NP-000447 is the stage 3 changes for CS call control protocol.
- 473: UID changed
- 478: goal not completely achieved because of missing input
- 479: AS: Rel5 changed to Rel4 according to SA#10 decision, milestone on testing added

| ID | WBS | Task | Duration | Start | Finish | Complete | Remaining | Baseline start | Baseline finish | Baseline duration | Total slack | Constraint | Resources | Work | Actual work | Text1 | Text4 | Text6 | Text7 | Text8 | Text9 | Text2 | Text3 | Text5 |
| --- | --- | --- | --- | --- | --- | --- | --- | --- | --- | --- | --- | --- | --- | --- | --- | --- | --- | --- | --- | --- | --- | --- | --- | --- |
| 482 | 68 | **Rel-4 Location Services enhancements** | 455d | 2000-04-03 A | 2001-12-28 | 99% | 0d | 2000-04-03 | 2001-12-28 | 455d | 0d |  | S2 | 28240.8h | 21192.8h | LCS1 | Jan Kall, Nokia | NA | TSG | Alain | 1536 |  |  |  |
| 483 | 68.1 | CBS interactions | 455d | 2000-04-03 A | 2001-12-28 A | 100% |  | 2000-04-03 | 2001-12-28 | 455d |  | finish no earlier than 2001-12-28 | T2 | 3640h | 3640h | LCS1-CBS |  | Rel-4 |  |  | 2229 | Loc | 23.041 |  |
| 484 | 68.2 | LCS support in the CS domain | 180d | 2000-05-15 A | 2001-01-19 A | 100% |  | 2000-05-15 | 2001-01-19 | 180d |  | finish no earlier than 2001-01-19 | S2 | 1440h | 1440h | LCS1-CS |  | Rel-4 |  |  | 523 | Loc |  |  |
| 485 | 68.3 | **LCS support in the PS domain** | 435d | 2000-05-01 A | 2001-12-28 | 99% | 0d | 2000-05-01 | 2001-12-28 | 435d | 0d |  | S2 | 14164.8h | 10684.8h | LCS1-PS |  | Rel-4 |  |  | 525 |  |  |  |
| 486 | 68.3.1 | Stage 1 | 40d | 2000-07-03 A | 2000-08-25 A | 100% |  | 2000-07-03 | 2000-08-25 | 40d |  | start no earlier than 2000-07-03 | S1 | 320h | 320h |  | Randolph Wohlert, Pacific Bell Wireless |  |  |  | 1642 | Loc | 22.071 | rwohlert@tri.sbc.com |
| 487 | 68.3.2 | Stage 2 | 190d | 2000-05-01 A | 2001-01-19 A | 100% |  | 2000-05-01 | 2001-01-19 | 190d |  | finish no earlier than 2001-01-19 | S2 | 1520h | 1520h |  |  |  |  |  | 1181 |  | 23.271 |  |
| 488 | 68.3.3 | **Stage 3** | 355d | 2000-08-21 A | 2001-12-28 A | 100% |  | 2000-08-21 | 2001-12-28 | 355d |  |  | N1 | 8240h | 8240h |  |  |  |  |  | 1180 | Loc |  |  |
| 489 | 68.3.3.1 | Layer 3 LCS signaling UE (MS) -SGSN (UMTS PS and and GSM-GPRS) | 355d | 2000-08-21 A | 2001-12-28 A | 100% |  | 2000-08-21 | 2001-12-28 | 355d |  | finish no earlier than 2001-12-28 | N1 | 2840h | 2840h |  | Janne Muhonen / Nokia |  |  |  | 526 | Loc |  |  |
| 490 | 68.3.3.2 | MAP impacts of LCS | 160d | 2000-08-21 A | 2001-03-30 A | 100% |  | 2000-08-21 | 2001-03-30 | 160d |  | finish no earlier than 2001-03-30 | N4 | 1280h | 1280h |  |  |  |  |  | 2462 | Loc |  |  |
| 491 | 68.3.3.3 | GTP signaling for LCS | 160d | 2000-08-21 A | 2001-03-30 A | 100% |  | 2000-08-21 | 2001-03-30 | 160d |  | finish no earlier than 2001-03-30 | N4 | 1280h | 1280h |  |  |  |  |  | 527 | Loc |  |  |
| 492 | 68.4 | **UE positioning Rel-4** | 260d | 2000-04-03 A | 2001-03-30 A | 100% |  | 2000-04-03 | 2001-03-30 | 260d |  |  | RP | 4591.2h | 4591.2h | LCS1-UEpos |  | NA | TSG |  | 1600 |  |  |  |
| 493 | 68.4.1 | Iub/Iur interfaces for methods Rel 99 | 233.9d | 2000-04-03 A | 2001-03-30 A | 100% |  | 2000-04-03 | 2001-03-30 | 233.9d |  | finish no earlier than 2001-03-30 | R3 | 1871.2h | 1871.2h | LCS1-UEpos-IubIur | Yun-Chao Hu, Ericsson | Rel-4 | TSG |  | 1601 |  |  |  |
| 494 | 68.4.2 | UE positioning enhancements - IPDL for TDD | 150d | 2000-08-28 A | 2001-03-23 A | 100% |  | 2000-08-28 | 2001-03-23 | 150d |  | finish no earlier than 2001-03-23 | R2 | 1200h | 1200h | LCS1-UEpos-enh | M. Beckmann, Siemens | Rel-4 | TSG |  | 1602 |  |  |  |
| 495 | 69 | **Rel-4 UICC/(U)SIM enhancements and interworking** | 175d | 2000-07-24 A | 2001-03-23 A | 100% |  | 2000-07-24 | 2001-03-23 | 175d |  |  | T3 | 2800h | 2800h | UICC1 |  | NA |  | Claus | 1560 | Ter |  |  |
| 496 | 69.1 | Common PCN Handset Specification (CPHS) | 175d | 2000-07-24 A | 2001-03-23 A | 100% |  | 2000-07-24 | 2001-03-23 | 175d |  | finish no earlier than 2001-03-23 | T3 | 1400h | 1400h | UICC1-CPHS | ?, One2One | Rel-4 | TSG |  | 1799 | Ter | 27.103 |  |
| 497 | 70 | **Rel-4 (U)SIM toolkit enhancements** | 210d | 2000-06-05 A | 2001-03-23 A | 100% |  | 2000-06-05 | 2001-03-23 | 210d |  |  | T3 | 3360h | 3360h | USAT1 |  | NA |  | Claus | 1800 | Ter |  |  |
| 498 | 70.1 | USAT local link | 210d | 2000-06-05 A | 2001-03-23 A | 100% |  | 2000-06-05 | 2001-03-23 | 210d |  | finish no earlier than 2001-03-23 | T3 | 1680h | 1680h | USAT1-LocLnk | Jean-Francois Rubon (Gemplus) | Rel-4 | TSG |  | 2034 |  |  |  |
| 499 | 71 | **Rel-4 Security enhancements** | 575d | 2000-01-03 A | 2002-03-15 | 87% | 74.38d | 2000-01-03 | 2002-03-15 | 575d | 708d |  | S3 | 24144h | 20865.5h | SEC1 | Peter Howard, Vodafone | NA | TSG | Maurice |  |  |  | Peter.Howard@vodafone.com |
| 500 | 71.1 | Evolution of GSM CS algorithms (e.g. A5/3 development and deployment) | 271d | 2000-01-03 A | 2001-01-15 A | 100% |  | 2000-01-03 | 2001-01-15 | 271d |  | finish no earlier than 2001-01-15 | S3 | 2168h | 2168h | SEC1-CSALGO1 |  | Rel-4 | TSG |  | 1587 | Sec |  |  |
| 501 | 71.2 | **Evolution of GSM PS algorithms (e.g. GEA 2 deployment)** | 219d | 2000-02-22 A | 2000-12-22 A | 100% |  | 2000-02-22 | 2000-12-22 | 219d |  |  | S3 | 6024h | 6024h | SEC1-PSALGO1 |  | Rel-4 | TSG |  | 1588 | Sec |  |  |
| 502 | 71.2.1 | Main aspects | 199d | 2000-02-22 A | 2000-11-24 A | 100% |  | 2000-02-22 | 2000-11-24 | 199d |  | finish no earlier than 2000-11-24 | S3 | 1592h | 1592h |  |  |  |  |  | 1589 | Sec |  |  |
| 503 | 71.2.2 | Impact on GTP | 200d | 2000-03-20 A | 2000-12-22 A | 100% |  | 2000-03-20 | 2000-12-22 | 200d |  | finish no earlier than 2000-12-22 | N4 | 1600h | 1600h |  |  |  | WG |  | 1618 |  |  |  |
| 504 | 71.2.3 | GEA capability indication in MS CM | 135d | 2000-06-19 A | 2000-12-22 A | 100% |  | 2000-06-19 | 2000-12-22 | 135d |  | finish no earlier than 2000-12-22 | N1 | 1080h | 1080h | SEC1-PSALGO1-GEACAP | Duncan Mills / Vodafone Airtouch |  |  |  | 1661 | Sec |  |  |
| 505 | 71.3 | **MAP application layer security** | 575d | 2000-01-03 A | 2002-03-15 | 76% | 135.92d | 2000-01-03 | 2002-03-15 | 575d | 708d |  | S3 | 11352h | 8668.59h | SEC1-MAPAL |  | Rel-4 | TSG |  |  | Sec |  |  |
| 506 | 71.3.1 | Main aspects | 199d | 2000-02-21 A | 2001-03-29 A | 100% |  | 2000-02-21 | 2001-03-29 | 199d |  | start no earlier than 2000-02-21 | S3 | 1592h | 1592h |  |  |  | WG |  | 1584 | Sec |  |  |
| 507 | 71.3.2 | Other stage 3 aspects | 199d | 2000-02-22 A | 2000-11-24 A | 100% |  | 2000-02-22 | 2000-11-24 | 199d |  | finish no earlier than 2000-11-24 | N4 | 1592h | 1592h |  |  |  | TSG |  | 2025 | Sec |  |  |
| 508 | 71.3.3 | CHECK STATUS - Visibility and Configurability of security | 575d | 2000-01-03 A | 2002-03-15 | 60% | 230d | 2000-01-03 | 2002-03-15 | 575d | 708d | finish no earlier than 2002-03-15 | S3 | 4600h | 2760h | SEC1-VCS | Sébastien Nguyen Ngoc, France Telecom | Rel-5 | TSG |  | 1594 | Sec |  | Sebastien.nguyenngoc@rd.francetelecom.com |

Notes:
- 484: Only MAP impact foreseen so far. To be further split if needed.
- 486: To be also considered: External LCS client identity, and Privacy options when PDP-context and when no PDP-context is established
- 487: AS: 23.271 completed at SA#10
- 490: Missing work task
- 492: UID changed
- 493: 27/11: WG corrected; rapporteur corrected
- 494: 5 Mar 2001: splitting off of IPDL for TDD for Rel-4 agreed by R2
- 496: 28/5/2001: CRs approved at TP-11. WI complete.
- 498: 25/5/2001:CR was approved at TP-11. WI is complete
- 499: Added BB UE authentication and rapporteur added. TO BE DELETED
- 500: Algorithm development go-ahead at SA3#21. Scheduled for completion in August 2002?. Approved SA#17. DELETE ENTRY FROM REL-4?
- 501: A5/3 development will consider new GEA algorithm based on Kasumi.
- 502: Complete TSG#09 (09/2000). S3#17: Proposed for deletion. TO BE DELETED
- 505: TO DELETE: REPLACED BY NDS-MAP and NDS-IP. TO BE DELETED, but replacement NDS-MAP was missing. Completed Auto Key Management -> Rel-6
- 506: UID changed
- 507: UID changed
- 508: CR approved at SA3#21 awaiting comments from CN1.

| ID | WBS | Task | Type | Duration | Start | Finish | Predecessors | Complete | Remaining | Baseline start | Baseline finish | Baseline duration | Total slack | Free slack | Constraint | Resources | Work | Actual work | Text1 | Text3 | Text5 | Text6 | Text7 | Text8 | Text2 | Text9 |
| --- | --- | --- | --- | --- | --- | --- | --- | --- | --- | --- | --- | --- | --- | --- | --- | --- | --- | --- | --- | --- | --- | --- | --- | --- | --- | --- |
| 509 | 72 | **Rel-4 Charging and OAM&P** |  | 221d | 2000-12-01 A | 2001-10-05 A |  | 100% |  | 2000-12-01 | 2001-10-05 | 221d |  |  |  | S5 | 10472h | 10472h | OAM | 32-series | Albert.Yuhan@voicestream.com; Michael.Truss@MOTOROLA.COM | NA | TSG | Adrian |  |  |
| 510 | 72.1 | Rel4 Principles, high level Requirements and Architecture |  | 145d | 2000-12-01 A | 2001-06-21 A |  | 100% |  | 2000-12-01 | 2001-06-21 | 145d |  |  | finish no earlier than 2001-06-21 | S5 | 1160h | 1160h | OAM-AR/PR | 32.101, 32.102 | Michael.Truss@MOTOROLA.COM; Tommy.R.Berggren@TELIA.SE | Rel-4 | TSG |  | BCaM | 2089 |
| 511 | 72.2 | Rel4 Performance Management |  | 216d | 2000-12-01 A | 2001-09-28 A |  | 100% |  | 2000-12-01 | 2001-09-28 | 216d |  |  | finish no earlier than 2001-06-21 | S5 | 1728h | 1728h |  | 32.4xy, 52.402 | karl-heinz.nenner@t-mobile.de | Rel-4 | TSG |  | BCaM | 2088 |
| 512 | 72.3 | Fault Management |  | 221d | 2000-12-01 A | 2001-10-05 A |  | 100% |  | 2000-12-01 | 2001-10-05 | 221d |  |  | finish no earlier than 2001-06-21 | S5 | 1768h | 1768h |  | 32.111-1/4 | pjure@LUCENT.COM | Rel-4 | TSG |  | BCaM | 2081 |
| 513 | 72.4 | Configuration Management |  | 145d | 2000-12-01 A | 2001-06-21 A |  | 100% |  | 2000-12-01 | 2001-06-21 | 145d |  |  | finish no earlier than 2001-06-21 | S5 | 1160h | 1160h | OAM-CM | 32.106-1/8 | Thomas.Tovinger@emw.ericsson.se | Rel-4 | TSG |  | BCaM | 2082 |
| 514 | 72.5 | Rel4 Charging Management |  | 216d | 2000-12-01 A | 2001-09-28 A |  | 100% |  | 2000-12-01 | 2001-09-28 | 216d |  |  | finish no earlier than 2001-06-21 | S5 | 1728h | 1728h | OAM-CH | 32.2xy (Charging) | karl-heinz.nenner@t-mobile.de | Rel-4 | TSG |  | BCaM | 2083 |
| 515 | 72.6 | UTRAN Operations and Maintenance procedures |  | 145d | 2000-12-01 A | 2001-06-21 A |  | 100% |  | 2000-12-01 | 2001-06-21 | 145d |  |  | finish no earlier than 2001-06-21 | S5 | 1160h | 1160h | UOAM | 32.800 | bert.boden@d2mannesmann.de | Rel-4 | TSG | Adrian |  | 2071 |
| 516 | 73 | **Global Text Telephony** |  | 567d | 2000-06-28 A | 2002-08-29 |  | 82% | 101.67d | 2000-06-28 | 2002-08-29 | 567d | 589d |  |  | S2 | 9984h | 8388.85h | GTT |  | gunnar.hellstrom@omnitor.se | Rel Indep | TSG | Alain |  |  |
| 517 | 73.1 | Stage 1 |  | 188d | 2000-06-28 A | 2001-03-16 A |  | 100% |  | 2000-06-28 | 2001-03-16 | 188d |  |  | finish no earlier than 2000-12-22 | S1 | 1504h | 1504h |  | 22.976, 22.226 |  |  | TSG |  |  | 1634 |
| 518 | 73.2 | Stage 2 |  | 205d | 2000-09-11 A | 2001-06-22 A |  | 100% |  | 2000-09-11 | 2001-06-22 | 205d |  |  |  | S2 | 1640h | 1640h |  | 23.226 |  |  | TSG |  |  |  |
| 519 | 73.3 | **Specification of Cellular Text telephone Modem** |  | 136d | 2000-09-11 A | 2001-03-19 A |  | 100% |  | 2000-09-11 | 2001-03-19 | 136d |  |  |  | S4 | 2704h | 2704h | GTT-CTM |  |  |  |  |  |  | 2234 |
| 520 | 73.3.1 | General description and C-code |  | 66d | 2000-09-11 A | 2000-12-11 A |  | 100% |  | 2000-09-11 | 2000-12-11 | 66d |  |  | finish no earlier than 2000-12-11 | S4 | 528h | 528h |  | 26.226, 26.230 |  |  |  |  |  | 2238 |
| 521 | 73.3.2 | Minimum Performance requirements |  | 136d | 2000-09-11 A | 2001-03-19 A |  | 100% |  | 2000-09-11 | 2001-03-19 | 136d |  |  | finish no earlier than 2001-03-19 | S4 | 1088h | 1088h |  | 26.231 |  |  |  |  |  | 2237 |
| 522 | 73.4 | Start Testing | milestone | 0d | 2002-02-18 | 2002-02-18 |  |  |  | 2002-02-18 | 2002-02-18 | 0d | 598d | 9d | start no earlier than 2002-02-18 | MLST |  |  |  |  |  |  |  |  |  |  |
| 523 | 73.5 | Conformance Test Aspects - Global Text telephony |  | 130d | 2002-03-01 | 2002-08-29 | 522 |  |  | 2002-03-01 | 2002-08-29 | 130d | 589d |  | finish no earlier than 2002-08-29 | T1 | 1040h |  |  | 34.125 |  |  |  |  |  |  |
| 524 | 74 | ----- Rel-5 features listed below ----- |  | 1d | 2000-01-03 | 2000-01-03 |  |  |  | 2000-01-03 | 2000-01-03 | 1d | 1282d |  |  |  |  |  |  |  |  | Rel-5 |  |  |  |  |
| 525 | 75 | IP transport in the UTRAN |  | 445d | 2000-07-17 A | 2002-03-29 A |  | 100% |  | 2000-07-17 | 2002-03-29 | 445d |  |  | finish no earlier than 2002-03-29 | R3 | 3560h | 3560h | ETRAN-IPtrans |  |  | Rel-5 | TSG |  | BaAS | 625 |
| 526 | 76 | FS on Usage of SUA |  | 205d | 2001-03-12 A | 2001-12-21 A |  | 100% |  | 2001-03-12 | 2001-12-21 | 205d |  |  | finish no earlier than 2001-12-21 | N4 | 1640h | 1640h | SS7IP |  |  | Rel-5 |  |  |  | 2455 |
| 527 | 77 | **High Speed Downlink Packet Access** |  | 510d | 2001-04-02 A | 2003-03-14 |  | 96% | 20.14d | 2001-04-02 | 2003-03-14 | 510d | 448d |  |  | R2 | 14312h | 13746.9h | HSDPA |  |  | Rel-5 | TSG | Cesar |  | 2476 |
| 528 | 77.1 | Physical Layer |  | 257d | 2001-04-05 A | 2002-03-29 A |  | 100% |  | 2001-04-05 | 2002-03-29 | 257d |  |  | finish no earlier than 2002-03-29 | R1 | 2056h | 2056h | HSDPA-Phys |  |  |  | TSG |  |  | 2477 |
| 529 | 77.2 | Layer 2 and 3 aspects |  | 257d | 2001-04-05 A | 2002-03-29 A |  | 100% |  | 2001-04-05 | 2002-03-29 | 257d |  |  | finish no earlier than 2002-03-29 | R2 | 2056h | 2056h | HSDPA-L23 |  |  |  | TSG |  |  | 2478 |
| 530 | 77.3 | Iub/Iur protocol aspects |  | 260d | 2001-04-02 A | 2002-03-29 A |  | 100% |  | 2001-04-02 | 2002-03-29 | 260d |  |  | finish no earlier than 2002-03-29 | R3 | 2080h | 2080h | HSDPA-IubIur |  |  |  | TSG |  |  | 2479 |
| 531 | 77.4 | RF Radio Transmission/ Reception, System Performance Requirements and Conformance Testing |  | 505d | 2001-04-09 A | 2003-03-14 |  | 90% | 50.5d | 2001-04-09 | 2003-03-14 | 505d | 448d |  | finish no earlier than 2003-03-14 | R4 | 4040h | 3636h | HSDPA-RF |  |  |  | TSG |  |  | 2480 |
| 532 | 78 | **Rel-5 Improvements of Radio Interface** |  | 535d | 2000-08-14 A | 2002-08-30 |  | 89% | 56.7d | 2000-08-14 | 2002-08-30 | 535d | 588d |  |  | RP | 30376h | 27009h | RInImp |  |  | NA | TSG | Tsukasa |  |  |
| 533 | 78.1 | **Base station classification** |  | 480d | 2000-08-14 A | 2002-06-14 A |  | 100% |  | 2000-08-14 | 2002-06-14 | 480d |  |  |  | R4 | 9208h | 9208h | RInImp-BSClass |  |  | Rel-5 | TSG |  | BaAS | 1471 |
| 534 | 78.1.1 | TDD Base station classification |  | 410d | 2000-08-14 A | 2002-03-08 A |  | 100% |  | 2000-08-14 | 2002-03-08 | 410d |  |  | finish no earlier than 2002-03-08 | R4 | 3280h | 3280h | RInImp-BSClass-TDD |  |  |  | TSG |  | BaAs | 1477 |
| 535 | 78.1.2 | Base Station Classification for 1.28 Mcps TDD option |  | 261d | 2001-06-15 A | 2002-06-14 A |  | 100% |  | 2001-06-15 | 2002-06-14 | 261d |  |  | finish no earlier than 2002-06-14 | R4 | 2088h | 2088h | RInImp-BSClass-LCRTDD |  |  |  | TSG |  |  |  |
| 536 | 78.2 | Enhancement on the DSCH hard split mode |  | 271d | 2001-03-16 A | 2002-03-29 A |  | 100% |  | 2001-03-16 | 2002-03-29 | 271d |  |  | finish no earlier than 2002-03-29 | R1 | 2168h | 2168h | RInImp-DSCHhsp |  |  | Rel-5 | TSG |  |  | 2469 |
| 537 | 78.3 | Hybrid ARQ II/III |  | 355d | 2000-08-21 A | 2001-12-28 A |  | 100% |  | 2000-08-21 | 2001-12-28 | 355d |  |  | finish no earlier than 2001-12-28 | R2 | 2840h | 2840h | RInImp-HARQ |  |  | Rel-5 | TSG |  |  | 1217 |
| 538 | 78.4 | FS on USTS |  | 355d | 2000-08-14 A | 2001-12-21 A |  | 100% |  | 2000-08-14 | 2001-12-21 | 355d |  |  | finish no earlier than 2001-12-21 | R1 | 2840h | 2840h | RInImp-USTS |  |  | Rel-5 | TSG |  | BaAS | 1221 |
| 539 | 78.5 | FS on UE antenna efficency test method performance requirements |  | 255d | 2000-09-25 A | 2001-09-14 A |  | 100% |  | 2000-09-25 | 2001-09-14 | 255d |  |  | finish no earlier than 2001-09-14 | R4 | 2040h | 2040h | RInImp-UEAnTM |  |  | Rel-5 | TSG |  |  | 1997 |
| 540 | 78.6 | FS on the re-introduction of the downlink SIR measurement |  | 200d | 2001-03-12 A | 2001-12-14 A |  | 100% |  | 2001-03-12 | 2001-12-14 | 200d |  |  | finish no earlier than 2001-12-14 | R4 | 1600h | 1600h | RInImp-SIR |  |  | Rel-5 | TSG | Cesar |  | 24002 |
| 541 | 78.7 | FS on mitigating the effect of CPICH interference at the UE |  | 255d | 2001-03-19 A | 2002-03-08 A |  | 100% |  | 2001-03-19 | 2002-03-08 | 255d |  |  | finish no earlier than 2002-03-08 | R4 | 2040h | 2040h | RInImp-CPICH_Intf |  |  | Rel-5 | TSG | Cesar |  | 24001 |

Notes:
- 509: az: WID appr.SA#13. / Text4: Albert YUHAN (VoiceStream Wireless), Michael TRUSS (Motorola)
- 510: Text4: Michael TRUSS (Motorola), Tommy BERGGREN (Telia AB)
- 511: Changed Rapp email / Text4: Karl-Heinz NENNER (T-Mobile)
- 512: Text4: Patrick JURÉ (Lucent Technologies)
- 513: Text4: Thomas TOVINGER (Ericsson)
- 514: Changed Rapp email / Text4: Karl-Heinz NENNER (T-Mobile)
- 515: Text4: Bert Boden (Mannesmann Mobilfunk)
- 516: SP-000162 agreed WI. Rapporteur / Gunnar Hellström, Ericsson Radio Systems AB, / email: gunnar.hellstrom@omnitor.se tel: +46 708 204 288 / Text4: Gunnar Hellström, Ericsson
- 523: Bearer services, new spec document? / This task requires supporting companies before it can start
- 525: Text4: Nicolas Drevon, Alcatel
- 526: update WID / 30.11.2001: To CN #14 for approval
- 527: Text4: Ravi Kuchibhotla, Motorola
- 528: Text4: Amitava Ghosh, Motorola
- 529: 30 November: Completion date shifted to March 2002 / Text4: Ravi Kuchibhotla, Motorola
- 530: Text4: Mike Diesen, Motorola
- 531: Text4: Howard Benn, Motorola
- 533: Text4: A. Toskala, Nokia
- 534: Text4: A. Toskala, Nokia
- 535: Text4: Meik Kottkamp, Siemens
- 536: Text4: Jaeyoel KIM, Samsung
- 537: Stopped at RAN#14; work on this task was performed as part of High Speed Downlink Packet Access feature / Text4: A. Sitte, Siemens
- 538: Text4: D. Kim, SK Telecom
- 539: Text4: O. Edvardsson, Allgon
- 540: Text4: Torgny Palenius, Ericsson
- 541: Text4: Shimon Moshavi, Intel

| ID | WBS | Task | Type | Duration | Start | Finish | Predecessors | Complete | Remaining | Baseline start | Baseline finish | Baseline duration | Total slack | Free slack | Constraint | Resources | Work | Actual work | Text6 | Text9 | Text1 | Text7 | Text8 | Text2 | Text4 | Text3 |
| --- | --- | --- | --- | --- | --- | --- | --- | --- | --- | --- | --- | --- | --- | --- | --- | --- | --- | --- | --- | --- | --- | --- | --- | --- | --- | --- |
| 542 | 78.8 | **Conformance Test Spec. improvements in Radio Interface** |  | 140d | 2002-02-18 | 2002-08-30 |  |  |  | 2002-02-18 | 2002-08-30 | 140d | 588d |  |  | T1 | 3360h |  |  |  |  |  |  |  |  |  |
| 543 | 78.8.1 | Testing improvement of inter-frequency and inter-system measurement |  | 140d | 2002-02-18 | 2002-08-30 |  |  |  | 2002-02-18 | 2002-08-30 | 140d | 588d |  | finish no earlier than 2002-08-30 | T1 | 1120h |  | Rel-5 | 2210 |  |  |  |  |  |  |
| 544 | 78.8.2 | Testing Hybrid ARQ II/III |  | 140d | 2002-02-18 | 2002-08-30 |  |  |  | 2002-02-18 | 2002-08-30 | 140d | 588d |  | finish no earlier than 2002-08-30 | T1 | 1120h |  | Rel-5 | 2211 |  |  |  |  |  |  |
| 545 | 79 | **Rel-5 RAN improvements** |  | 772d? | 2001-03-16 A | 2004-03-01 |  | 87% | 100.69d? | 2001-03-16 | 2002-09-03 | 383d | 197d |  |  | RP | 39984h | 28864h | NA |  | RANimp | TSG | Cesar |  |  |  |
| 546 | 79.1 | **RRM optimization for Iur and Iub** |  | 318d | 2001-03-16 A | 2002-06-04 A |  | 100% |  | 2001-03-16 | 2002-06-04 | 318d |  |  |  | R3 | 8904h | 8904h | Rel-5 | 656 | RANimp-RRMopt | TSG |  | BaAS | Gert-Jan van Lieshout, Ericsson |  |
| 547 | 79.1.1 | Iur common transport channel efficiency optimisation |  | 271d | 2001-03-16 A | 2002-03-29 A |  | 100% |  | 2001-03-16 | 2002-03-29 | 271d |  |  | finish no earlier than 2002-03-29 | R3 | 2168h | 2168h |  |  | RANimp-RRMopt-ctc | TSG |  |  | Shahrokh Amirijoo, Ericsson |  |
| 548 | 79.1.2 | Iur neighbouring cell reporting efficiency optimisation |  | 271d | 2001-03-16 A | 2002-03-29 A |  | 100% |  | 2001-03-16 | 2002-03-29 | 271d |  |  | finish no earlier than 2002-03-29 | R3 | 2168h | 2168h |  |  | RANimp-RRMopt-ncr | TSG |  |  | Shahrokh Amirijoo, Ericsson |  |
| 549 | 79.1.3 | FS Introduction of direct transport bearers between SRNC and Node-B |  | 253d | 2001-06-15 A | 2002-06-04 A |  | 100% |  | 2001-06-15 | 2002-06-04 | 253d |  |  | finish no earlier than 2002-06-28 | R3 | 2024h | 2024h |  |  | RAN-imp-RRMopt-DTB | TSG |  |  | Risto Sepponen, Ericsson |  |
| 550 | 79.2 | RL Timing Adjustment |  | 271d | 2001-03-16 A | 2002-03-29 A |  | 100% |  | 2001-03-16 | 2002-03-29 | 271d |  |  | finish no earlier than 2002-03-29 | R3 | 2168h | 2168h | Rel-5 | 22003 | RANimp-RLTA | TSG |  |  | Elena Voltolina, Ericsson |  |
| 551 | 79.3 | Separation of resource reservation and radio link activation |  | 271d | 2001-03-16 A | 2002-03-29 A |  | 100% |  | 2001-03-16 | 2002-03-29 | 271d |  |  | finish no earlier than 2002-03-29 | R3 | 2168h | 2168h | Rel-5 | 22004 | RANimp-SepRR | TSG |  |  | Gert-Jan van Lieshout, Ericsson |  |
| 552 | 79.4 | FS SRNS Relocation Procedure Enhancement |  | 318d | 2001-06-15 A | 2002-09-03 A |  | 100% |  | 2001-06-15 | 2002-09-03 | 318d |  |  | finish no earlier than 2002-09-06 | R3 | 2544h | 2544h | Rel-5 |  | RANimp-SRNS | TSG |  |  | Olivier Guyot, Nokia |  |
| 553 | 79.5 | FS Improvement of Radio Resource Management across RNS and RNS/PSS |  | 201d | 2001-03-16 A | 2001-12-21 A |  | 100% |  | 2001-03-16 | 2001-12-21 | 201d |  |  | finish no earlier than 2001-12-21 | R3 | 1608h | 1608h | Rel-5 | 22001 | RANimp-ImpRRM | TSG |  |  | Antti Toskala, Nokia |  |
| 554 | 79.6 | Re-arrangements of Iub transport bearers |  | 271d | 2001-03-16 A | 2002-03-29 A |  | 100% |  | 2001-03-16 | 2002-03-29 | 271d |  |  | finish no earlier than 2002-03-29 | R3 | 2168h | 2168h | Rel-5 | 22002 | RANimp-TTPS | TSG |  |  | Antti Toskala, Nokia |  |
| 555 | 79.7 | RAB support enhancement for Rel-5 |  | 325d | 2001-04-02 A | 2002-06-28 A |  | 100% |  | 2001-04-02 | 2002-06-28 | 325d |  |  | finish no earlier than 2002-06-28 | R2 | 2600h | 2600h | Rel-5 |  | RANimp-RABSE5 | TSG |  |  | Juha Mikola, Nokia |  |
| 556 | 79.8 | Beamforming requirements for UE |  | 61d | 2001-09-21 A | 2001-12-14 A |  | 100% |  | 2001-09-21 | 2001-12-14 | 61d |  |  | finish no earlier than 2001-12-14 | R1 | 488h | 488h | Rel-5 |  | RANimp-BFR-UE | TSG |  |  | Jussi Kähtävä, Nokia |  |
| 557 | 79.9 | Support of Site Selection Diversity Transmission in UTRAN |  | 123d | 2001-12-14 A | 2002-06-04 A |  | 100% |  | 2001-12-14 | 2002-06-04 | 123d |  |  | finish no earlier than 2002-06-04 | R1 | 984h | 984h | Rel-5 |  | RANimp-SSDT | TSG |  |  | NEC |  |
| 558 | 79.10 | Node B Synchronisation for 1.28 Mcps TDD |  | 271d | 2001-03-16 A | 2002-03-29 A |  | 100% |  | 2001-03-16 | 2002-03-29 | 271d |  |  | finish no earlier than 2002-03-29 | R1 | 2168h | 2168h | Rel-5 | 2472 | RANimp-NBSLCR | TSG |  |  | Jinling HU, CWTS/CATT |  |
| 559 | 79.11 | Start Testing | milestone | 0d | 2001-12-03 | 2001-12-03 |  |  |  | 2001-12-03 | 2001-12-03 | 0d | 522d | 21d | start no earlier than 2001-12-03 | MLST |  |  |  | 1912 |  |  |  |  |  |  |
| 560 | 79.12 | **Conformance Test Aspects - RAN Improvements** |  | 565d? | 2002-01-01 | 2004-03-01 | 559 |  |  | 2002-01-01 | 2002-09-02 | 175d | 197d |  |  | T1 | 8008h |  |  | 2102 |  |  |  |  |  | 0% |
| 561 | 79.12.1 | Testing Radio access bearer support enhancments |  | 175d | 2002-01-01 | 2002-09-02 |  |  |  | 2002-01-01 | 2002-09-02 | 175d | 587d |  | finish no earlier than 2002-09-02 | T1 | 1400h |  |  | 2222 |  |  |  |  |  |  |
| 562 | 83.12.2 | New: NEW: General changes to TS34.121 and TS34.122 corresponding to release 5 |  | 261d? | 2003-03-03 | 2004-03-01 |  |  |  |  |  |  | 197d |  | finish no earlier than 2004-03-01 | T1 | 2088h |  | Rel-5 |  | RANimp-test | WG |  |  |  | 34.108, 34.121, 34.122 |
| 563 | 80 | UTRAN Sharing in Connected Mode |  | 197d | 2001-12-03 A | 2002-09-03 A |  | 100% |  | 2001-12-03 | 2002-09-03 | 197d |  |  | finish no earlier than 2002-09-06 | R3 | 1576h | 1576h | Rel-5 |  | NETSHARE |  |  |  | Martin Israelsson, Ericsson |  |
| 564 | 81 | **Provisioning of IP-based multimedia services** |  | 1088d | 2000-01-03 A | 2004-03-03 |  | 92% | 90.06d | 2000-01-03 | 2003-09-30 | 977d | 195d |  |  | S1 | 187985h | 157803h | NA |  | IMS | TSG | MichaelC/Alain |  | Mark Cataldo, Openwave |  |
| 565 | 81.1 | **Call control and roaming to support IMS in UMTS** |  | 640d | 2000-01-03 A | 2002-06-14 |  | 98% | 12.24d | 2000-01-03 | 2002-06-14 | 640d | 643d |  |  | S2 | 82726.6h | 72776.6h | Rel-5 |  | IMS-CCR | TSG |  |  | Liz Daniel, Lucent |  |
| 566 | 81.1.1 | Stage 1 |  | 215d | 2000-02-21 A | 2000-12-15 A |  | 100% |  | 2000-02-21 | 2000-12-15 | 215d |  |  | finish no earlier than 2000-09-21 | S1 | 1720h | 1720h |  | 1633 |  |  |  | CCaR | Mark Cataldo, Motorola | 22.228 |
| 567 | 81.1.2 | Stage 2 (Architecture and Main flows) |  | 246d | 2000-04-14 A | 2001-03-23 A |  | 100% |  | 2000-04-14 | 2001-03-23 | 246d |  |  | finish no earlier than 2001-03-23 | S2 | 1968h | 1968h |  | 1514 |  | TSG |  | CCaR | Liz Daniel, Lucent | 23.228 |
| 568 | 81.1.3 | Impact on MM/CC/SM |  | 400d | 2000-08-28 A | 2002-03-08 A |  | 100% |  | 2000-08-28 | 2002-03-08 | 400d |  |  | finish no earlier than 2002-03-08 | N1 | 3200h | 3200h |  | 1296 | IMS-CCR-IWMM |  |  | CCaR | Keith Drage, Lucent |  |

Notes:
- 543: start/finish dates set / Not started due to lack of supporting companies
- 544: start/finish dates set / Not started yet due to lack of supporting companies
- 549: FS was closed and introduction of WI not agreed at RAN #16
- 553: FS was closed and WI was introduced at RAN #14
- 555: RFC 3095 context relocation
- 557: RP-020356
- 561: duration set to 6 months (was 0) / Task not started due to lack of supporting companies
- 563: Formerly 'Shared Network support in connected mode', renamed at RAN #16.
- 564: S1 WI proposed S1-000290 / TR22.976, WI Rapporteur, Mark Cataldo, Motorola
- 566: Issues include e.g.: Roaming requirements, Requirements on supplementary services, Interworking requirements / Text5: 17.-21.7., S1#9, Completion of CR's against 22 series [dates taken from 22.976]
- 567: Issues include e.g.: Mobile IP, RAB selection principles, Optimized VoIP bearer mechanisms, SIP multimedia protocol / Text5: R00 stage 2 at least 80 % complete in TSGS #8 21.-23.6.2000 [WI dates need revision. To be revised by TSG#8]
- 568: Per 26/2-02: This is understood to be the PCO & TFT CRs which CN1 provides to TSGN #15 for approval. If this is correct understanding, then the task is 100 % complete. / Text5: drage@lucent.com

| ID | WBS | Task | Duration | Start | Finish | Complete | Remaining | Baseline start | Baseline finish | Baseline duration | Total slack | Constraint | Resources | Work | Actual work | Text3 | Text5 | Text7 | Text2 | Text9 | Text1 | Text6 |
| --- | --- | --- | --- | --- | --- | --- | --- | --- | --- | --- | --- | --- | --- | --- | --- | --- | --- | --- | --- | --- | --- | --- |
| 569 | 81.1.4 | **SIP Call Control protocol for the IMS** | 640d | 2000-01-03 A | 2002-06-14 | 98% | 13.73d | 2000-01-03 | 2002-06-14 | 640d | 643d |  | N1 | 70800h | 65682h | TS 24.228, TS 24.229, TS 23.218 | drage@lucent.com | TSG |  |  |  |  |
| 570 | 81.1.4.1 | IMS signalling flows | 385d | 2000-10-02 A | 2002-03-22 A | 100% |  | 2000-10-02 | 2002-03-22 | 385d |  | finish no earlier than 2002-03-22 | N1 | 3080h | 3080h | TS 24.228 |  | TSG | CCaR | 1998 |  |  |
| 571 | 81.1.4.2 | IMS stage 3 | 385d | 2000-10-02 A | 2002-03-22 A | 100% |  | 2000-10-02 | 2002-03-22 | 385d |  | finish no earlier than 2002-03-22 | N1 | 3080h | 3080h | TS 24.229 |  | TSG | CCaR | 1278 |  |  |
| 572 | 81.1.4.3 | IMS Session Handling; stage 2 | 385d | 2000-10-02 A | 2002-03-22 A | 100% |  | 2000-10-02 | 2002-03-22 | 385d |  | finish no earlier than 2002-03-22 | N1 | 3080h | 3080h | TS 23.218 |  | TSG |  | 2255 |  |  |
| 573 | 81.1.4.4 | **Main IETF dependencies** | 635d | 2000-01-03 A | 2002-06-07 | 99% | 0d | 2000-01-03 | 2002-06-07 | 635d | 0d |  | NP | 45392h | 43712h |  |  |  |  |  |  |  |
| 574 | 81.1.4.4.1 | IETF: RFC 3261 (Session Initiation Protocol) | 346d | 2000-11-24 A | 2002-03-22 A | 100% |  | 2000-11-24 | 2002-03-22 | 346d |  | finish no earlier than 2002-03-22 | N1 | 2768h | 2768h |  |  |  |  |  |  |  |
| 575 | 81.1.4.4.2 | IETF: RFC 3262 (Reliability of provisional responses) | 346d | 2000-11-24 A | 2002-03-22 A | 100% |  | 2000-11-24 | 2002-03-22 | 346d |  | finish no earlier than 2002-03-22 | N1 | 2768h | 2768h |  |  |  |  |  |  |  |
| 576 | 81.1.4.4.3 | IETF: RFC 3312 (Without COMET)(Integration of resource management and SIP) | 382d | 2000-11-24 A | 2002-05-13 A | 100% |  | 2000-11-24 | 2002-05-13 | 382d |  | finish no earlier than 2002-05-13 | N1 | 3056h | 3056h |  |  |  |  |  |  |  |
| 577 | 81.1.4.4.4 | IETF: RFC 3323 (SIP extensions for caller identity and privacy) | 382d | 2000-11-24 A | 2002-05-13 A | 100% |  | 2000-11-24 | 2002-05-13 | 382d |  | finish no earlier than 2002-05-13 | N1 | 3056h | 3056h |  |  |  |  |  |  |  |
| 578 | 81.1.4.4.5 | IETF: RFC 3313 (SIP extensions for media authorization) | 382d | 2000-11-24 A | 2002-05-13 A | 100% |  | 2000-11-24 | 2002-05-13 | 382d |  | finish no earlier than 2002-05-13 | N1 | 3056h | 3056h |  |  |  |  |  |  |  |
| 579 | 81.1.4.4.6 | IETF: RFC 3265 (specific event notification) | 346d | 2000-11-24 A | 2002-03-22 A | 100% |  | 2000-11-24 | 2002-03-22 | 346d |  | finish no earlier than 2002-03-22 | N1 | 2768h | 2768h |  |  |  |  |  |  |  |
| 580 | 81.1.4.4.7 | IETF: RFC editor Queue (refer method) | 401d | 2000-11-24 A | 2002-06-07 A | 100% |  | 2000-11-24 | 2002-06-07 | 401d |  | finish no earlier than 2002-06-07 | N1 | 3208h | 3208h |  |  |  |  |  |  |  |
| 581 | 81.1.4.4.8 | IETF: RFC editor Queue (DHCP options for SIP servers) | 382d | 2000-11-24 A | 2002-05-13 A | 100% |  | 2000-11-24 | 2002-05-13 | 382d |  | finish no earlier than 2002-05-13 | N1 | 3056h | 3056h |  |  |  |  |  |  |  |
| 582 | 81.1.4.4.10 | IETF: RFC 3267 (AMR and AMR WB RTP and SDP) | 346d | 2000-11-24 A | 2002-03-22 A | 100% |  | 2000-11-24 | 2002-03-22 | 346d |  | finish no earlier than 2002-03-22 | N1 | 2768h | 2768h |  |  |  |  |  |  |  |
| 583 | 81.1.4.4.11 | IETF: RFC 3266 (IPv6 support within SDP) | 580d | 2000-01-03 A | 2002-03-22 A | 100% |  | 2000-01-03 | 2002-03-22 | 580d |  | finish no earlier than 2002-03-22 | N1 | 4640h | 4640h |  |  |  |  |  |  |  |
| 584 | 81.1.4.4.12 | IETF: RFC 3311 (The Update method) | 382d | 2000-11-24 A | 2002-05-13 A | 100% |  | 2000-11-24 | 2002-05-13 | 382d |  | finish no earlier than 2002-05-13 | N1 | 3056h | 3056h |  |  |  |  |  |  |  |
| 585 | 81.1.4.4.13 | IETF: RFC 3324 (Network Asserted Identity) | 382d | 2000-11-24 A | 2002-05-13 A | 100% |  | 2000-11-24 | 2002-05-13 | 382d |  | finish no earlier than 2002-05-13 | N1 | 3056h | 3056h |  |  |  |  |  |  |  |
| 586 | 81.1.4.4.14 | IETF: RFC editor Queue (Various 3GPP Private Extensions) | 382d | 2000-11-24 A | 2002-05-13 A | 100% |  | 2000-11-24 | 2002-05-13 | 382d |  | finish no earlier than 2002-05-13 | N1 | 3056h | 3056h |  |  |  |  |  |  |  |
| 587 | 81.1.4.5 | **Addressing** | 380d | 2000-10-09 A | 2002-03-22 A | 100% |  | 2000-10-09 | 2002-03-22 | 380d |  |  | S2 | 7744h | 7744h |  |  |  | CCaR | 1290 |  |  |
| 588 | 81.1.4.5.1 | Architectural issues | 235d | 2000-10-09 A | 2001-08-31 A | 100% |  | 2000-10-09 | 2001-08-31 | 235d |  | finish no earlier than 2001-03-16 | S2 | 1880h | 1880h |  |  |  | CCaR | 1291 |  |  |
| 589 | 81.1.4.5.2 | Impact on HSS | 353d | 2000-11-15 A | 2002-03-22 A | 100% |  | 2000-11-15 | 2002-03-22 | 353d |  | finish no earlier than 2002-03-22 | N4 | 2824h | 2824h |  |  |  | CCaR | 1292 |  |  |
| 590 | 81.1.4.6 | **Service Examples** | 304d | 2001-04-17 A | 2002-06-14 | 50% | 152d | 2001-04-17 | 2002-06-14 | 304d | 643d |  | S1 | 4864h | 1502.4h | 22.928 | mcatald1@email.mot.com | TSG |  |  | IMS-Sex |  |
| 591 | 81.1.4.6.1 | IMS Framework Report | 304d | 2001-04-17 A | 2002-06-14 | 50% | 152d | 2001-04-17 | 2002-06-14 | 304d | 643d | finish no earlier than 2002-06-14 | S1 | 2432h | 1216h | 22.941 | rwohlert@tri.sbc.com | TSG |  |  | IMS-FrWk |  |
| 592 | 81.2 | **Access Security for IMS** | 270d | 2001-06-25 A | 2002-07-05 A | 100% |  | 2001-06-25 | 2002-07-05 | 270d |  |  | S3 | 6920h | 6920h |  | krister.boman@emw.ericsson.se | TSG |  | 1298 | IMS-ASEC | Rel-5 |
| 593 | 81.2.1 | SA3 task | 270d | 2001-06-25 A | 2002-07-05 A | 100% |  | 2001-06-25 | 2002-07-05 | 270d |  | finish no earlier than 2002-07-05 | S3 | 2160h | 2160h |  |  |  |  |  |  |  |
| 594 | 81.2.2 | IMS impacts on UICC (ISIM application) | 185d | 2001-10-08 A | 2002-06-21 A | 100% |  | 2001-10-08 | 2002-06-21 | 185d |  | finish no earlier than 2002-06-21 | T3 | 1480h | 1480h |  |  |  |  |  |  |  |
| 595 | 81.2.3 | SIP extensions for Integrity protection | 140d | 2001-12-17 A | 2002-06-28 A | 100% |  | 2001-12-17 | 2002-06-28 | 140d |  | finish no earlier than 2002-06-28 | N1 | 1120h | 1120h |  |  |  |  |  |  |  |
| 596 | 81.3 | Security Aspects of Requirement for Network Configuration Independence | 130d | 2001-07-02 A | 2001-12-28 A | 100% |  | 2001-07-02 | 2001-12-28 | 130d |  | finish no earlier than 2001-12-28 | S3 | 1040h | 1040h |  | hugh.shieh@attws.com | TSG |  |  | SEC1-NCI | Rel-5 |
| 597 | 81.4 | Lawful interception | 410d | 2000-09-04 A | 2002-03-29 A | 100% |  | 2000-09-04 | 2002-03-29 | 410d |  | finish no earlier than 2002-03-29 | S3 | 3280h | 3280h |  | berthold.wilhelm@regtp.de | TSG | CCaR | 1299 | IMS-LI | Rel-5 |
| 598 | 81.5 | Charging and OAM&P for IMS | 383d | 2000-12-25 A | 2002-06-12 A | 100% |  | 2000-12-25 | 2002-06-12 | 383d |  | finish no earlier than 2002-06-12 | S5 | 3064h | 3064h | 32-series | Albert.Yuhan@voicestream.com; Michael.Truss@MOTOROLA.COM | TSG | CCaR | 1303 | IMS-OAM | Rel-5 |

Notes:
- 569: TSGN_10 approved the change:CN1 - SA2 SIP joint meeting spotted one more place for improvement: work tasks with ID 1998 and 1278 are actually subtasks under of single CN1 WT. One WI has been approved for the CN1 WT with title "SIP Call Control protocol... / Text4: Keith Drage, Lucent
- 570: TS 24.228...
- 571: TS 24.229...
- 572: TS 23.218...
- 589: 17th May, KK: This is cover by 29.228 & 29228. Work complete.
- 590: Text4: Mark Cataldo, Motorola
- 591: Text4: Randolph Wohlert, SBC Technology Resources, Inc.
- 592: TS33.203 will be presented for info at SA#14 and is scheduled for approval at SA#15. Dependencies on IETF exist. Approved SA#15 / Text4: Krister Boman, Ericsson
- 593: SHOULD BE DELETED - COVERED BY REAL S3 TASKS
- 594: Text4: Jeremy Norris (Vodafone)
- 595: Per 26/2-02: CN1 is not aware of any requirements and is not doing anything on this task.
- 596: Incorporated into IMS access security TS (33.203) which will be presented for info at SA#14 and is scheduled for approval at SA#15.Editors notes removed SA#16&17 / Text4: Hugh Shieh, AT&T Wireless Services
- 597: Rel-5 33.106 and 33.107 approved at SA#12.Revised WID including new Rel-5 specification (33.108) scheduled for approval at SA#14. 33.108 approved SA#16. CR at SA#17 / Text4: Berthold Wilhelm, Reg TP
- 598: Text4: Albert YUHAN (VoiceStream Wireless), Michael TRUSS (Motorola)

| ID | WBS | Task | Duration | Start | Finish | Complete | Remaining | Baseline start | Baseline finish | Baseline duration | Total slack | Constraint | Resources | Work | Actual work | Text1 | Text3 | Text4 | Text5 | Text6 | Text7 | Text9 | Text2 |
| --- | --- | --- | --- | --- | --- | --- | --- | --- | --- | --- | --- | --- | --- | --- | --- | --- | --- | --- | --- | --- | --- | --- | --- |
| 599 | 81.6 | **Multimedia codecs and protocols for conversational PS services** | 568d | 2000-07-26 A | 2002-09-27 A | 100% |  | 2000-07-26 | 2002-09-27 | 568d |  |  | S4 | 15640h | 15640h | IMS-CODEC | 26.235, 26.236 | B. Aronson, Toshiba, and P. Ojala, Nokia | pasi.s.ojala@nokia.com | Rel-5 | TSG |  |  |
| 600 | 81.6.1 | Codecs | 427d | 2000-07-26 A | 2002-03-14 A | 100% |  | 2000-07-26 | 2002-03-14 | 427d |  | finish no earlier than 2001-03-21 | S4 | 3416h | 3416h |  | 26.235, 26.236 |  |  |  | TSG | 2039 |  |
| 601 | 81.6.2 | Transport protocols | 1d | 2002-03-12 A | 2002-03-12 A | 100% |  | 2002-03-12 | 2002-03-12 | 1d |  | finish no earlier than 2002-03-12 | S4 | 8h | 8h | IMS-CODEC | 26.236 | P. Ojala, Nokia |  | Rel-5 |  |  |  |
| 602 | 81.6.4 | recommendation for QoS parameter values for various media types | 195d | 2001-12-31 A | 2002-09-27 A | 100% |  | 2001-12-31 | 2002-09-27 | 195d |  | finish no earlier than 2002-09-27 | S4 | 1560h | 1560h |  |  |  |  |  | TSG |  |  |
| 603 | 81.6.5 | IETF: RFC 3310 (HTTP Digest Authentication using AKA) | 382d | 2000-11-24 A | 2002-05-13 A | 100% |  | 2000-11-24 | 2002-05-13 | 382d |  | finish no earlier than 2002-05-13 | N1 | 3056h | 3056h |  |  |  |  |  |  |  |  |
| 604 | 81.6.6 | IETF: RFC 3329 (Security mechanism agreement for SIP connections) | 382d | 2000-11-24 A | 2002-05-13 A | 100% |  | 2000-11-24 | 2002-05-13 | 382d |  | finish no earlier than 2002-05-13 | N1 | 3056h | 3056h |  |  |  |  |  |  |  |  |
| 605 | 81.7 | **SIP message compression** | 185d | 2001-09-24 A | 2002-06-07 A | 100% |  | 2001-09-24 | 2002-06-07 | 185d |  |  | S2 | 3128h | 3128h |  |  |  |  | Rel-5 |  |  |  |
| 606 | 81.7.1 | Stage 2 | 25d | 2001-09-24 A | 2001-10-26 A | 100% |  | 2001-09-24 | 2001-10-26 | 25d |  | finish no earlier than 2001-10-26 | S2 | 200h | 200h |  |  |  |  |  |  |  |  |
| 607 | 81.7.2 | Compression signalling | 181d | 2001-09-28 A | 2002-06-07 A | 100% |  | 2001-09-28 | 2002-06-07 | 181d |  | finish no earlier than 2002-06-07 | N1 | 1448h | 1448h |  |  |  |  |  |  |  |  |
| 608 | 81.8 | **Stage 3 description of IMS interfaces** | 383d | 2001-03-14 A | 2002-08-30 | 98% | 6.7d | 2001-03-14 | 2002-08-30 | 383d | 588d |  | NP | 29531.6h | 29014.9h |  |  |  |  | Rel-5 |  |  |  |
| 609 | 81.8.1 | Cx interface (HSS to CSCF) | 135.95d | 2001-03-14 A | 2002-06-07 A | 100% |  | 2001-03-14 | 2002-06-07 | 135.95d |  | finish no earlier than 2002-06-07 | N4 | 1087.58h | 1087.58h |  |  |  |  |  | TSG |  |  |
| 610 | 81.8.2 | Mp interface (MRFC - MRFP) enhancements | 258d | 2001-03-14 A | 2002-03-08 A | 100% |  | 2001-03-14 | 2002-03-08 | 258d |  | finish no earlier than 2002-06-07 | N4 | 2064h | 2064h |  |  |  |  |  |  |  |  |
| 611 | 81.8.3 | Mw interface (CSCF to P-CSCF) | 323d | 2001-03-14 A | 2002-06-07 A | 100% |  | 2001-03-14 | 2002-06-07 | 323d |  | finish no earlier than 2002-06-07 | N1 | 2584h | 2584h |  |  |  |  |  |  |  |  |
| 612 | 81.8.4 | Mr interface (CSCF to MRF) | 273d | 2001-03-14 A | 2002-03-29 A | 100% |  | 2001-03-14 | 2002-03-29 | 273d |  | finish no earlier than 2002-03-29 | N1 | 2184h | 2184h |  |  |  |  |  |  |  |  |
| 613 | 81.8.5 | Dx interface (I-CSCF to SLF) | 323d | 2001-03-14 A | 2002-06-07 A | 100% |  | 2001-03-14 | 2002-06-07 | 323d |  | finish no earlier than 2002-06-07 | N4 | 2584h | 2584h |  |  |  |  |  |  |  |  |
| 614 | 81.8.6 | Go interface (GGSN to PCF) | 323d | 2001-03-14 A | 2002-06-07 | 95% | 16.15d | 2001-03-14 | 2002-06-07 | 323d | 648d | finish no earlier than 2002-06-07 | N3 | 2584h | 2454.8h |  |  |  |  |  |  |  |  |
| 615 | 81.8.7 | ISC (IMS Service Control) Interface | 323d | 2001-03-14 A | 2002-06-07 A | 100% |  | 2001-03-14 | 2002-06-07 | 323d |  | finish no earlier than 2002-06-07 | N1 | 2584h | 2584h |  |  |  |  |  |  |  |  |
| 616 | 81.8.8 | Sh interface (HSS to AS) | 82d | 2002-02-14 A | 2002-06-07 A | 100% |  | 2002-02-14 | 2002-06-07 | 82d |  | finish no earlier than 2002-06-07 | N4 | 656h | 656h |  |  |  |  |  |  |  |  |
| 617 | 81.8.9 | Si interface (HSS to IM-SSF) | 162.5d | 2002-01-16 A | 2002-08-30 | 72% | 45d | 2002-01-16 | 2002-08-30 | 162.5d | 588d | finish no earlier than 2002-06-07 | N4 | 1300h | 940h |  |  |  |  |  |  |  |  |
| 618 | 81.8.10 | Gm interface (UE to CSCF) | 323d | 2001-03-14 A | 2002-06-07 A | 100% |  | 2001-03-14 | 2002-06-07 | 323d |  | finish no earlier than 2002-06-07 | N1 | 2584h | 2584h |  |  |  |  |  |  |  |  |
| 619 | 81.8.11 | Mi interface (CSCF to BGCF) | 323d | 2001-03-14 A | 2002-06-07 A | 100% |  | 2001-03-14 | 2002-06-07 | 323d |  | finish no earlier than 2002-06-07 | N1 | 2584h | 2584h |  |  |  |  |  |  |  |  |
| 620 | 81.8.12 | Mj interface (BGCF to MGCF) | 323d | 2001-03-14 A | 2002-06-07 A | 100% |  | 2001-03-14 | 2002-06-07 | 323d |  | finish no earlier than 2002-06-07 | N1 | 2584h | 2584h |  |  |  |  |  |  |  |  |
| 621 | 81.8.13 | Mk interface (BGCF to BGCF) | 323d | 2001-03-14 A | 2002-06-07 A | 100% |  | 2001-03-14 | 2002-06-07 | 323d |  | finish no earlier than 2002-06-07 | N1 | 2584h | 2584h |  |  |  |  |  |  |  |  |
| 622 | 81.9 | Support of VHE/OSA by entities and protocols of the IMS (e.g. CSCF) | 186d | 2001-09-21 A | 2002-06-07 A | 100% |  | 2001-09-21 | 2002-06-07 | 186d |  | finish no earlier than 2002-06-07 | N5 | 1488h | 1488h | IMS-ONOSA | 29.198, 29.998 | Ard-Jan MOERDIJK (Ericsson) | Ard.Jan.Moerdijk@eln.ericsson.se | Rel-5 | TSG | 1310 | CCaR |

Notes:
- 609: DAB 12/12/01 to 75% / CN4 14/02/02 to 79% / 17th May work complete. 3GPP TSs 29.228 and 29.229 will be sent for proval in CN#16
- 610: [DAB 08-03-02] - No work required in CN4
- 613: CN4#11 30/11/01: No inputs received in CN4 / 14/02/02 Completed(introduced in 29.228)
- 614: [DAB - 30/07/02] - % complete to 95% (if we exclude Diffserv)
- 616: CN4#11 30/11/01: No inputs received in CN4 / CN4#12bis 14/02/02: WID approved / 17th May 100% complete. 3GPP TS 29.329 will be sent for approval in CN#16
- 617: SA16: Part of Rel5 only if completed in September 02

| ID | WBS | Task | Type | Duration | Start | Finish | Predecessors | Complete | Remaining | Baseline start | Baseline finish | Baseline duration | Total slack | Free slack | Constraint | Resources | Work | Actual work | Text1 | Text2 | Text4 | Text6 | Text9 | Text3 | Text5 | Text7 | Text8 |
| --- | --- | --- | --- | --- | --- | --- | --- | --- | --- | --- | --- | --- | --- | --- | --- | --- | --- | --- | --- | --- | --- | --- | --- | --- | --- | --- | --- |
| 623 | 81.10 | **CAMEL control of IMS services** |  | 365d | 2001-04-16 A | 2002-09-06 |  | 91% | 34.05d | 2001-04-16 | 2002-09-06 | 365d | 583d |  |  | N2 | 9952h | 9023.6h | IMS-CAMEL | CCaR | Angelica Remoquillo, Lucent | Rel-5 | 1310 |  |  |  |  |
| 624 | 81.10.1 | Stage2 work 'general' |  | 365d | 2001-04-16 A | 2002-09-06 A |  | 100% |  | 2001-04-16 | 2002-09-06 | 365d |  |  | finish no earlier than 2002-09-06 | N2 | 2920h | 2920h |  |  |  |  |  |  |  |  |  |
| 625 | 81.10.2 | Stage3 work 'CAP' |  | 175d | 2002-01-07 A | 2002-09-06 A |  | 100% |  | 2002-01-07 | 2002-09-06 | 175d |  |  | finish no earlier than 2002-09-06 | N2 | 1400h | 1400h |  |  |  |  |  |  |  |  |  |
| 626 | 81.10.3 | Stage2 work 'Si interface' |  | 175d | 2002-01-07 A | 2002-09-06 A |  | 100% |  | 2002-01-07 | 2002-09-06 | 175d |  |  | finish no earlier than 2002-09-06 | N2 | 1400h | 1400h |  |  |  |  |  |  |  |  |  |
| 627 | 81.10.4 | Stage3 work 'Si interface' |  | 82d | 2002-02-14 A | 2002-06-07 A |  | 100% |  | 2002-02-14 | 2002-06-07 | 82d |  |  | finish no earlier than 2002-06-07 | N4 | 656h | 656h |  |  |  |  |  |  |  |  |  |
| 628 | 81.10.5 | SDM issues for CAMEL control of IMS |  | 82d | 2002-02-14 | 2002-06-07 |  |  |  | 2002-02-14 | 2002-06-07 | 82d | 648d |  | finish no earlier than 2002-06-07 | N4 | 656h |  |  |  |  |  |  |  |  |  |  |
| 629 | 81.11 | Pre-pay/real-time charging in IMS |  | 196d | 2001-06-15 A | 2002-03-15 |  | 60% | 78.4d | 2001-06-15 | 2002-03-15 | 196d | 708d |  | finish no earlier than 2002-03-15 | S1 | 1568h | 940.8h |  |  |  | TBD |  |  |  |  |  |
| 630 | 81.12 | **Charging** |  | 289d | 2001-08-06 A | 2002-09-12 A |  | 100% |  | 2001-08-06 | 2002-09-12 | 289d |  |  |  | S5 | 4624h | 4624h | OAM-CH |  | Karl-Heinz NENNER (T-Mobile) | Rel-5 |  | 32.2xy | karl-heinz.nenner@t-mobile.de | TSG |  |
| 631 | 81.12.1 | Charging Implications of IMS architecture |  | 75d | 2001-08-06 A | 2001-11-16 A |  | 100% |  | 2001-08-06 | 2001-11-16 | 75d |  |  | finish no earlier than 2001-11-16 | S2 | 600h | 600h |  |  |  |  |  |  |  |  |  |
| 632 | 81.12.2 | Charging management for IMS (off-line & on-line) |  | 214d | 2001-11-19 A | 2002-09-12 A | 631 | 100% |  | 2001-11-19 | 2002-09-12 | 214d |  |  | finish no earlier than 2002-09-12 | S5 | 1712h | 1712h | OAM-CH |  |  | Rel-5 |  |  |  | TSG |  |
| 633 | 81.13 | **Other IETF depencies** |  | 401d | 2000-11-24 A | 2002-06-07 |  | 70% | 120.3d | 2000-11-24 | 2002-06-07 | 401d | 648d |  |  | NP | 9624h | 6736.8h |  |  |  | Rel-5 |  |  |  |  |  |
| 634 | 81.13.1 | IETF: draft-ietf-aaa-diameter - should be CN4 |  | 401d | 2000-11-24 A | 2002-06-07 |  | 90% | 40.1d | 2000-11-24 | 2002-06-07 | 401d | 648d |  | finish no earlier than 2002-06-07 | NP | 3208h | 2887.2h |  |  |  |  |  |  |  |  |  |
| 635 | 81.13.2 | IETF: draft-johansson-aaa-diameter-mm-app - should be CN4 |  | 401d | 2000-11-24 A | 2002-06-07 |  | 50% | 200.5d | 2000-11-24 | 2002-06-07 | 401d | 648d |  | finish no earlier than 2002-06-07 | NP | 3208h | 1604h |  |  |  |  |  |  |  |  |  |
| 636 | 81.14 | Start Testing | milestone | 0d | 2002-03-18 | 2002-03-18 |  |  |  | 2002-03-18 | 2002-03-18 | 0d | 503d | 0d | start no earlier than 2002-03-18 | MLST |  |  |  |  |  | Rel-5 | 1913 |  |  |  |  |
| 637 | 81.15 | Conformance Test Aspects - Provisioning of IMS |  | 205d | 2002-03-18 | 2002-12-27 | 636 |  |  | 2002-03-18 | 2002-12-27 | 205d | 503d |  | finish no earlier than 2002-12-27 | T1 | 1640h |  | IMS-TEST |  |  |  | 1844 |  |  |  |  |
| 638 | 81.16 | Testing of support for IMS - prose |  | 270d | 2002-09-18 | 2003-09-30 |  |  |  | 2002-09-18 | 2003-03-31 | 139d | 306d |  | finish no earlier than 2003-09-30 | T1 | 2160h |  |  |  | Dan Fox, Anritsu | Rel-5 |  | 34.108, 34.123 | dan.fox@eu.anritsu.com | TSG |  |
| 639 | 81.17 | Testing of support for IMS - TTCN |  | 381d | 2002-09-18 | 2004-03-03 |  |  |  | 2002-09-18 | 2003-09-30 | 270d | 195d |  | finish no earlier than 2004-03-03 | T1 | 3048h |  |  |  | Dan Fox, Anritsu | Rel-5 |  | 34.108, 34.123 | dan.fox@eu.anritsu.com | TSG |  |
| 640 | 82 | **Extended Transparent End-to-End PS Streaming Service** |  | 313d? | 2002-01-03 A | 2003-03-17 |  | 86% | 44.84d? | 2002-01-03 | 2003-03-17 | 313d? | 447d |  |  | S4 | 6224h | 4687.31h | PSS-E |  | O. Franceschi, Ericsson | Rel-5 |  | 26.233, 26.234 | olle.franceschi@nrj.ericsson.se | TSG | Paolo |
| 641 | 82.1 | **Stage 1** |  | 86d? | 2002-11-18 A | 2003-03-17 |  | 65% | 30.1d? | 2002-11-18 | 2003-03-17 | 86d? | 447d |  |  | S1 | 1376h | 1015.2h |  |  | Stephen Wolak, VODAFONE Group Plc |  |  | 22.233 | stephen.wolak@vodafone.com | TSG |  |
| 642 | 86.1.1 | Interaction with other services |  | 86d? | 2002-11-18 A | 2003-03-17 |  | 65% | 30.1d? | 2002-11-18 | 2003-03-17 | 86d? | 447d |  | finish no earlier than 2003-03-17 | S1 | 688h | 447.2h |  |  | Stephen Wolak, VODAFONE Group Plc |  |  | 22.233 | stephen.wolak@vodafone.com | TSG |  |
| 643 | 82.2 | Stage 2 (version Rel5 of TS 26.234) |  | 51d | 2002-01-03 A | 2002-03-14 A |  | 100% |  | 2002-01-03 | 2002-03-14 | 51d |  |  | finish no earlier than 2002-03-26 | S4 | 408h | 408h |  |  |  |  |  | 26.234 |  | TSG |  |
| 644 | 82.3 | RTP usage model |  | 242d | 2002-01-03 A | 2002-12-06 |  | 90% | 24.2d | 2002-01-03 | 2002-12-06 | 242d | 518d |  | finish no earlier than 2002-12-06 | S4 | 1936h | 1742.4h |  |  |  |  |  | 26.937 |  |  |  |
| 645 | 83 | **Rel-5 OSA enhancements** |  | 504d | 2000-07-11 A | 2002-06-14 |  | 95% | 25.55d | 2000-07-11 | 2002-06-14 | 504d | 643d |  |  | S1 | 46736h | 41443.5h | OSA1 |  | Jörg Swetina, SIEMENS AG | NA |  | 22.127, 23.127, 29.198-x, 29.998-x |  | TSG | Adrian |
| 646 | 83.1 | General Stage 2 for Rel5 |  | 194d | 2001-09-11 A | 2002-06-07 |  | 47% | 103d | 2001-09-11 | 2002-06-07 | 194d | 648d |  |  | S2 | 1232h | 408h |  |  |  |  | 2116 |  |  |  |  |

Notes:
- 623: SA16: Part of Rel5 only if Si completed in September 02
- 624: DAB 12.12.01 split into cn4 and cn2 parts
- 625: DAB 12.12.01 split into cn4 and cn2 parts
- 626: DAB 12.12.01 split into cn4 and cn2 parts
- 627: [DAB 08-03-02] - UID 12004 is MASTER of UID 14998 / 17 May need to be recearch possible impact on 23.008 & 23.016, changes to 29.002 are done.
- 628: [DAB 08-03-02] - No activity on this in CN4
- 630: Changed Rapp email
- 633: Was introduced at SA#13 by Ileana Leuca (exact position in the WP and related WG have to be defined)
- 637: The task is a building block, individual work items are being considered but are constrained by lack of supporting companies
- 641: 2nd resp SA4
- 642: 2nd resp SA4
- 643: 2nd resp SA2

| ID | WBS | Task | Duration | Start | Finish | Predecessors | Complete | Remaining | Baseline start | Baseline finish | Baseline duration | Total slack | Constraint | Resources | Work | Actual work | Text1 | Text6 | Text7 | Text2 | Text3 | Text4 | Text5 | Text8 | Text9 |
| --- | --- | --- | --- | --- | --- | --- | --- | --- | --- | --- | --- | --- | --- | --- | --- | --- | --- | --- | --- | --- | --- | --- | --- | --- | --- |
| 647 | 83.2 | **OSA APIs for Multimedia Call Control** | 499d | 2000-07-11 A | 2002-06-07 A |  | 100% |  | 2000-07-11 | 2002-06-07 | 499d |  |  | S2 | 5960h | 5960h | OSA1-CSCF | Rel-5 | TSG |  |  |  |  |  |  |
| 648 | 83.2.1 | Stage 1 | 438d | 2000-07-11 A | 2002-03-14 A |  | 100% |  | 2000-07-11 | 2002-03-14 | 438d |  | finish no earlier than 2002-03-14 | S1 | 3504h | 3504h |  |  | TSG | Ser | 22.127 | Manfred Leitgeb, SIEMENS AG | Manfred.leitgeb@siemens.at | Michael | 1430 |
| 649 | 83.2.2 | (Multimedia) Call Control - Stages 2 and 3 | 194d | 2001-09-11 A | 2002-06-07 A |  | 100% |  | 2001-09-11 | 2002-06-07 | 194d |  | finish no earlier than 2002-06-07 | N5 | 1552h | 1552h |  |  | TSG |  | 29.198-04 |  |  |  |  |
| 650 | 83.3 | Generic user interaction - Stage 3 | 194d | 2001-09-11 A | 2002-06-07 A |  | 100% |  | 2001-09-11 | 2002-06-07 | 194d |  | finish no earlier than 2002-06-07 | N5 | 1552h | 1552h |  | Rel-5 | TSG |  | 29.198-05 |  |  |  |  |
| 651 | 83.4 | Charging - Stage 3 | 194d | 2001-09-11 A | 2002-06-07 A |  | 100% |  | 2001-09-11 | 2002-06-07 | 194d |  | finish no earlier than 2002-06-07 | N5 | 1552h | 1552h |  | Rel-5 | TSG |  | 29.198-12 |  |  |  |  |
| 652 | 83.5 | Call Control Service Mapping; Multiparty Call Control SIP - Stage 3 | 194d | 2001-09-11 A | 2002-06-07 A |  | 100% |  | 2001-09-11 | 2002-06-07 | 194d |  | finish no earlier than 2002-06-07 | N5 | 1552h | 1552h |  | Rel-5 | TSG |  | 29.998-04-4 |  |  |  |  |
| 653 | 83.6 | WSDL APIs for SOAP/HTTP - Stage 3 | 455d | 2000-09-11 A | 2002-06-07 A |  | 100% |  | 2000-09-11 | 2002-06-07 | 455d |  | finish no earlier than 2002-06-07 | N5 | 3640h | 3640h |  | Rel-5 | TSG |  | 29.198, 29.998 |  |  |  |  |
| 654 | 83.7 | **OSA security** | 504d | 2000-07-11 A | 2002-06-14 |  | 92% | 41.92d | 2000-07-11 | 2002-06-14 | 504d | 643d |  | S3 | 12304h | 11280.6h | OSA1-SEC | Rel-5 | TSG | Ser |  | Colin Blanchard, BT | colin.blanchard@bt.com |  | 1419 |
| 655 | 83.7.1 | Stage 1 | 349d | 2000-07-11 A | 2001-11-09 A |  | 100% |  | 2000-07-11 | 2001-11-09 | 349d |  | finish no earlier than 2001-11-09 | S1 | 2792h | 2792h |  |  | TSG |  | 22.127 | Manfred Leitgeb, SIEMENS AG | Manfred.leitgeb@siemens.at | Michael | 2121 |
| 656 | 83.7.2 | Stage 3 | 430d | 2000-10-23 A | 2002-06-14 |  | 80% | 86d | 2000-10-23 | 2002-06-14 | 430d | 643d | finish no earlier than 2002-06-14 | S3 | 3440h | 2752h |  |  | TSG | Ser | ??? |  |  |  | 1421 |
| 657 | 83.7.3 | security related SCF(s) definition | 186d | 2001-09-21 A | 2002-06-07 A |  | 100% |  | 2001-09-21 | 2002-06-07 | 186d |  | finish no earlier than 2002-06-07 | N5 | 1488h | 1488h |  |  | TSG | Ser | 29.198, 29.998 | Ard-Jan MOERDIJK (Ericsson) | Ard.Jan.Moerdijk@eln.ericsson.se |  | 1422 |
| 658 | 83.7.4 | (possibly) changes required from supporting platforms, e.g. gsmSCF, HLR | 69d | 2000-09-11 A | 2000-12-14 A |  | 100% |  | 2000-09-11 | 2000-12-14 | 69d |  | finish no earlier than 2000-12-14 | S3 | 552h | 552h |  |  | TSG | Ser | ??? |  |  |  | 1423 |
| 659 | 83.8 | **Interactions OSA - e-commerce** | 499d | 2000-07-11 A | 2002-06-07 |  | 96% | 17.51d | 2000-07-11 | 2002-06-07 | 499d | 648d |  | S2 | 6152h | 5976.8h | OSA1-ECOM | Rel-5 | TSG |  |  |  |  |  | 1424 |
| 660 | 83.8.1 | Stage 1 | 438d | 2000-07-11 A | 2002-03-14 |  | 95% | 21.9d | 2000-07-11 | 2002-03-14 | 438d | 709d | finish no earlier than 2000-12-28 | S1 | 3504h | 3328.8h |  |  | TSG |  | 22.127 | Jörg Swetina, SIEMENS AG |  |  | 1425 |
| 661 | 83.8.2 | Stages 2 and 3 | 186d | 2001-09-21 A | 2002-06-07 A |  | 100% |  | 2001-09-21 | 2002-06-07 | 186d |  | finish no earlier than 2002-06-07 | N5 | 1488h | 1488h |  |  | TSG |  | 29.198, 29.998 | Ard-Jan MOERDIJK (Ericsson) | Ard.Jan.Moerdijk@eln.ericsson.se |  | 1529 |
| 662 | 83.9 | Policy Management - Stage 3 | 194d | 2001-09-11 A | 2002-06-07 A |  | 100% |  | 2001-09-11 | 2002-06-07 | 194d |  | finish no earlier than 2002-06-07 | N5 | 1552h | 1552h |  | Rel-5 | TSG |  | 29.198-13 |  |  |  |  |
| 663 | 83.10 | Presence and Availability Management (PAM) - Stage 3 | 194d | 2001-09-11 A | 2002-06-07 A |  | 100% |  | 2001-09-11 | 2002-06-07 | 194d |  | finish no earlier than 2002-06-07 | N5 | 1552h | 1552h |  | Rel-5 | TSG |  | 29.198-14 |  |  |  |  |
| 664 | 83.11 | **CHECK STATUS - LCS - OSA interfaces** | 455d | 2000-09-11 A | 2002-06-07 |  | 99% | 0d | 2000-09-11 | 2002-06-07 | 455d | 0d |  | S1 | 5656h | 2590.4h | OSA1-LCSI | Rel-5 | TSG | Ser |  | Jörg Swetina, SIEMENS AG |  |  | 1786 |
| 665 | 83.11.1 | Stage 1 | 65d | 2000-09-11 A | 2000-12-08 A |  | 100% |  | 2000-09-11 | 2000-12-08 | 65d |  | finish no earlier than 2000-12-08 | S1 | 520h | 520h |  |  | TSG | Ser | 22.127 | Jörg Swetina, SIEMENS AG |  |  | 1787 |
| 666 | 83.11.2 | Stage 2 | 1d | 2000-12-11 A | 2000-12-11 A | 665 | 100% |  | 2000-12-11 | 2000-12-11 | 1d |  | finish no earlier than 2000-12-11 | S2 | 8h | 8h |  |  | TSG |  | 23.127 | Christophe GOURRAUD, Ericsson Canada |  |  | 2124 |
| 667 | 83.11.3 | Stage 3 | 186d | 2001-09-21 A | 2002-06-07 A | 666 | 100% |  | 2001-09-21 | 2002-06-07 | 186d |  | finish no earlier than 2002-06-07 | N5 | 1488h | 1488h |  |  | TSG | Ser | 29.198, 29.998 | Ard-Jan MOERDIJK (Ericsson) | Ard.Jan.Moerdijk@eln.ericsson.se |  | 1788 |
| 668 | 84 | **CAMEL phase 4** | 625d | 2000-04-17 A | 2002-09-06 |  | 99% | 0d | 2000-04-17 | 2002-09-06 | 625d | 0d |  | S1 | 41104h | 36244h | CAMEL4 | Rel-5 | WG |  |  | Keijo Palviainen, Nokia | keijo.palviainen@nokia.com | Andrijana | 1638 |
| 669 | 84.1 | Service requirements | 565d | 2000-04-17 A | 2002-06-14 A |  | 100% |  | 2000-04-17 | 2002-06-14 | 565d |  | finish no earlier than 2002-06-14 | S1 | 4520h | 4520h |  |  | WG | Ser |  |  |  |  | 1461 |
| 670 | 84.2 | Call Party Handling | 500d | 2000-07-10 A | 2002-06-07 A |  | 100% |  | 2000-07-10 | 2002-06-07 | 500d |  | finish no earlier than 2002-06-07 | N2 | 4000h | 4000h | CAMEL4-CPH |  | WG | Ser |  |  |  |  | 2012 |
| 671 | 84.3 | Mid call procedure for MO and MT calls | 495d | 2000-07-17 A | 2002-06-07 A |  | 100% |  | 2000-07-17 | 2002-06-07 | 495d |  | finish no earlier than 2002-06-07 | N2 | 3960h | 3960h | CAMEL4-MCP |  | WG | Ser |  |  |  |  | 2013 |
| 672 | 84.4 | Interactions with Optimal Routing | 430d | 2000-07-17 A | 2002-03-08 A |  | 100% |  | 2000-07-17 | 2002-03-08 | 430d |  | finish no earlier than 2002-03-08 | N2 | 3440h | 3440h | CAMEL4-IOR |  | WG | Ser |  |  |  |  | 2014 |
| 673 | 84.5 | Inclusion of flexible tone injection | 430d | 2000-07-17 A | 2002-03-08 A |  | 100% |  | 2000-07-17 | 2002-03-08 | 430d |  | finish no earlier than 2002-03-08 | N2 | 3440h | 3440h | CAMEL4-IFTI |  | WG | Ser |  |  |  |  | 2015 |
| 674 | 84.6 | CSE control over MT SMS | 430d | 2000-07-17 A | 2002-03-08 A |  | 100% |  | 2000-07-17 | 2002-03-08 | 430d |  | finish no earlier than 2002-03-08 | N2 | 3440h | 3440h | CAMEL4-CCSMS |  | WG | Ser |  |  |  |  | 2016 |
| 675 | 84.7 | Notification of GPRS mobility management to CSE | 331d | 2001-03-02 A | 2002-06-07 A |  | 100% |  | 2001-03-02 | 2002-06-07 | 331d |  | finish no earlier than 2002-06-07 | N2 | 2648h | 2648h | CAMEL4-NMM |  | WG |  |  |  |  |  | 2460 |
| 676 | 84.8 | Provision of location information of called subscriber | 266d | 2001-03-02 A | 2002-03-08 A |  | 100% |  | 2001-03-02 | 2002-03-08 | 266d |  | finish no earlier than 2002-03-08 | N2 | 2128h | 2128h | CAMEL4-LOCB |  | WG |  |  |  |  |  | 2458 |
| 677 | 84.9 | Inclusion of ODB data in the CSE_HLR interface | 175d | 2001-07-09 A | 2002-03-08 A |  | 100% |  | 2001-07-09 | 2002-03-08 | 175d |  | finish no earlier than 2002-03-08 | N2 | 1400h | 1400h | CAMEL4-ODB |  | WG |  |  |  |  |  |  |
| 678 | 84.10 | Location information during an ongoing call (Handover DP) | 280d | 2001-05-14 A | 2002-06-07 A |  | 100% |  | 2001-05-14 | 2002-06-07 | 280d |  | finish no earlier than 2002-06-07 | N2 | 2240h | 2240h | CAMEL4-HODP |  | WG |  |  |  |  |  |  |
| 679 | 84.11 | GPRS Any Time Interrogation | 240d | 2001-07-09 A | 2002-06-07 A |  | 100% |  | 2001-07-09 | 2002-06-07 | 240d |  | finish no earlier than 2002-06-07 | N2 | 1920h | 1920h | CAMEL4-ATI |  | WG |  |  |  |  |  |  |
| 680 | 84.12 | Transfer of IMEI (with SW version) to CSE | 240d | 2001-07-09 A | 2002-06-07 A |  | 100% |  | 2001-07-09 | 2002-06-07 | 240d |  | finish no earlier than 2002-06-07 | N2 | 1920h | 1920h | CAMEL4-ATI |  | WG |  |  |  |  |  |  |
| 681 | 84.13 | Handling of partial implementations of CAMEL4 | 131d | 2002-03-08 A | 2002-09-06 A |  | 100% |  | 2002-03-08 | 2002-09-06 | 131d |  | finish no earlier than 2002-06-07 | N2 | 1048h | 1048h | CAMEL4-SUB |  | WG |  |  |  |  |  |  |

Notes:
- 647: For Rel5 even if completed by March
- 654: CR to correct security specifications in 29.198 scheduled for approval at CN#15
- 656: ??
- 664: az: CN#13 - changed to Rel5
- 666: az 24/05/01: Rel4 completion 90->100%.
- 677: Added on May 29, 2001
- 681: stage2 and stage3 CRs for approval at CN#17

| ID | WBS | Task | Type | Duration | Start | Finish | Predecessors | Complete | Remaining | Baseline start | Baseline finish | Baseline duration | Total slack | Constraint | Resources | Work | Actual work | Text1 | Text2 | Text6 | Text7 | Text8 | Text9 | Text3 | Text4 | Text5 |
| --- | --- | --- | --- | --- | --- | --- | --- | --- | --- | --- | --- | --- | --- | --- | --- | --- | --- | --- | --- | --- | --- | --- | --- | --- | --- | --- |
| 682 | 85 | **Rel-5 MExE enhancements** |  | 250d | 2001-03-26 A | 2002-03-08 A |  | 100% |  | 2001-03-26 | 2002-03-08 | 250d |  |  | T2 | 2880h | 2880h | MEXE5 | Ter | Rel-5 | TSG | Friedhelm | 2464 |  |  |  |
| 683 | 85.1 | MExE Rel-5 Improvements and Investigations |  | 110d | 2001-03-26 A | 2002-03-08 A |  | 100% |  | 2001-03-26 | 2002-03-08 | 110d |  | finish no earlier than 2001-12-17 | T2 | 880h | 880h | MEXE5-ENHANC | Ter |  | TSG |  | 2466 | 22.057, 23.057 | Mark CATALDO, Motorola | mcatald1@MOTOROLA.COM |
| 684 | 86 | **Wideband Telephony Service - AMR** |  | 1035d | 2000-01-01 A | 2003-12-19 |  | 83% | 179.73d | 2000-01-01 | 2003-12-19 | 1035d | 248d |  | S4 | 83992h | 65964.1h | AMRWB |  | Rel-5 | TSG | Paolo |  |  | Imre Varga, Siemens AG | Imre.Varga@mch.siemens.de |
| 685 | 86.1 | **Specification** |  | 704d | 2000-01-01 A | 2002-09-12 |  | 99% | 0.4d | 2000-01-01 | 2002-09-12 | 704d | 579d |  | S4 | 22512h | 22481.9h |  |  |  |  |  |  |  |  |  |
| 686 | 86.1.1 | Stage 1 |  | 125d | 2001-10-01 A | 2002-03-22 A |  | 100% |  | 2001-10-01 | 2002-03-22 | 125d |  | finish no earlier than 2002-03-22 | S1 | 1000h | 1000h |  |  |  |  |  |  |  |  |  |
| 687 | 86.1.2 | **Stage 2** |  | 76d | 2000-01-03 A | 2000-04-17 A |  | 100% |  | 2000-01-03 | 2000-04-17 | 76d |  |  | S4 | 1224h | 1224h |  |  |  |  |  |  |  |  |  |
| 688 | 86.1.2.1 | Design Constraints |  | 26d | 2000-01-03 A | 2000-02-07 A |  | 100% |  | 2000-01-03 | 2000-02-07 | 26d |  |  | S4 | 208h | 208h |  | Cod |  |  |  | 1459 |  |  |  |
| 689 | 86.1.2.2 | General Description |  | 51d | 2000-02-07 A | 2000-04-17 A | 688 | 100% |  | 2000-02-07 | 2000-04-17 | 51d |  | start no earlier than 2000-09-25 | S4 | 408h | 408h |  | Cod |  |  |  | 1460 |  |  |  |
| 690 | 86.1.3 | Feasibility Study |  | 26d | 2000-04-28 A | 2000-06-02 A | 689 | 100% |  | 2000-04-28 | 2000-06-02 | 26d |  | finish no earlier than 2000-06-02 | S4 | 208h | 208h |  | Cod |  | TSG |  | 1626 | TR 26.901 |  |  |
| 691 | 86.1.4 | N1 Aspects |  | 66d | 2001-09-21 A | 2001-12-21 A |  | 100% |  | 2001-09-21 | 2001-12-21 | 66d |  | finish no earlier than 2001-12-21 | N1 | 528h | 528h |  |  |  | TSG |  | 1656 |  |  |  |
| 692 | 86.1.5 | N4 work |  | 83d | 2002-02-13 A | 2002-06-07 A |  | 100% |  | 2002-02-13 | 2002-06-07 | 83d |  | finish no earlier than 2002-06-07 | N4 | 664h | 664h |  |  |  | TSG |  | 1656 |  |  |  |
| 693 | 86.1.6 | **Codec issues** |  | 704d | 2000-01-03 A | 2002-09-12 |  | 99% | 0.54d | 2000-01-03 | 2002-09-12 | 704d | 579d |  | S4 | 11504h | 11496h |  |  |  |  |  |  |  |  |  |
| 694 | 86.1.6.1 | Codec qualification |  | 86d | 2000-02-01 A | 2000-05-30 A |  | 100% |  | 2000-02-01 | 2000-05-30 | 86d |  | finish no earlier than 2000-05-31 | S4 | 688h | 688h |  | Cod |  | TSG |  | 1627 |  |  |  |
| 695 | 86.1.6.2 | Codec selection tests |  | 102d | 2000-06-01 A | 2000-10-20 A | 694 | 100% |  | 2000-06-01 | 2000-10-20 | 102d |  | finish no earlier than 2000-10-20 | S4 | 816h | 816h |  | Cod |  |  |  | 74 |  |  |  |
| 696 | 86.1.6.3 | Codec selection |  | 5d | 2000-10-23 A | 2000-10-27 A | 695 | 100% |  | 2000-10-23 | 2000-10-27 | 5d |  | finish no earlier than 2000-10-27 | S4 | 40h | 40h |  | Cod |  |  |  | 891 |  |  |  |
| 697 | 86.1.6.4 | TFO AMR-WB |  | 63d | 2001-12-18 A | 2002-03-14 A |  | 100% |  | 2001-12-18 | 2002-03-14 | 63d |  | finish no earlier than 2002-03-14 | S4 | 504h | 504h | AMRWB-TFO |  |  |  |  |  |  |  |  |
| 698 | 86.1.6.5 | Other codec issues (verif., caracterisation) |  | 441d | 2000-09-29 A | 2002-06-07 A |  | 100% |  | 2000-09-29 | 2002-06-07 | 441d |  | finish no earlier than 2002-06-07 | S4 | 3528h | 3528h |  | Cod |  |  |  | 890 | TR 26.976 |  |  |
| 699 | 86.1.6.6 | AMR-WB and narrrowband interworking |  | 121d | 2001-09-27 A | 2002-03-14 A |  | 100% |  | 2001-09-27 | 2002-03-14 | 121d |  | finish no earlier than 2002-03-14 | S4 | 968h | 968h | AMRWB-IWG |  |  |  |  |  |  |  |  |
| 700 | 86.1.6.7 | Interworking with fixed broadband networks |  | 121d | 2001-09-27 A | 2002-03-14 A |  | 100% |  | 2001-09-27 | 2002-03-14 | 121d |  | finish no earlier than 2002-03-14 | S4 | 968h | 968h |  |  |  |  |  |  |  |  |  |
| 701 | 86.1.6.8 | Tones and announcements |  | 121d | 2001-09-27 A | 2002-03-14 A |  | 100% |  | 2001-09-27 | 2002-03-14 | 121d |  | finish no earlier than 2002-03-14 | S4 | 968h | 968h |  |  |  |  |  |  |  |  |  |
| 702 | 86.1.6.9 | WB Conferencing and WB Voice Group calls |  | 1d | 2000-01-03 | 2000-01-03 |  |  |  | 2000-01-03 | 2000-01-03 | 1d | 1282d | finish no earlier than 2000-01-03 | S1 | 8h |  |  |  |  |  |  |  |  |  |  |
| 703 | 86.1.6.10 | Billing, accounting and call detail record aspects |  | 251d | 2001-09-27 A | 2002-09-12 A |  | 100% |  | 2001-09-27 | 2002-09-12 | 251d |  | finish no earlier than 2002-09-12 | S5 | 2008h | 2008h |  |  | Rel-5 |  |  |  | 32.2xy | Karl-Heinz NENNER (T-Mobile) | Karl-Heinz.Nenner@T-MOBILE.DE |
| 704 | 86.1.7 | Start Testing | milestone | 0d | 2002-02-25 | 2002-02-25 |  |  |  | 2002-02-25 | 2002-02-25 | 0d | 723d | start no earlier than 2002-02-25 | MLST |  |  |  |  |  |  |  | 1989 |  |  |  |
| 705 | 86.1.8 | **Conformance tests (CRs to 34 series)** |  | 73d | 2000-01-01 A | 2000-04-12 A | 704 | 100% |  | 2000-01-01 | 2000-04-12 | 73d |  |  | T1 | 1752h | 1752h |  | Cod |  |  |  | 1855 |  |  |  |
| 706 | 86.1.8.1 | **Terminal Acoustic Characteristics** |  | 73d | 2000-01-01 A | 2000-04-12 A |  | 100% |  | 2000-01-01 | 2000-04-12 | 73d |  |  | S4 | 1168h | 1168h |  | Cod |  |  |  | 76 |  |  |  |
| 707 | 86.1.8.1.1 | Definition |  | 21d | 2000-01-01 A | 2000-01-31 A |  | 100% |  | 2000-01-01 | 2000-01-31 | 21d |  | finish no earlier than 2000-01-28 | S4 | 168h | 168h |  | Cod |  | TSG |  | 1628 | 26.131 |  |  |
| 708 | 86.1.8.1.2 | Test specification |  | 52d | 2000-02-01 A | 2000-04-12 A | 707 | 100% |  | 2000-02-01 | 2000-04-12 | 52d |  | finish no earlier than 2000-03-13 | S4 | 416h | 416h |  | Cod |  | TSG |  | 1629 | 26.132 |  |  |
| 709 | 86.2 | Floating-point ANSI-C code for the AMR-WB speech codec |  | 123d | 2001-09-25 A | 2002-03-14 A |  | 100% |  | 2001-09-25 | 2002-03-14 | 123d |  | finish no earlier than 2002-03-14 | S4 | 984h | 984h | AMRWB-FP |  |  | TSG |  |  | TS 26.204 | J. Vainio (Nokia) | janne.m.vainio@nokia.com |

Notes:
- 690: S4,TD SP-000024: TR 26.901 v.4.0.0
- 691: Some of N1 tasks: Indication of supported codecs by the MS, Bearer cap negociation, codec indication to MS... / One common set of codec negotiation procedures will be specified as in ID1657.
- 692: CN4#11 30/11/01: No inputs to CN4 at this meeting / 14/02/02 work started 50% reached / 17 May work is done 100%
- 698: ANSI C-Code , Test Sequences, Speech Transcoding Functions, Error Concealment of lost frames, Source Controlled Bit-Rate Operation, Voice Activity Detector, Frame Structure

| ID | WBS | Task | Duration | Start | Finish | Complete | Remaining | Baseline start | Baseline finish | Baseline duration | Total slack | Constraint | Resources | Work | Actual work | Text1 | Text2 | Text7 | Text8 | Text9 | Text6 | Text3 | Text4 | Text5 |
| --- | --- | --- | --- | --- | --- | --- | --- | --- | --- | --- | --- | --- | --- | --- | --- | --- | --- | --- | --- | --- | --- | --- | --- | --- |
| 710 | 86.3 | **Support of AMR-WB in GERAN: GMSK and 8PSK WB FR / HR** | 650d | 2000-01-03 A | 2002-06-28 A | 100% |  | 2000-01-03 | 2002-06-28 | 650d |  |  | GP | 23480h | 23480h | GAMRWB | Cod | TSG | Paolo | 80 |  |  |  |  |
| 711 | 86.3.1 | Channel coding in 45.003 | 590d | 2000-01-03 A | 2002-04-05 A | 100% |  | 2000-01-03 | 2002-04-05 | 590d |  |  | GP | 4720h | 4720h |  |  | TSG |  | 2265 |  |  |  |  |
| 712 | 86.3.2 | Signalling for the A interface | 390d | 2000-01-03 A | 2001-06-29 A | 100% |  | 2000-01-03 | 2001-06-29 | 390d |  | finish no earlier than 2001-06-29 | GP | 3120h | 3120h |  |  | TSG |  | 2266 |  |  |  |  |
| 713 | 86.3.3 | Signalling for Iu | 650d | 2000-01-03 A | 2002-06-28 A | 100% |  | 2000-01-03 | 2002-06-28 | 650d |  | finish no earlier than 2002-06-28 | GP | 5200h | 5200h |  |  | TSG |  | 2267 |  |  |  |  |
| 714 | 86.3.4 | Receiver performance in TS 45.005 | 325d | 2001-04-02 A | 2002-06-28 A | 100% |  | 2001-04-02 | 2002-06-28 | 325d |  | finish no earlier than 2002-06-28 | GP | 2600h | 2600h |  |  | TSG |  | 2268 |  |  |  |  |
| 715 | 86.3.5 | Link Adaptation in 45.009 | 330d | 2001-03-26 A | 2002-06-28 A | 100% |  | 2001-03-26 | 2002-06-28 | 330d |  | finish no earlier than 2002-06-28 | GP | 2640h | 2640h |  |  |  |  |  |  |  |  |  |
| 716 | 86.4 | **GERAN MS conformance test for AMR-WB** | 1035d | 2000-01-03 | 2003-12-19 |  |  | 2000-01-03 | 2003-12-19 | 1035d | 248d |  | GP | 16560h |  |  |  | TSG | Paolo | 2269 |  |  |  |  |
| 717 | 86.4.1 | MS test | 1035d | 2000-01-03 | 2003-12-19 |  |  | 2000-01-03 | 2003-12-19 | 1035d | 248d | finish no earlier than 2003-12-19 | GP | 8280h |  |  |  | TSG |  | 2270 |  |  |  |  |
| 718 | 86.5 | **GERAN BTS conformance test for AMR-WB** | 761d | 2000-01-03 A | 2002-12-02 A | 100% |  | 2000-01-03 | 2002-12-02 | 761d |  |  | GP | 12176h | 12176h |  |  | TSG | Paolo | 2271 |  |  |  |  |
| 719 | 86.5.1 | BTS test | 761d | 2000-01-03 A | 2002-12-02 A | 100% |  | 2000-01-03 | 2002-12-02 | 761d |  | finish no earlier than 2002-12-02 | GP | 6088h | 6088h |  |  | TSG |  | 2272 |  |  |  |  |
| 720 | 11 | Terminal interfaces | 223d | 2001-05-14 A | 2002-03-20 A | 100% |  | 2001-05-14 | 2002-03-20 | 223d |  |  | T2 | 1784h | 1784h | TI | Ter |  | Friedhelm | 1826 | NA |  |  |  |
| 721 | 87 | Terminal local model enhancements | 223d | 2001-05-14 A | 2002-03-20 A | 100% |  | 2001-05-14 | 2002-03-20 | 223d |  | finish no earlier than 2002-03-20 | T2 | 1784h | 1784h | TLM5 | Ter | TSG |  | 1832 | Rel-5 | 23.227 | Olga Tomé, Ericsson | Olga.Tome@ECS.ERICSSON.SE |
| 722 | 88 | **Rel-5 Location Services enhancements** | 845d | 2000-04-03 A | 2003-06-27 | 80% | 167.61d | 2000-04-03 | 2003-06-27 | 845d | 373d |  | S2 | 175255h | 147009h | LCS1 |  | TSG | Alain |  | Rel-5 |  | Jan Kall, Nokia |  |
| 723 | 88.1 | **UE positioning** | 315d | 2001-01-15 A | 2002-03-29 | 99% | 0d | 2001-01-15 | 2002-03-29 | 315d | 0d |  | RP | 5560h | 5368.13h | LCS1-UEpos |  | TSG |  | 1600 | NA |  |  |  |
| 724 | 88.1.1 | UE positioning enhancements for 1.28 Mcps TDD | 255d | 2001-04-09 A | 2002-03-29 A | 100% |  | 2001-04-09 | 2002-03-29 | 255d |  | finish no earlier than 2002-03-29 | R2 | 2040h | 2040h | LCS-128Pos |  | TSG |  | 2474 | Rel-5 |  | Xiaohua Mei, CATT |  |
| 725 | 88.1.2 | Open SMLC-SRNC Interface within the UTRAN to support A-GPS Positioning | 195d | 2001-01-15 A | 2001-10-12 A | 100% |  | 2001-01-15 | 2001-10-12 | 195d |  |  | R2 | 1560h | 1560h | LCS-INTF |  | TSG |  | 2125 | Rel-5 |  | Kirk Burroughs, Qualcomm |  |
| 726 | 88.2 | **Event based and Periodic LCS** | 535d | 2000-05-22 A | 2002-06-07 | 88% | 62.67d | 2000-05-22 | 2002-06-07 | 535d | 648d |  | S1 | 6288h | 5551.48h | LCS1-EBP | Loc |  |  | 1171 | Rel-5 |  |  |  |
| 727 | 88.2.1 | Stage 1 | 130d | 2000-05-22 A | 2000-11-17 A | 100% |  | 2000-05-22 | 2000-11-17 | 130d |  | finish no earlier than 2000-07-21 | S1 | 1040h | 1040h |  | Loc |  |  | 1641 |  | 22.071 | Randolph Wohlert, Pacific Bell Wireless | rwohlert@tri.sbc.com |
| 728 | 88.2.2 | Stage 2 specification | 60d | 2000-11-06 A | 2001-01-26 | 51% | 29.4d | 2000-11-06 | 2001-01-26 | 60d | 1003d | finish no earlier than 2001-01-26 | S2 | 480h | 244.8h |  | Loc |  |  | 1538 |  |  |  |  |
| 729 | 88.2.3 | Impact on MAP | 61d | 2002-03-15 A | 2002-06-07 A | 100% |  | 2002-03-15 | 2002-06-07 | 61d |  | finish no earlier than 2002-06-07 | N4 | 488h | 488h |  | Loc |  |  | 1179 |  |  |  |  |
| 730 | 88.3 | **Location Services for GERAN in A/Gb Mode** | 485d | 2000-04-03 A | 2002-02-08 A | 100% |  | 2000-04-03 | 2002-02-08 | 485d |  |  | GP | 24032h | 24032h | LCS-GERAN |  | TSG | Paolo | 2436 | Rel-5 |  |  |  |
| 731 | 88.3.1 | GERAN LCS Stage 2 (first release) | 485d | 2000-04-03 A | 2002-02-08 A | 100% |  | 2000-04-03 | 2002-02-08 | 485d |  | finish no earlier than 2002-02-08 | GP; S2; G1; G2 | 13152h | 13152h |  |  | TSG |  | 2437 |  |  |  |  |
| 732 | 88.3.2 | Gb interface support for LCS | 370d | 2000-04-03 A | 2001-08-31 A | 100% |  | 2000-04-03 | 2001-08-31 | 370d |  | finish no earlier than 2001-08-31 | GP | 2960h | 2960h |  |  | TSG |  | 2438 |  |  |  |  |
| 733 | 88.3.3 | L3 protocol support for LCS | 305d | 2000-04-03 A | 2001-06-01 A | 100% |  | 2000-04-03 | 2001-06-01 | 305d |  | finish no earlier than 2001-06-01 | GP | 2440h | 2440h |  |  | TSG |  | 2440 |  |  |  |  |
| 734 | 88.3.4 | Stage 3 specifications | 305d | 2000-04-03 A | 2001-06-01 A | 100% |  | 2000-04-03 | 2001-06-01 | 305d |  | finish no earlier than 2001-06-01 | GP | 2440h | 2440h |  |  | TSG |  | 2441 |  |  |  |  |

Notes:
- 716: Not started
- 725: Finished at RAN#13
- 727: Evaluate Event based and Periodic LCS to be included in R00, corresponding Stage 1 description
- 729: Possible impact on UTRAN of LCS quality level request / 17 May No stage 2 for event-based & periodic LCS. Work 100% completefor current stage 2

| ID | WBS | Task | Duration | Start | Finish | Complete | Remaining | Baseline start | Baseline finish | Baseline duration | Total slack | Constraint | Resources | Work | Actual work | Text6 | Text7 | Text8 | Text9 | Text1 | Text2 | Text3 | Text5 |
| --- | --- | --- | --- | --- | --- | --- | --- | --- | --- | --- | --- | --- | --- | --- | --- | --- | --- | --- | --- | --- | --- | --- | --- |
| 735 | 88.4 | **Location Services for GERAN in Iu Mode** | 585d | 2000-04-03 A | 2002-06-28 A | 100% |  | 2000-04-03 | 2002-06-28 | 585d |  |  | GP | 78498.6h | 78498.6h | Rel-5 | TSG | Paolo |  |  |  |  |  |
| 736 | 88.4.1 | GERAN LCS Stage 2 | 585d | 2000-04-03 A | 2002-06-28 A | 100% |  | 2000-04-03 | 2002-06-28 | 585d |  | finish no earlier than 2002-06-28 | GP; R2; R3; S2; G1; G2 | 22880.9h | 22880.9h |  | TSG |  | 2443 |  |  |  |  |
| 737 | 88.4.2 | Iu-ps interface support for LCS | 585d | 2000-04-03 A | 2002-06-28 A | 100% |  | 2000-04-03 | 2002-06-28 | 585d |  | finish no earlier than 2002-06-28 | GP; R2; R3; S2; G1; G2 | 19000.9h | 19000.9h |  | TSG |  |  |  |  |  |  |
| 738 | 88.4.3 | Iu-cs interface support for LCS | 585d | 2000-04-03 A | 2002-06-28 A | 100% |  | 2000-04-03 | 2002-06-28 | 585d |  | finish no earlier than 2002-06-28 | GP; R2; R3; S2; G1; G2 | 19000.9h | 19000.9h |  | TSG |  | 2445 |  |  |  |  |
| 739 | 88.4.4 | Iur-g interface support for LCS | 62.5d | 2002-01-23 A | 2002-04-19 A | 100% |  | 2002-01-23 | 2002-04-19 | 62.5d |  | finish no earlier than 2002-04-19 | GP; R2; R3; S2; G1; G2 | 3000h | 3000h |  | TSG |  | 2446 |  |  |  |  |
| 740 | 88.4.5 | RRC protocol support for LCS | 75d | 2001-08-20 A | 2001-11-30 A | 100% |  | 2001-08-20 | 2001-11-30 | 75d |  | finish no earlier than 2001-11-30 | GP; R2; R3; S2; G1; G2 | 3600h | 3600h |  | TSG |  | 2447 |  |  |  |  |
| 741 | 88.4.6 | Additional impacts on Broadcast of LCS data on packet channels | 77.5d | 2001-08-20 A | 2001-12-05 A | 100% |  | 2001-08-20 | 2001-12-05 | 77.5d |  | finish no earlier than 2001-12-05 | GP; R2; R3; S2; G1; G2 | 3000h | 3000h |  | TSG |  | 2448 |  |  |  |  |
| 742 | 88.4.7 | Stage 3 specifications | 69.5d | 2002-03-25 A | 2002-06-28 A | 100% |  | 2002-03-25 | 2002-06-28 | 69.5d |  | finish no earlier than 2002-06-28 | GP; R2; R3; S2; G1; G2 | 3336h | 3336h |  | TSG |  | 2449 |  |  |  |  |
| 743 | 88.5 | **GERAN MS Conformance test for LCS** | 280d | 2002-06-03 A | 2003-06-27 | 60% | 112d | 2002-06-03 | 2003-06-27 | 280d | 373d |  | GP | 11200h | 6720h |  |  |  |  | LCS-GERAN-MSconf |  |  |  |
| 744 | 88.5.1 | Develop LCS MS test case work plan (Release 98/99/4) | 280d | 2002-06-03 A | 2003-06-27 | 60% | 112d | 2002-06-03 | 2003-06-27 | 280d | 373d | finish no earlier than 2003-06-27 | G4; G5 | 4480h | 2688h |  |  |  |  |  |  |  |  |
| 745 | 88.5.2 | Develop LCS MS test cases | 280d | 2002-06-03 A | 2003-06-27 | 60% | 112d | 2002-06-03 | 2003-06-27 | 280d | 373d | finish no earlier than 2003-06-27 | G4; G5 | 4480h | 2688h |  |  |  |  |  |  |  |  |
| 746 | 88.6 | **GERAN BTS Conformance test for LCS** | 280d | 2002-06-03 | 2003-06-27 |  |  | 2002-06-03 | 2003-06-27 | 280d | 373d |  | GP | 11200h |  |  |  |  |  | LCS-GERAN-BTSconf |  |  |  |
| 747 | 88.6.1 | Develop LCS BTS test case work plan (Release 98/99/4) | 280d | 2002-06-03 | 2003-06-27 |  |  | 2002-06-03 | 2003-06-27 | 280d | 373d | finish no earlier than 2003-06-27 | G4; G5 | 4480h |  |  |  |  |  |  |  |  |  |
| 748 | 88.6.2 | Develop LCS BTS test cases | 280d | 2002-06-03 | 2003-06-27 |  |  | 2002-06-03 | 2003-06-27 | 280d | 373d | finish no earlier than 2003-06-27 | G4; G5 | 4480h |  |  |  |  |  |  |  |  |  |
| 749 | 88.7 | LCS interoperation stage 2 aspects | 480d | 2000-08-28 A | 2002-06-28 | 17% | 400.8d | 2000-08-28 | 2002-06-28 | 480d | 633d |  | S2 | 3840h | 633.6h |  |  |  | 544 |  | Loc |  |  |
| 750 | 88.8 | **LCS interoperability aspects to GERAN** | 480d | 2000-08-28 A | 2002-06-28 A | 100% |  | 2000-08-28 | 2002-06-28 | 480d |  |  | GP | 19632h | 19632h | Rel-5 | TSG | Paolo | 2434 | LCS-GERAN |  |  |  |
| 751 | 88.8.1 | Co-ordinated development of GSM LCS Phase 2 and UMTS LCS, S2 and GERAN | 480d | 2000-08-28 A | 2002-06-28 A | 100% |  | 2000-08-28 | 2002-06-28 | 480d |  | finish no earlier than 2002-06-28 | GP; S2; S5; R2; R3; G2; G1 | 15792h | 15792h |  | TSG |  | 2435 | LCS-GERAN |  |  |  |
| 752 | 88.9 | FS on LCS support in the IMS | 90d | 2001-02-12 A | 2002-01-18 | 28% | 65d | 2001-02-12 | 2002-01-18 | 90d | 748d | start no earlier than 2001-02-12 | S1 | 720h | 200h |  |  |  | 1183 |  | Loc |  |  |
| 753 | 88.10 | Charging and OAM&P for LCS enhancements | 201d | 2001-09-21 A | 2002-06-28 A | 100% |  | 2001-09-21 | 2002-06-28 | 201d |  | finish no earlier than 2002-06-28 | S5 | 1608h | 1608h | Rel-5 | TSG |  | 519 | LCS1-OAM |  | 32-series | Albert.Yuhan@voicestream.com; Michael.Truss@MOTOROLA.COM |
| 754 | 88.11 | New security aspects of LCS (not identified) | 446d | 2000-04-14 A | 2001-12-28 A | 100% |  | 2000-04-14 | 2001-12-28 | 446d |  | finish no earlier than 2001-12-28 | S3 | 3568h | 3568h | Rel-5 |  |  | 521 | LCS1-SEC | Loc |  | valtteri.niemi@nokia.com |
| 755 | 88.12 | Specification for the Le Interface | 45d | 2002-01-14 A | 2002-03-15 A | 100% |  | 2002-01-14 | 2002-03-15 | 45d |  | start no earlier than 2002-01-14 | S2 | 360h | 360h | Rel-5 | TSG |  |  | LCS1-Le |  |  |  |
| 756 | 88.13 | CHECK STATUS - Inter-GMLC interface | 153d | 2002-05-30 | 2002-12-30 |  |  | 2002-05-30 | 2002-12-30 | 153d | 502d | finish no earlier than 2002-12-30 | S2 | 1224h |  |  |  |  |  |  |  |  |  |
| 757 | 89 | **Rel-5 Security enhancements** | 615d | 2000-02-21 A | 2002-06-28 | 99% | 4.24d | 2000-02-21 | 2002-06-28 | 615d | 633d |  | S3 | 29974.9h | 28337.4h | NA | TSG | Maurice |  | SEC1 |  |  | Peter.Howard@vodafone.com |
| 758 | 89.1 | **Network domain security** | 615d | 2000-02-21 A | 2002-06-28 | 99% | 4.24d | 2000-02-21 | 2002-06-28 | 615d | 633d |  | S3 | 25054.9h | 23451.3h | Rel-5 | TSG |  | 1576 | SEC1-NDS | Sec |  | Geir-myrdahl.koien@telenor.com |
| 759 | 89.1.1 | **Control plane protection in core network (e.g., GTP, CAP, MAP/IP, provided by IPsec)** | 541d | 2000-05-12 A | 2002-06-07 | 99% | 0d | 2000-05-12 | 2002-06-07 | 541d | 0d |  | S3 | 7118.9h | 5722.99h |  |  |  | 1577 |  | Sec |  |  |
| 760 | 89.1.1.1 | Main aspects | 290d | 2000-05-12 A | 2001-06-21 A | 100% |  | 2000-05-12 | 2001-06-21 | 290d |  | finish no earlier than 2001-06-21 | S3 | 2320h | 2320h |  |  |  | 1578 |  | Sec |  |  |
| 761 | 89.1.1.2 | Integration of GTP signalling security architecture | 191d | 2001-09-14 A | 2002-06-07 A | 100% |  | 2001-09-14 | 2002-06-07 | 191d |  | finish no earlier than 2002-06-07 | N4 | 1528h | 1528h |  |  |  | 1579 |  | Sec |  |  |

Notes:
- 739: FFS
- 743: On-going
- 746: Not started
- 753: Text4: Albert YUHAN (VoiceStream Wireless), Michael TRUSS (Motorola)
- 754: 14/09/00: End date 28/12/01 WI may need to be split to improve on this date. S3#17 15% complete. No progress since S3#17 / Text4: Valtteri Niemi, Nokia
- 757: Added BB UE authentication and rapporteur added. TO BE DELETED / Text4: Peter Howard, Vodafone
- 758: S3#17: All due in Rel5. (WI Update at S3#18). Replaced by NDS-IP and NDS-MAP. TO BE DELETED OR MOVED TO HISTORY FILE / Text4: Geir M. Køien, Telenor
- 760: TO BE DELETED
- 761: Waiting for input from SA3! / 14/02/2002 requirements are not clear/not received / 17 May 100% complete

| ID | WBS | Task | Duration | Start | Finish | Predecessors | Complete | Remaining | Baseline start | Baseline finish | Baseline duration | Total slack | Constraint | Resources | Work | Actual work | Text2 | Text9 | Text1 | Text3 | Text5 | Text7 | Text6 | Text8 |
| --- | --- | --- | --- | --- | --- | --- | --- | --- | --- | --- | --- | --- | --- | --- | --- | --- | --- | --- | --- | --- | --- | --- | --- | --- |
| 762 | 89.1.2 | **User plane protection in core network (e.g., provided by IPsec)** | 615d | 2000-02-21 A | 2002-06-28 |  | 98% | 11.41d | 2000-02-21 | 2002-06-28 | 615d | 633d |  | S3 | 9360h | 9186.29h | Sec | 1580 |  |  |  |  |  |  |
| 763 | 89.1.2.1 | Main aspects | 349d | 2000-02-21 A | 2001-06-21 A |  | 100% |  | 2000-02-21 | 2001-06-21 | 349d |  | finish no earlier than 2001-06-21 | S3 | 2792h | 2792h | Sec | 1581 |  |  |  |  |  |  |
| 764 | 89.1.2.2 | Integration of GTP signalling security architecture | 206d | 2001-09-14 A | 2002-06-28 |  | 95% | 10.3d | 2001-09-14 | 2002-06-28 | 206d | 633d | finish no earlier than 2002-06-28 | N4 | 1648h | 1565.6h | Sec | 1582 |  |  |  |  |  |  |
| 765 | 89.1.3 | IP network layer security (NDS/IP) | 457d | 2000-06-15 A | 2002-03-15 A |  | 100% |  | 2000-06-15 | 2002-03-15 | 457d |  | finish no earlier than 2002-03-15 | S3 | 3656h | 3656h |  |  | SEC1-NDS-IP | TS 33.210 | Geir-myrdahl.koien@telenor.com | WG |  |  |
| 766 | 90 | **Intra Domain Connection of RAN Nodes to Multiple CN Nodes** | 455d | 2000-10-02 A | 2002-06-28 A |  | 100% |  | 2000-10-02 | 2002-06-28 | 455d |  |  | S2 | 15136h | 15136h |  |  | IUFLEX | 23.236 |  | TSG | Rel-5 | Alain |
| 767 | 90.1 | Overall System Architecture | 188d | 2001-01-03 A | 2001-09-21 A |  | 100% |  | 2001-01-03 | 2001-09-21 | 188d |  | finish no earlier than 2001-06-01 | S2 | 1504h | 1504h |  | 2244 |  |  |  | TSG |  |  |
| 768 | 90.2 | Stage 3: RAN node selecting CN node | 130d | 2001-09-24 A | 2002-03-22 A | 767 | 100% |  | 2001-09-24 | 2002-03-22 | 130d |  | finish no earlier than 2002-03-22 | R3 | 1040h | 1040h |  |  |  |  |  | TSG |  |  |
| 769 | 90.3 | N1 work | 205d | 2001-09-17 A | 2002-06-28 A |  | 100% |  | 2001-09-17 | 2002-06-28 | 205d |  | start no earlier than 2001-09-17 | N1 | 1640h | 1640h |  |  |  | 24.008 and check 29.018 |  | TSG |  |  |
| 770 | 90.4 | N4 work | 375d | 2000-10-02 A | 2002-03-08 A |  | 100% |  | 2000-10-02 | 2002-03-08 | 375d |  | finish no earlier than 2002-03-15 | N4 | 3000h | 3000h |  | 2249 |  |  |  | TSG |  |  |
| 771 | 90.5 | **GERAN work for Intra Domain Connection of RAN Nodes to Multiple CN Nodes** | 101d | 2002-02-08 A | 2002-06-28 A |  | 100% |  | 2002-02-08 | 2002-06-28 | 101d |  |  | GP | 4848h | 4848h |  |  | IDCRAN-GERAN |  | ingemar.backlund@era.ericsson.se |  | Rel-5 |  |
| 772 | 90.5.1 | Stage 2 (changes to ) | 101d | 2002-02-08 A | 2002-06-28 A |  | 100% |  | 2002-02-08 | 2002-06-28 | 101d |  | finish no earlier than 2002-06-28 | G1 | 808h | 808h |  |  |  |  |  |  |  |  |
| 773 | 90.5.2 | 43.051 Introduction of support for IDNNS in GERAN Iu mode | 101d | 2002-02-08 A | 2002-06-28 A |  | 100% |  | 2002-02-08 | 2002-06-28 | 101d |  | finish no earlier than 2002-06-28 | G1 | 808h | 808h |  |  |  |  |  |  |  |  |
| 774 | 90.5.3 | Stage 3 (changes to ) | 101d | 2002-02-08 A | 2002-06-28 A |  | 100% |  | 2002-02-08 | 2002-06-28 | 101d |  | finish no earlier than 2002-06-28 | G2 | 808h | 808h |  |  |  |  |  |  |  |  |
| 775 | 90.5.4 | 48.016 Use of Gb interface concepts when a network applies IDNNS | 101d | 2002-02-08 A | 2002-06-28 A |  | 100% |  | 2002-02-08 | 2002-06-28 | 101d |  | finish no earlier than 2002-06-28 | G2 | 808h | 808h |  |  |  |  |  |  |  |  |
| 776 | 90.5.5 | 48.018 Include MSC/VLR identity in CS IMSI paging | 101d | 2002-02-08 A | 2002-06-28 A |  | 100% |  | 2002-02-08 | 2002-06-28 | 101d |  | finish no earlier than 2002-06-28 | G2 | 808h | 808h |  |  |  |  |  |  |  |  |
| 777 | 91 | **GERAN improvements 3 (new transport layer on interface A)** | 446d | 2001-04-06 | 2002-12-20 |  |  |  | 2001-04-06 | 2002-12-20 | 446d | 508d |  | GP | 14272h |  |  | 2320 | GEIMP3 |  |  | TSG | Rel-5 | Paolo |
| 778 | 91.1 | **Evolution of the transport for A** | 446d | 2001-04-06 | 2002-12-20 |  |  |  | 2001-04-06 | 2002-12-20 | 446d | 508d |  | GP | 10704h |  |  | 2321 | GEIMP3-EtA |  |  | TSG |  | Paolo |
| 779 | 91.1.1 | Definition of a new A/Ater interface Transport Layer option based on the Iu Interface Transport Layer | 446d | 2001-04-06 | 2002-12-20 |  |  |  | 2001-04-06 | 2002-12-20 | 446d | 508d | finish no earlier than 2002-12-20 | GP | 3568h |  |  | 2322 |  |  |  | TSG |  |  |
| 780 | 91.1.2 | Adaptation of the Layer 3 BSSMAP procedures as required | 446d | 2001-04-06 | 2002-12-20 |  |  |  | 2001-04-06 | 2002-12-20 | 446d | 508d | finish no earlier than 2002-12-20 | GP | 3568h |  |  | 2323 |  |  |  | TSG |  |  |
| 781 | 92 | **Rel-5 Charging and OAM&P** | 264d | 2001-09-10 A | 2002-09-12 A |  | 100% |  | 2001-09-10 | 2002-09-12 | 264d |  |  | S5 | 9976h | 9976h |  |  | OAM | 32-series | Albert.Yuhan@voicestream.com; Michael.Truss@MOTOROLA.COM | TSG | NA | Adrian |
| 782 | 92.1 | Rel5 Principles, high level Requirements and Architecture | 205d | 2001-09-17 A | 2002-06-28 A |  | 100% |  | 2001-09-17 | 2002-06-28 | 205d |  | finish no earlier than 2002-06-28 | S5 | 1640h | 1640h | BCaM | 2089 | OAM-AR/PR | 32.101, 32.102 | Michael.Truss@MOTOROLA.COM | TSG | Rel-5 |  |
| 783 | 92.2 | Rel5 Performance Management | 259d | 2001-09-17 A | 2002-09-12 A |  | 100% |  | 2001-09-17 | 2002-09-12 | 259d |  | finish no earlier than 2002-09-12 | S5 | 2072h | 2072h | BCaM | 2088 | OAM-PM | 32.4xy, 52.402 | toche@NORTELNETWORKS.COM | TSG | Rel-5 |  |
| 784 | 92.3 | Rel5 Charging Management | 264d | 2001-09-10 A | 2002-09-12 A |  | 100% |  | 2001-09-10 | 2002-09-12 | 264d |  | finish no earlier than 2002-09-12 | S5 | 2112h | 2112h |  | 2083 | OAM-CH | 32.2xy | Karl-Heinz.Nenner@T-MOBILE.DE | TSG | Rel-5 |  |
| 785 | 92.4 | Rel5 Network Infrastructure Management | 255d | 2001-09-21 A | 2002-09-12 A |  | 100% |  | 2001-09-21 | 2002-09-12 | 255d |  | finish no earlier than 2002-09-12 | S5 | 2040h | 2040h |  |  | OAM-NIM | 32.6xy, 32.3xy | Thomas.Tovinger@emw.ericsson.se | TSG | Rel-5 |  |

Notes:
- 762: TO BE DELETED
- 763: ??
- 764: 14/02/2002 requirements are not clear/not received
- 765: TS 33.210 will be presented for info at SA#14 and is scheduled for approval at SA#15. 2002/12: All IPsec RFCs are stable STD Track RFCs. WID updated SA#17 / Text4: Geir M. Køien, Telenor
- 766: No clear indication on the end date. Put to Rel5 by AS. / Text4: Stephen Terrill, Ericsson
- 768: Not identified / Text4: Brendan McWilliams, Vodafone
- 770: DAB 12.12.01 - % complete to 66% / 14/02/02 Work completed
- 771: Accept changes Gb over IP / Text4: Ingemar Backlund, Ericsson
- 775: Closed, accept changes for Gb over IP
- 777: TERMINATED - NOT STANDARDIZED
- 778: TERMINATED - NOT STANDARDIZED
- 779: TERMINATED - NOT STANDARDIZED
- 780: TERMINATED - NOT STANDARDIZED
- 781: Text4: Albert YUHAN (VoiceStream Wireless), Michael TRUSS (Motorola)
- 782: Text4: Michael TRUSS (Motorola)
- 783: Text4: Christian TOCHE (Nortel Networks)
- 784: Text4: Karl-Heinz NENNER (T-Mobile)
- 785: Text4: Thomas TOVINGER (Ericsson)

| ID | WBS | Task | Duration | Start | Finish | Predecessors | Complete | Remaining | Baseline start | Baseline finish | Baseline duration | Total slack | Constraint | Resources | Work | Actual work | Text6 | Text8 | Text9 | Text1 | Text5 | Text7 | Text2 |
| --- | --- | --- | --- | --- | --- | --- | --- | --- | --- | --- | --- | --- | --- | --- | --- | --- | --- | --- | --- | --- | --- | --- | --- |
| 786 | 93 | **GERAN enhancements for streaming services 1 (RLC enhancements)** | 430d | 2000-11-06 A | 2002-06-28 A |  | 100% |  | 2000-11-06 | 2002-06-28 | 430d |  |  | GP | 8944h | 8944h | Rel-5 | Paolo | 2392 |  |  |  |  |
| 787 | 93.1 | Concept | 258d | 2000-11-06 A | 2001-10-31 A |  | 100% |  | 2000-11-06 | 2001-10-31 | 258d |  | finish no earlier than 2001-10-31 | GP | 2064h | 2064h |  |  | 2394 |  |  |  |  |
| 788 | 93.2 | RLC protocol enhancement (SDU Discard) | 430d | 2000-11-06 A | 2002-06-28 A |  | 100% |  | 2000-11-06 | 2002-06-28 | 430d |  | finish no earlier than 2002-06-28 | GP | 3440h | 3440h |  |  | 2395 |  |  |  |  |
| 789 | 94 | **GERAN enhancements for streaming services 2 (usage of ECSD)** | 430d | 2000-11-06 A | 2002-06-28 |  | 99% | 0d | 2000-11-06 | 2002-06-28 | 430d | 0d |  | GP | 19840h | 16400h | Rel-5 | Paolo | 2396 |  |  |  |  |
| 790 | 94.1 | Usage of ECSD Concept | 380d | 2000-11-06 A | 2002-04-19 A |  | 100% |  | 2000-11-06 | 2002-04-19 | 380d |  | finish no earlier than 2002-04-19 | GP | 3040h | 3040h |  |  | 2398 |  |  |  |  |
| 791 | 94.2 | Stage 2 | 380d | 2000-11-06 A | 2002-04-19 A |  | 100% |  | 2000-11-06 | 2002-04-19 | 380d |  | finish no earlier than 2002-04-19 | GP | 3040h | 3040h |  |  | 2399 |  |  |  |  |
| 792 | 94.3 | Stage 3 | 430d | 2000-11-06 A | 2002-06-28 A |  | 100% |  | 2000-11-06 | 2002-06-28 | 430d |  | finish no earlier than 2002-06-28 | GP | 3440h | 3440h |  |  | 2400 |  |  |  |  |
| 793 | 94.4 | RLC PDU formats | 430d | 2000-11-06 A | 2002-06-28 A |  | 100% |  | 2000-11-06 | 2002-06-28 | 430d |  | finish no earlier than 2002-06-28 | GP | 3440h | 3440h |  |  | 2401 |  |  |  |  |
| 794 | 94.5 | MAC header | 430d | 2000-11-06 A | 2002-06-28 A |  | 100% |  | 2000-11-06 | 2002-06-28 | 430d |  | finish no earlier than 2002-06-28 | GP | 3440h | 3440h |  |  | 2402 |  |  |  |  |
| 795 | 95 | **GERAN/UTRAN interface evolution 1 (evolution of Iu PS)** | 476d | 2000-09-01 A | 2002-06-28 A |  | 100% |  | 2000-09-01 | 2002-06-28 | 476d |  |  | GP; R3 | 17825.6h | 17825.6h | Rel-5 | Paolo | 2412 | GERUEV1 |  |  |  |
| 796 | 95.1 | **Evolution of Iu ps** | 476d | 2000-09-01 A | 2002-06-28 A |  | 100% |  | 2000-09-01 | 2002-06-28 | 476d |  |  | GP; R3 | 12205.6h | 12205.6h |  |  | 2413 | GERUEV1-IuPS |  |  |  |
| 797 | 95.1.1 | Identification of GERAN requirements on Iu ps | 326d | 2000-09-01 A | 2001-11-30 A |  | 100% |  | 2000-09-01 | 2001-11-30 | 326d |  | finish no earlier than 2001-11-30 | GP; R3 | 4185.6h | 4185.6h |  |  | 2414 |  |  |  |  |
| 798 | 95.1.2 | Update of specifications | 150d | 2001-12-03 A | 2002-06-28 A | 797 | 100% |  | 2001-12-03 | 2002-06-28 | 150d |  | finish no earlier than 2002-06-28 | GP; R3 | 2400h | 2400h |  |  | 2415 |  |  |  |  |
| 799 | 96 | **GERAN/UTRAN interface evolution 2 (evolution of Iu CS)** | 476d | 2000-09-01 A | 2002-06-28 A |  | 100% |  | 2000-09-01 | 2002-06-28 | 476d |  |  | GP; R3 | 23025.6h | 23025.6h | Rel-5 | Paolo | 2416 | GERUEV2 |  |  |  |
| 800 | 96.1 | **Evolution of Iu cs** | 476d | 2000-09-01 A | 2002-06-28 A |  | 100% |  | 2000-09-01 | 2002-06-28 | 476d |  |  | GP; R3 | 17845.6h | 17845.6h |  | Paolo | 2417 | GERUEV2-IuCS |  |  |  |
| 801 | 96.1.1 | Identification of GERAN requirements on Iu cs | 426d | 2000-09-01 A | 2002-04-19 A |  | 100% |  | 2000-09-01 | 2002-04-19 | 426d |  | finish no earlier than 2002-04-19 | GP; R3 | 5049.6h | 5049.6h |  |  | 2418 |  |  |  |  |
| 802 | 96.1.2 | Update of specifications | 476d | 2000-09-01 A | 2002-06-28 A |  | 100% |  | 2000-09-01 | 2002-06-28 | 476d |  | finish no earlier than 2002-06-28 | GP; R3 | 7616h | 7616h |  |  | 2419 |  |  |  |  |
| 803 | 97 | **End to End QoS for PS Domain including IMS** | 480d | 2000-08-28 A | 2002-06-28 |  | 97% | 13.22d | 2000-08-28 | 2002-06-28 | 480d | 633d |  | S2 | 9856h | 9584.49h | Rel-5 | Alain |  | E2EQoS | Johnson.oyama@era.ericcson.se | TSG |  |
| 804 | 97.1 | E2E QoSConcept and Architecture | 178d | 2001-01-03 A | 2001-09-07 A |  | 100% |  | 2001-01-03 | 2001-09-07 | 178d |  | finish no earlier than 2001-09-07 | S2 | 1424h | 1424h |  |  |  |  |  | TSG |  |
| 805 | 97.2 | E2E QoS interworking | 465d | 2000-08-28 A | 2002-06-07 |  | 95% | 23.25d | 2000-08-28 | 2002-06-07 | 465d | 648d | finish no earlier than 2002-06-07 | N3 | 3720h | 3534h |  |  |  | E2EQoS-IW | yokota@lucent.com | WG |  |
| 806 | 97.3 | QoS Management (Provisioning and Monitoring) | 201d | 2001-09-21 A | 2002-06-28 A |  | 100% |  | 2001-09-21 | 2002-06-28 | 201d |  | finish no earlier than 2002-06-28 | S5 | 1608h | 1608h | Rel-5 |  |  | E2EQoS-OAM | Albert.Yuhan@voicestream.com; Michael.Truss@MOTOROLA.COM | TSG |  |
| 807 | 98 | **Messaging enhancements Rel-5** | 256d | 2001-06-15 A | 2002-06-07 |  | 75% | 65.08d | 2001-06-15 | 2002-06-07 | 256d | 648d |  | T2 | 13936h | 7742.17h | Rel-5 | Friedhelm | 1818 | MESS5 |  | TSG | Mes |
| 808 | 98.1 | **Multimedia Messaging (MMS) enhancements** | 256d | 2001-06-15 A | 2002-06-07 |  | 73% | 69.18d | 2001-06-15 | 2002-06-07 | 256d | 648d |  | T2 | 8312h | 4579.2h |  |  | 1819 | MESS5-MMS | Josef.Laumen@SAL.SIEMENS.DE | TSG | Mes |
| 809 | 98.1.1 | Definition of service requirements | 196d | 2001-06-15 A | 2002-03-15 |  | 90% | 19.6d | 2001-06-15 | 2002-03-15 | 196d | 708d | finish no earlier than 2002-03-15 | S1 | 1568h | 1411.2h | Rel-5 |  |  | MESS5-SR | Josef.Laumen@SAL.SIEMENS.DE |  |  |
| 810 | 98.1.2 | Technical realization | 256d | 2001-06-15 A | 2002-06-07 |  | 95% | 12.8d | 2001-06-15 | 2002-06-07 | 256d | 648d | finish no earlier than 2002-06-07 | T2 | 2048h | 1945.6h |  |  |  |  | Josef.Laumen@SAL.SIEMENS.DE |  |  |
| 811 | 98.1.3 | WAP Forum dependency: MM1 stage 3 | 256d | 2001-06-15 A | 2002-06-07 |  | 30% | 179.2d | 2001-06-15 | 2002-06-07 | 256d | 648d | finish no earlier than 2002-06-07 | T2 | 2048h | 614.4h |  |  |  |  |  |  |  |
| 812 | 98.1.4 | MMS formats and codecs | 75d | 2001-12-03 A | 2002-03-15 A |  | 100% |  | 2001-12-03 | 2002-03-15 | 75d |  | finish no earlier than 2002-03-15 | S4 | 600h | 600h |  |  |  |  |  |  |  |

Notes:
- 789: AWS, Nokia, Ericsson, Nortel, Siemens, Motorola, Vodafone / Text4: Frank Muller, Ericsson
- 795: SBC, Motorola, Nokia, Ericsson, Nortel / Text4: Marc Grant , SBC
- 800: Lucent, Ericsson, AWS, Nortel / Text4: Krishna Balachandran, Lucent
- 803: Text4: Johnson Oyama, Ericsson
- 804: Text3: 23.207
- 805: [DAB - 30/07/02] - % complete to 95% (if we exclude Diffserv) / Text3: 29.208, 29.207, 27.060, 29.061, 24.008, 24.228, , 24.229, 29.060, 29.163 / Text4: Daisuke Yokota, Lucent
- 806: Text3: 32-series / Text4: Albert YUHAN (VoiceStream Wireless), Michael TRUSS (Motorola)
- 807: support of UAProf, so this in my opinion is 100% complete
- 808: Text4: Josef Laumen, Siemens
- 809: Text3: 22.140 / Text4: Josef Laumen, Siemens
- 810: stage 3 MM7 is missing / Text3: 23.140 / Text4: Josef Laumen, Siemens
- 812: Text3: 26.140

| ID | WBS | Task | Duration | Start | Finish | Complete | Remaining | Baseline start | Baseline finish | Baseline duration | Total slack | Constraint | Resources | Work | Actual work | Text1 | Text2 | Text3 | Text4 | Text5 | Text7 | Text9 | Text6 | Text8 |
| --- | --- | --- | --- | --- | --- | --- | --- | --- | --- | --- | --- | --- | --- | --- | --- | --- | --- | --- | --- | --- | --- | --- | --- | --- |
| 813 | 98.2 | **Enhanced Messaging Service (EMS) enhancements** | 191d | 2001-06-15 A | 2002-03-08 | 79% | 39.24d | 2001-06-15 | 2002-03-08 | 191d | 713d |  | T2 | 3584h | 1641.6h | MESS5-EMS | Mes | 23.040 | Alan Baldwin, Ericsson | Alan.Baldwin@EML.ERICSSON.SE | TSG | 1820 |  |  |
| 814 | 98.2.1 | Definition of service requirements | 66d | 2001-06-15 A | 2001-09-14 | 20% | 52.8d | 2001-06-15 | 2001-09-14 | 66d | 838d | finish no earlier than 2001-09-14 | S1 | 528h | 105.6h |  |  |  | Alan Baldwin, Ericsson | Alan.Baldwin@EML.ERICSSON.SE |  |  |  |  |
| 815 | 98.2.2 | Technical realization | 191d | 2001-06-15 A | 2002-03-08 A | 100% |  | 2001-06-15 | 2002-03-08 | 191d |  | finish no earlier than 2002-03-08 | T2 | 1528h | 1528h |  |  | 23.040 | Alan Baldwin, Ericsson | Alan.Baldwin@EML.ERICSSON.SE |  |  |  |  |
| 816 | 99 | **GERAN Inter BSC NACC improvements over the Gb Interface** | 215d | 2001-09-03 A | 2002-06-28 A | 100% |  | 2001-09-03 | 2002-06-28 | 215d |  |  | GP | 11184h | 11184h | GERNACC |  |  |  |  |  |  | Rel-5 | Paolo |
| 817 | 99.1 | **Modification of core network protocols for GERAN Inter BSC NACC over Gb Interface** | 165d | 2001-09-03 A | 2002-04-19 A | 100% |  | 2001-09-03 | 2002-04-19 | 165d |  |  | N4; S2 | 7048h | 7048h | GERNACC-Cnmod |  |  |  |  |  |  |  |  |
| 818 | 99.1.1 | Stage 2 - Concept | 43d | 2001-09-03 A | 2001-10-31 A | 100% |  | 2001-09-03 | 2001-10-31 | 43d |  | finish no earlier than 2001-10-31 | N4; S2 | 688h | 688h |  |  |  |  |  |  |  |  |  |
| 819 | 99.1.2 | Stage 2 - 23.060 change - Definition of Inter BSC NACC | 165d | 2001-09-03 A | 2002-04-19 A | 100% |  | 2001-09-03 | 2002-04-19 | 165d |  | finish no earlier than 2002-04-19 | N4; S2 | 2640h | 2640h |  |  |  |  |  |  |  |  |  |
| 820 | 99.1.3 | Stage 3 (changes to TS 29.060) | 135d | 2001-09-03 A | 2002-03-08 A | 100% |  | 2001-09-03 | 2002-03-08 | 135d |  | finish no earlier than 2002-03-08 | N4 | 1080h | 1080h |  |  |  |  |  |  |  |  |  |
| 821 | 99.2 | **Modification of Gb protocols for GERAN Inter BSC NACC over Gb Interface** | 151d | 2001-11-30 A | 2002-06-28 A | 100% |  | 2001-11-30 | 2002-06-28 | 151d |  |  | GP | 2416h | 2416h | GERNACC-Gbmod |  |  |  |  |  |  |  |  |
| 822 | 99.2.1 | Stage 3 (changes to TS 48.018) | 151d | 2001-11-30 A | 2002-06-28 A | 100% |  | 2001-11-30 | 2002-06-28 | 151d |  | finish no earlier than 2002-06-28 | GP | 1208h | 1208h |  |  |  |  |  |  |  |  |  |
| 823 | 100 | **Enhanced Power Control** | 540d | 2001-11-26 A | 2003-12-19 |  | 537.46d | 2001-11-26 | 2003-12-19 | 540d | 248d |  | GP | 12840h | 60.28h | EPC |  |  |  |  |  |  | Rel-5 |  |
| 824 | 100.1 | Realization of Enhanced power control and signaling support | 5d | 2001-11-26 A | 2001-11-30 A | 100% |  | 2001-11-26 | 2001-11-30 | 5d |  | finish no earlier than 2001-11-30 | GP | 40h | 40h |  |  |  |  |  |  |  |  |  |
| 825 | 100.2 | GERAN MS Conformance test for Enhanced Power Control | 530d | 2001-12-10 | 2003-12-19 |  |  | 2001-12-10 | 2003-12-19 | 530d | 248d | finish no earlier than 2003-12-19 | GP | 4240h |  |  |  |  |  |  |  |  |  |  |
| 826 | 100.3 | GERAN BTS Conformance test for Enhanced Power Control | 530d | 2001-12-10 | 2003-12-19 |  |  | 2001-12-10 | 2003-12-19 | 530d | 248d | finish no earlier than 2003-12-19 | GP | 4240h |  |  |  |  |  |  |  |  |  |  |
| 827 | 101 | **8PSK AMR HR** | 530d | 2001-12-10 A | 2003-12-19 | 73% | 143.32d | 2001-12-10 | 2003-12-19 | 530d | 248d |  | GP | 21080h | 15693.5h | 8PSK-AH |  |  |  |  |  |  | Rel-5 | Paolo |
| 828 | 101.1 | **Definition of channel coding, performance requirements and signaling support** | 145d | 2001-12-10 A | 2002-06-28 A | 100% |  | 2001-12-10 | 2002-06-28 | 145d |  |  | GP | 10440h | 10440h |  |  |  |  |  |  |  |  |  |
| 829 | 101.1.1 | Concept | 145d | 2001-12-10 A | 2002-06-28 A | 100% |  | 2001-12-10 | 2002-06-28 | 145d |  | finish no earlier than 2002-06-28 | GP | 1160h | 1160h |  |  |  |  |  |  |  |  |  |
| 830 | 101.1.2 | Changes to 44.018 | 145d | 2001-12-10 A | 2002-06-28 A | 100% |  | 2001-12-10 | 2002-06-28 | 145d |  | finish no earlier than 2002-06-28 | G2 | 1160h | 1160h |  |  |  |  |  |  |  |  |  |
| 831 | 101.1.3 | Changes to 45.001 | 145d | 2001-12-10 A | 2002-06-28 A | 100% |  | 2001-12-10 | 2002-06-28 | 145d |  | finish no earlier than 2002-06-28 | G1 | 1160h | 1160h |  |  |  |  |  |  |  |  |  |
| 832 | 101.1.4 | Changes to 45.002 | 145d | 2001-12-10 A | 2002-06-28 A | 100% |  | 2001-12-10 | 2002-06-28 | 145d |  | finish no earlier than 2002-06-28 | G1 | 1160h | 1160h |  |  |  |  |  |  |  |  |  |
| 833 | 101.1.5 | Changes to 45.003 | 145d | 2001-12-10 A | 2002-06-28 A | 100% |  | 2001-12-10 | 2002-06-28 | 145d |  | finish no earlier than 2002-06-28 | G1 | 1160h | 1160h |  |  |  |  |  |  |  |  |  |
| 834 | 101.1.6 | Changes to 45.005 | 145d | 2001-12-10 A | 2002-06-28 A | 100% |  | 2001-12-10 | 2002-06-28 | 145d |  | finish no earlier than 2002-06-28 | G1 | 1160h | 1160h |  |  |  |  |  |  |  |  |  |
| 835 | 101.1.7 | Changes to 24.008 | 145d | 2001-12-10 A | 2002-06-28 A | 100% |  | 2001-12-10 | 2002-06-28 | 145d |  | finish no earlier than 2002-06-28 | G2 | 1160h | 1160h |  |  |  |  |  |  |  |  |  |
| 836 | 101.1.8 | Changes to 48.058 | 145d | 2001-12-10 A | 2002-06-28 A | 100% |  | 2001-12-10 | 2002-06-28 | 145d |  | finish no earlier than 2002-06-28 | G2 | 1160h | 1160h |  |  |  |  |  |  |  |  |  |
| 837 | 101.2 | GERAN MS Conformance test for 8PSK HR | 530d | 2001-12-10 | 2003-12-19 |  |  | 2001-12-10 | 2003-12-19 | 530d | 248d | finish no earlier than 2003-12-19 | GP | 4240h |  |  |  |  |  |  |  |  |  |  |
| 838 | 101.3 | GERAN BTS Conformance test for 8PSK HR | 270d | 2001-12-10 A | 2002-12-20 A | 100% |  | 2001-12-10 | 2002-12-20 | 270d |  | finish no earlier than 2002-12-20 | GP | 2160h | 2160h |  |  |  |  |  |  |  |  |  |
| 839 | 102 | Service Change and UDI Fallback | 175d | 2001-10-08 A | 2002-06-07 A | 100% |  | 2001-10-08 | 2002-06-07 | 175d |  | finish no earlier than 2002-06-07 | N3 | 1400h | 1400h | SCUDIF |  | 29.007, 27.001, 24.008 | Rune Werner Wiik, Ericsson AS | Rune.Werner.Wiik@ericsson.no | WG |  | Rel-5 | David |

Notes:
- 820: IP 30/11/01: Input awaited from GERAN2 to CN4 / 17 May Work complete 100%
- 824: Ready
- 825: Not started
- 826: Not started
- 827: Completed for Rel-5
- 839: [DAB - 15/11/02] - NOTE INTERWORKING ISSUES IDENTIFIED THAT NEED CLARIFICATION

| ID | WBS | Task | Duration | Start | Finish | Complete | Remaining | Baseline start | Baseline finish | Baseline duration | Total slack | Constraint | Resources | Work | Actual work | Text1 | Text2 | Text6 | Text8 | Text9 | Text4 | Text3 | Text7 | Text5 |
| --- | --- | --- | --- | --- | --- | --- | --- | --- | --- | --- | --- | --- | --- | --- | --- | --- | --- | --- | --- | --- | --- | --- | --- | --- |
| 840 | 103 | **Rel-5 USIM toolkit enhancements** | 865d | 2000-06-05 A | 2003-09-26 | 51% | 425.77d | 2000-06-05 | 2003-09-26 | 865d | 308d |  | T3 | 24352h | 13591.2h | USAT1 | Ter | NA | Claus | 1800 |  |  |  |  |
| 841 | 103.1 | Test specification for USIM toolkit security mechanims | 349d | 2002-05-28 | 2003-09-26 |  |  | 2002-05-28 | 2003-09-26 | 349d | 308d | finish no earlier than 2003-09-26 | T3 | 2792h |  |  |  |  |  |  | Sophie Viallet (Gemplus) |  |  |  |
| 842 | 103.2 | **Protocol Standardisation of a SIM Toolkit Interpreter** | 688d | 2000-06-05 A | 2003-01-22 | 64% | 250.88d | 2000-06-05 | 2003-01-22 | 688d | 485d |  | T3 | 12512h | 7949.4h | USAT1-Interpr | Ter | Rel-5 |  | 1801 | Michael Meyer, G & D | 27.103 | TSG |  |
| 843 | 103.2.1 | Stage 1 | 205d | 2000-06-05 A | 2001-03-16 A | 100% |  | 2000-06-05 | 2001-03-16 | 205d |  | finish no earlier than 2001-03-16 | T3 | 1640h | 1640h |  |  |  |  |  |  |  | TSG |  |
| 844 | 103.2.2 | Stage 2 and 3 | 308d | 2001-01-03 A | 2002-03-08 A | 100% |  | 2001-01-03 | 2002-03-08 | 308d |  | finish no earlier than 2002-03-08 | T3 | 2464h | 2464h |  |  |  |  |  |  |  | TSG |  |
| 845 | 103.2.3 | Test specification | 363d | 2001-09-03 A | 2003-01-22 | 12% | 319.44d | 2001-09-03 | 2003-01-22 | 363d | 485d | finish no earlier than 2003-01-22 | T3 | 2904h | 348.48h |  |  |  |  |  | Gérald MAUNIER (Gemplus) |  | TSG |  |
| 846 | 103.4 | **(U)SIM API** | 133d | 2002-03-20 A | 2002-09-20 A | 100% |  | 2002-03-20 | 2002-09-20 | 133d |  |  | T3 | 2128h | 2128h | USAT1-API |  | NA |  |  |  |  |  |  |
| 847 | 103.4.1 | Java API Test specification | 133d | 2002-03-20 A | 2002-09-20 A | 100% |  | 2002-03-20 | 2002-09-20 | 133d |  | finish no earlier than 2002-09-20 | T3 | 1064h | 1064h |  |  |  |  |  | Mario Pérez (Microelectrónica Española) |  |  |  |
| 848 | 104 | small Technical Enhancements and Improvements for Rel5 | 325d | 2000-12-25 A | 2002-03-22 A | 100% |  | 2000-12-25 | 2002-03-22 | 325d |  | start no earlier than 2000-12-25 | Generic | 2600h | 2600h | TEI5 |  | Rel-5 |  | 1993 |  |  | TSG |  |
| 849 | 105 | Technical Report on UE Functionality Split | 86d | 2000-01-03 | 2000-05-01 |  |  | 2000-01-03 | 2000-05-01 | 86d | 1197d |  | S1 | 688h |  | UESPLIT |  | Rel-5 | Michael |  | Sanjay Gupta, Motorola |  | TSG | sanjay.gupta@motorola.com |
| 850 | 106 | **User Equipment Management** | 267d | 2001-06-21 A | 2002-06-28 | 99% | 0d | 2001-06-21 | 2002-06-28 | 267d | 0d |  | S5 | 3752h | 3752h | UEM |  | NA | Adrian |  | John Mudge (Vodafone) |  | TSG | john.mudge@vf.vodafone.co.uk |
| 851 | 106.1 | FS on User Equipment (UE) Management | 267d | 2001-06-21 A | 2002-06-28 A | 100% |  | 2001-06-21 | 2002-06-28 | 267d |  | finish no earlier than 2002-06-28 | S5 | 2136h | 2136h | OAM-UEM |  | Rel-5 | Adrian |  | John Mudge (Vodafone) | 32.802 | TSG | john.mudge@VF.VODAFONE.CO.UK |
| 852 | 107 | **Flow control supporting an MS with multiple data flows with different QoS over the Gb interface** | 50d | 2002-06-24 A | 2002-08-30 A | 100% |  | 2002-06-24 | 2002-08-30 | 50d |  |  | GP | 1288h | 1288h | FlowCon |  | Rel-5 |  |  | Ingemar Backlund, Ericsson |  | TSG |  |
| 853 | 107.1 | **Update of stage 2 specifications** | 50d | 2002-06-24 A | 2002-08-30 A | 100% |  | 2002-06-24 | 2002-08-30 | 50d |  |  | GP | 808h | 808h |  |  |  |  |  |  |  | TSG |  |
| 854 | 107.1.1 | Concept document 23.060 (changes to) | 46d | 2002-06-28 A | 2002-08-30 A | 100% |  | 2002-06-28 | 2002-08-30 | 46d |  | finish no earlier than 2002-08-30 | S2 | 368h | 368h |  |  |  |  |  |  |  |  |  |
| 855 | 107.1.2 | Flow Control | 5d | 2002-06-24 A | 2002-06-28 A | 100% |  | 2002-06-24 | 2002-06-28 | 5d |  | finish no earlier than 2002-06-28 | GP | 40h | 40h |  |  |  |  |  |  |  |  |  |
| 856 | 107.2 | **Modification of BSSGP protocol** | 5d | 2002-06-24 A | 2002-06-28 A | 100% |  | 2002-06-24 | 2002-06-28 | 5d |  |  | GP | 80h | 80h |  |  |  |  |  | Ingemar Backlund, Ericsson |  | TSG |  |
| 857 | 107.2.1 | Stage 3 (changes to 48.018) | 5d | 2002-06-24 A | 2002-06-28 A | 100% |  | 2002-06-24 | 2002-06-28 | 5d |  | finish no earlier than 2002-06-28 | G2 | 40h | 40h |  |  |  |  |  |  |  |  |  |
| 858 | 108 | **Multiple TBF in A/Gb mode** | 421d | 2002-04-19 A | 2003-11-28 | 17% | 349.82d | 2002-04-19 | 2003-11-28 | 421d | 263d |  | GP | 17480h | 2716.74h | MULTBF |  | Rel-5 |  |  | Gunnar Mildh, Ericsson |  | TSG | gunnar.mildh@era.ericsson.se |
| 859 | 108.1 | **Multiple TBF in A/Gb mode** | 351d | 2002-04-19 A | 2003-08-22 | 26% | 258.09d | 2002-04-19 | 2003-08-22 | 351d | 333d |  | GP | 8112h | 2147.29h | MULTBF-Agbmode |  |  |  |  |  |  |  |  |
| 860 | 108.1.1 | Multiple TBF Concept paper | 351d | 2002-04-19 A | 2003-08-22 | 50% | 175.5d | 2002-04-19 | 2003-08-22 | 351d | 333d | finish no earlier than 2003-08-22 | GP | 2808h | 1404h |  |  |  |  |  |  |  |  |  |
| 861 | 108.1.2 | Multiple TBF Stage 2 (43.064) CRs | 156d | 2002-04-19 | 2002-11-22 |  |  | 2002-04-19 | 2002-11-22 | 156d | 528d | finish no earlier than 2002-11-22 | G1 | 1248h |  |  |  |  |  |  |  |  |  |  |
| 862 | 108.1.3 | Multiple TBF Stage 3 (44.060) CRs | 156d | 2002-04-19 | 2002-11-22 |  |  | 2002-04-19 | 2002-11-22 | 156d | 528d | finish no earlier than 2002-11-22 | G2 | 1248h |  |  |  |  |  |  |  |  |  |  |
| 863 | 108.2 | **Multiple TBF in A/Gb mode – MS testing** | 375d | 2002-06-24 | 2003-11-28 |  |  | 2002-06-24 | 2003-11-28 | 375d | 263d |  | GP | 6000h |  |  |  |  |  |  | Ingemar Backlund, Ericsson |  |  |  |
| 864 | 108.2.1 | MS conformance tests | 375d | 2002-06-24 | 2003-11-28 |  |  | 2002-06-24 | 2003-11-28 | 375d | 263d | finish no earlier than 2003-11-28 | G4 | 3000h |  |  |  |  |  |  |  |  |  |  |

Notes:
- 842: 28/5/2001: T3-19 proposed that since the stage 2 and 3 will not be presented to TP-12 for approval as expected, the WI will be moved to rel-5, with completion expected at TP-13.
- 843: 5/10/2001: Stage one comepeted at TP-12.
- 844: 5/10/2001: TS 31.112 and 31.113 approved at TP-13. TS 31.114 to be presented to TP-14.
- 845: 5/10/2001: Work started on test specification
- 846: 8/3/2001: test spec is based on R99 core spec, so deleted from Workplan
- 848: "Joker" WI, to be used for a Rel 5 CR not related to any feature and with very limited impact on the system
- 850: az: Rel-5->NA (to cover also Rel-6)
- 859: Started
- 864: Not started

| ID | WBS | Task | Duration | Start | Finish | Complete | Remaining | Baseline start | Baseline finish | Baseline duration | Total slack | Constraint | Resources | Work | Actual work | Text1 | Text4 | Text6 | Text7 | Text8 | Text9 |
| --- | --- | --- | --- | --- | --- | --- | --- | --- | --- | --- | --- | --- | --- | --- | --- | --- | --- | --- | --- | --- | --- |
| 865 | 109 | **Alignment of 3G functional split and Iu** | 922d | 2000-06-08 A | 2003-12-19 | 85% | 141.74d | 2000-06-08 | 2003-12-19 | 922d | 248d |  | GP | 161582h | 123264h | GER3GAL | Frank Muller, Ericsson | Rel-5 | TSG | Paolo | 2345 |
| 866 | 109.1 | **GERAN user / control plane** | 540d | 2000-08-07 A | 2002-08-30 | 99% | 0d | 2000-08-07 | 2002-08-30 | 540d | 0d |  | GP | 36232h | 32092h | GER3GAL-GUCOPL | Frank Muller, Ericsson |  | TSG | Paolo | 2346 |
| 867 | 109.1.1 | **Alignment with UMTS bearer concept** | 540d | 2000-08-07 A | 2002-08-30 | 99% | 0d | 2000-08-07 | 2002-08-30 | 540d | 0d |  | GP | 24952h | 22392h |  |  |  | TSG |  | 2347 |
| 868 | 109.1.1.1 | Enhanced power control | 1d | 2001-08-31 A | 2001-08-31 A | 100% |  | 2001-08-31 | 2001-08-31 | 1d |  | finish no earlier than 2001-08-31 | GP | 8h | 8h |  |  |  | TSG |  |  |
| 869 | 109.1.1.2 | Stage 2 | 235d | 2000-08-07 A | 2001-06-29 A | 100% |  | 2000-08-07 | 2001-06-29 | 235d |  | finish no earlier than 2001-06-29 | GP | 1880h | 1880h |  |  |  | TSG |  | 2423 |
| 870 | 109.1.1.3 | Adoption of the UTRAN PDCP | 295d | 2000-11-06 A | 2001-12-21 A | 100% |  | 2000-11-06 | 2001-12-21 | 295d |  | finish no earlier than 2001-12-21 | GP | 2360h | 2360h |  |  |  | TSG |  | 2348 |
| 871 | 109.1.1.4 | Development of RLC / MAC | 261d | 2001-08-31 A | 2002-08-30 A | 100% |  | 2001-08-31 | 2002-08-30 | 261d |  | finish no earlier than 2002-08-30 | GP | 2088h | 2088h |  |  |  | TSG |  |  |
| 872 | 109.1.1.5 | Development of GERAN RRC | 266d | 2001-06-22 A | 2002-06-28 A | 100% |  | 2001-06-22 | 2002-06-28 | 266d |  | finish no earlier than 2002-06-28 | GP | 2128h | 2128h |  |  |  | TSG |  |  |
| 873 | 109.1.1.6 | Ciphering and integrity protection concept paper | 166d | 2001-08-31 A | 2002-04-19 A | 100% |  | 2001-08-31 | 2002-04-19 | 166d |  | finish no earlier than 2002-04-19 | GP | 1328h | 1328h |  |  |  | TSG |  |  |
| 874 | 109.1.1.7 | Multiple TBF or equivalent Concept paper | 116d | 2001-08-31 A | 2002-02-08 A | 100% |  | 2001-08-31 | 2002-02-08 | 116d |  | finish no earlier than 2002-02-08 | GP | 928h | 928h |  |  |  | TSG |  |  |
| 875 | 109.1.1.8 | Paging concept | 166d | 2001-08-31 A | 2002-04-19 A | 100% |  | 2001-08-31 | 2002-04-19 | 166d |  | finish no earlier than 2002-04-19 | GP | 1328h | 1328h |  |  |  | TSG |  |  |
| 876 | 109.1.1.9 | Dedicated Physical subchannels, includes traffic and control channels | 66d | 2001-08-31 A | 2001-11-30 A | 100% |  | 2001-08-31 | 2001-11-30 | 66d |  | finish no earlier than 2001-11-30 | GP | 528h | 528h |  |  |  | TSG |  |  |
| 877 | 109.1.1.10 | Iu support and broadcast concept | 166d | 2001-08-31 A | 2002-04-19 A | 100% |  | 2001-08-31 | 2002-04-19 | 166d |  | finish no earlier than 2002-04-19 | GP | 1328h | 1328h |  |  |  | TSG |  |  |
| 878 | 109.1.1.11 | Impact of using RLC instead of LAPDm concept | 116d | 2001-08-31 A | 2002-02-08 A | 100% |  | 2001-08-31 | 2002-02-08 | 116d |  | finish no earlier than 2002-02-08 | GP | 928h | 928h |  |  |  | TSG |  |  |
| 879 | 109.1.1.12 | Contention resolution, mobile station identity, and access concept | 66d | 2001-08-31 A | 2001-11-30 A | 100% |  | 2001-08-31 | 2001-11-30 | 66d |  | finish no earlier than 2001-11-30 | GP | 528h | 528h |  |  |  | TSG |  |  |
| 880 | 109.1.1.13 | PDCP concept | 166d | 2001-08-31 A | 2002-04-19 A | 100% |  | 2001-08-31 | 2002-04-19 | 166d |  | finish no earlier than 2002-04-19 | GP | 1328h | 1328h |  |  |  | TSG |  |  |
| 881 | 109.1.1.14 | Downlink delayed TBF release | 261d | 2001-08-31 A | 2002-08-30 A | 100% |  | 2001-08-31 | 2002-08-30 | 261d |  | finish no earlier than 2002-08-30 | GP | 2088h | 2088h |  |  |  | TSG |  |  |
| 882 | 109.1.1.15 | Add transparent RLC Concept | 116d | 2001-08-31 A | 2002-02-08 A | 100% |  | 2001-08-31 | 2002-02-08 | 116d |  | finish no earlier than 2002-02-08 | GP | 928h | 928h |  |  |  | TSG |  |  |
| 883 | 109.1.1.16 | Handover concept | 116d | 2001-08-31 A | 2002-02-08 A | 100% |  | 2001-08-31 | 2002-02-08 | 116d |  | finish no earlier than 2002-02-08 | GP | 928h | 928h |  |  |  |  |  |  |
| 884 | 109.1.2 | **Physical layer alignment with UMTS bearer concept** | 280d | 2000-11-06 A | 2001-11-30 | 99% | 0d | 2000-11-06 | 2001-11-30 | 280d | 0d |  | GP | 6960h | 5380h |  |  |  | TSG |  | 2424 |
| 885 | 109.1.2.1 | PDTCH/TCH in 45.003 | 155d | 2000-11-06 A | 2001-06-08 A | 100% |  | 2000-11-06 | 2001-06-08 | 155d |  | finish no earlier than 2001-06-08 | GP | 1240h | 1240h |  |  |  | TSG |  | 2356 |
| 886 | 109.1.2.2 | Control channels in 45.003 | 155d | 2000-11-06 A | 2001-06-08 A | 100% |  | 2000-11-06 | 2001-06-08 | 155d |  | finish no earlier than 2001-06-08 | GP | 1240h | 1240h |  |  |  | TSG |  | 2357 |
| 887 | 109.1.2.3 | Receiver performance in 45.005 for PDTCH/TCH and control channels | 280d | 2000-11-06 A | 2001-11-30 A | 100% |  | 2000-11-06 | 2001-11-30 | 280d |  | finish no earlier than 2001-11-30 | GP | 2240h | 2240h |  |  |  | TSG |  | 2358 |
| 888 | 109.2 | **Iu rg interface** | 430d | 2000-11-06 A | 2002-06-28 A | 100% |  | 2000-11-06 | 2002-06-28 | 430d |  |  | GP; RP | 59660h | 56220h | GER3GAL-Iurg | Frank Muller, Ericsson |  | TSG | Paolo | 2359 |
| 889 | 109.2.1 | **Inter BSS interface** | 430d | 2000-11-06 A | 2002-06-28 A | 100% |  | 2000-11-06 | 2002-06-28 | 430d |  |  | GP; RP | 24080h | 24080h |  |  |  |  |  | 2425 |
| 890 | 109.2.1.1 | Identification of requirements | 430d | 2000-11-06 A | 2002-06-28 A | 100% |  | 2000-11-06 | 2002-06-28 | 430d |  | finish no earlier than 2002-06-28 | GP | 3440h | 3440h |  |  |  |  |  | 2360 |
| 891 | 109.2.1.2 | Stage 2 | 430d | 2000-11-06 A | 2002-06-28 A | 100% |  | 2000-11-06 | 2002-06-28 | 430d |  | finish no earlier than 2002-06-28 | GP | 3440h | 3440h |  |  |  |  |  | 2361 |
| 892 | 109.2.1.3 | Adoption of relevant parts from Iur | 430d | 2000-11-06 A | 2002-06-28 A | 100% |  | 2000-11-06 | 2002-06-28 | 430d |  | finish no earlier than 2002-06-28 | GP | 3440h | 3440h |  |  |  |  |  | 2362 |
| 893 | 109.2.1.4 | Complementation with GERAN specifics | 430d | 2000-11-06 A | 2002-06-28 A | 100% |  | 2000-11-06 | 2002-06-28 | 430d |  | finish no earlier than 2002-06-28 | GP | 3440h | 3440h |  |  |  |  |  | 2363 |
| 894 | 109.2.1.5 | Stage 3 | 430d | 2000-11-06 A | 2002-06-28 A | 100% |  | 2000-11-06 | 2002-06-28 | 430d |  | finish no earlier than 2002-06-28 | GP | 3440h | 3440h |  |  |  |  |  | 2364 |

Notes:
- 865: AWS, Nokia, Ericsson, Nortel, Siemens, Vodafone
- 866: AWS, Nokia, Ericsson, Nortel, Siemens, Vodafone
- 870: Responsible is GERAN; RAN WG2 help may be needed.
- 888: AWS, Nokia, Ericsson, Nortel, Siemens, Vodafone

| ID | WBS | Task | Duration | Start | Finish | Complete | Remaining | Baseline start | Baseline finish | Baseline duration | Total slack | Constraint | Resources | Work | Actual work | Text9 | Text8 | Text1 | Text4 | Text6 | Text7 |
| --- | --- | --- | --- | --- | --- | --- | --- | --- | --- | --- | --- | --- | --- | --- | --- | --- | --- | --- | --- | --- | --- |
| 895 | 109.2.2 | **Inter BSS-RNS interface** | 430d | 2000-11-06 A | 2002-06-28 A | 100% |  | 2000-11-06 | 2002-06-28 | 430d |  |  | GP; RP | 28700h | 28700h | 2426 |  |  |  |  |  |
| 896 | 109.2.2.1 | Identification of requirements | 430d | 2000-11-06 A | 2002-06-28 A | 100% |  | 2000-11-06 | 2002-06-28 | 430d |  | start no earlier than 2000-11-06 | GP; R3 | 6880h | 6880h | 2365 |  |  |  |  |  |
| 897 | 109.2.2.2 | Stage 2 | 430d | 2000-11-06 A | 2002-06-28 A | 100% |  | 2000-11-06 | 2002-06-28 | 430d |  | finish no earlier than 2002-06-28 | GP; R3 | 5744.8h | 5744.8h | 2366 |  |  |  |  |  |
| 898 | 109.2.2.3 | Adoption of relevant parts from Iur | 430d | 2000-11-06 A | 2002-06-28 A | 100% |  | 2000-11-06 | 2002-06-28 | 430d |  | finish no earlier than 2002-06-28 | GP; R3 | 6880h | 6880h | 2367 |  |  |  |  |  |
| 899 | 109.2.2.4 | Complementation with GERAN specifics | 107.5d | 2002-01-30 A | 2002-06-28 A | 100% |  | 2002-01-30 | 2002-06-28 | 107.5d |  | finish no earlier than 2002-06-28 | GP; R3 | 1720h | 1720h | 2368 |  |  |  |  |  |
| 900 | 109.2.2.5 | Stage 3 | 107.5d | 2002-01-30 A | 2002-06-28 A | 100% |  | 2002-01-30 | 2002-06-28 | 107.5d |  | finish no earlier than 2002-06-28 | GP; R3 | 1720h | 1720h | 2369 |  |  |  |  |  |
| 901 | 109.3 | **Voice over GERAN PS and CS concept** | 430d | 2000-11-06 A | 2002-06-28 A | 100% |  | 2000-11-06 | 2002-06-28 | 430d |  |  | GP; R3 | 33338.4h | 33338.4h | 2370 | Paolo |  |  |  |  |
| 902 | 109.3.1 | Architecture for A, Iu cs and Iu ps | 430d | 2000-11-06 A | 2002-06-28 A | 100% |  | 2000-11-06 | 2002-06-28 | 430d |  | finish no earlier than 2002-06-28 | GP; R3 | 6412.8h | 6412.8h | 2371 |  |  |  |  |  |
| 903 | 109.3.2 | Transcoder position/operation | 115d | 2000-11-06 A | 2001-04-13 A | 100% |  | 2000-11-06 | 2001-04-13 | 115d |  | finish no earlier than 2001-04-13 | GP | 920h | 920h | 2372 |  |  |  |  |  |
| 904 | 109.3.3 | Handover | 430d | 2000-11-06 A | 2002-06-28 A | 100% |  | 2000-11-06 | 2002-06-28 | 430d |  | finish no earlier than 2002-06-28 | GP; R3 | 6412.8h | 6412.8h | 2373 |  |  |  |  |  |
| 905 | 109.3.4 | RTP payload | 430d | 2000-11-06 A | 2002-06-28 A | 100% |  | 2000-11-06 | 2002-06-28 | 430d |  | finish no earlier than 2002-06-28 | GP; R3 | 6412.8h | 6412.8h | 2374 |  |  |  |  |  |
| 906 | 109.3.5 | Codec renegotiation concept | 365d | 2000-11-06 A | 2002-03-29 A | 100% |  | 2000-11-06 | 2002-03-29 | 365d |  | finish no earlier than 2002-03-29 | GP; R3 | 5840h | 5840h |  |  |  |  |  |  |
| 907 | 109.3.6 | LA | 115d | 2000-11-06 A | 2001-04-13 A | 100% |  | 2000-11-06 | 2001-04-13 | 115d |  | finish no earlier than 2001-04-13 | GP | 920h | 920h |  |  |  |  |  |  |
| 908 | 109.4 | **GERAN MS Conformance test for GERAN interface evolution** | 660d | 2001-06-11 | 2003-12-19 |  |  | 2001-06-11 | 2003-12-19 | 660d | 248d |  | GP | 10560h |  | 2388 | Paolo |  |  |  |  |
| 909 | 109.4.1 | MS test | 660d | 2001-06-11 | 2003-12-19 |  |  | 2001-06-11 | 2003-12-19 | 660d | 248d | finish no earlier than 2003-12-19 | GP | 5280h |  | 2389 |  |  |  |  |  |
| 910 | 109.5 | **GERAN BSS Conformance test for GERAN interface evolution** | 922d | 2000-06-08 | 2003-12-19 |  |  | 2000-06-08 | 2003-12-19 | 922d | 248d |  | GP | 14752h |  | 2390 | Paolo |  |  |  |  |
| 911 | 109.5.1 | BSS test | 922d | 2000-06-08 | 2003-12-19 |  |  | 2000-06-08 | 2003-12-19 | 922d | 248d | finish no earlier than 2003-12-19 | GP | 7376h |  | 2391 |  |  |  |  |  |
| 912 | 110 | **GERAN support for IMS** | 690d | 2000-05-01 A | 2002-12-20 | 59% | 286.24d | 2000-05-01 | 2002-12-20 | 690d | 508d |  | GP | 66591.8h | 29961h |  | Paolo | GERIMS | Shkumbin Hamiti, Nokia | Rel-5 | TSG |
| 913 | 110.1 | **GERAN Header adaptation** | 690d | 2000-05-01 A | 2002-12-20 A | 100% |  | 2000-05-01 | 2002-12-20 | 690d |  |  | GP; S2; RP | 27325.8h | 18525.8h |  | Paolo | GERIMS-HEADAPT | Shkumbin Hamiti, Nokia |  | TSG |
| 914 | 110.1.1 | Definition of compression and removal modes for PDCP protocol | 22.1d | 2000-05-01 A | 2000-11-10 A | 100% |  | 2000-05-01 | 2000-11-10 | 22.1d |  | finish no earlier than 2000-09-01 | GP; S2; RP | 248.4h | 248.4h | 2332 |  |  |  |  | TSG |
| 915 | 110.1.2 | Conceptual description in stage 2 | 393d | 2000-05-01 A | 2001-10-31 A | 100% |  | 2000-05-01 | 2001-10-31 | 393d |  | finish no earlier than 2001-10-31 | GP; S2; RP | 5989.92h | 5989.92h | 2333 |  |  |  |  | TSG |
| 916 | 110.1.3 | Necessary changes on stage 3 regarding header removal | 439.8d | 2000-11-06 A | 2002-12-20 A | 100% |  | 2000-11-06 | 2002-12-20 | 439.8d |  | finish no earlier than 2002-12-20 | GP; S2; RP | 6767.47h | 6767.47h |  |  |  |  |  | TSG |
| 917 | 110.2 | **GERAN Radio access bearer design for IMS** | 430d | 2000-11-06 A | 2002-06-28 | 89% | 46.49d | 2000-11-06 | 2002-06-28 | 430d | 633d |  | GP; S2; RP | 21658h | 8621.71h | 2335 | Paolo | GERIMS-RABDES | Shkumbin Hamiti, Nokia |  | TSG |
| 918 | 110.2.1 | **MuM control signalling for conversational multimedia services** | 430d | 2000-11-06 A | 2002-06-28 | 89% | 46.49d | 2000-11-06 | 2002-06-28 | 430d | 633d |  | GP; S2; RP | 12458h | 5553.6h | 2422 |  |  |  |  | TSG |
| 919 | 110.2.1.1 | Identification of requirements | 330d | 2000-11-06 A | 2002-02-08 A | 100% |  | 2000-11-06 | 2002-02-08 | 330d |  | finish no earlier than 2002-02-08 | GP; S2; RP | 5545.6h | 5545.6h | 2431 |  |  |  |  | TSG |
| 920 | 110.2.1.2 | Necessary modifications due to SIP | 40d | 2002-05-06 | 2002-06-28 |  |  | 2002-05-06 | 2002-06-28 | 40d | 633d | finish no earlier than 2002-06-28 | GP; S2; RP | 960h |  | 2337 |  |  |  |  | TSG |

Notes:
- 908: Not started
- 909: Not started
- 910: Not started
- 911: Not started
- 912: AWS, Nokia, Ericsson, Nortel, Siemens, Motorola
- 913: AWS, Nokia, Ericsson, Nortel, Siemens, Motorola
- 917: TERMINATED - NOT STANDARDIZED
- 918: TERMINATED - NOT STANDARDIZED
- 919: TERMINATED - NOT STANDARDIZED
- 920: TERMINATED - NOT STANDARDIZED

| ID | WBS | Task | Duration | Start | Finish | Complete | Baseline start | Baseline finish | Baseline duration | Total slack | Constraint | Resources | Work | Actual work | Text1 | Text4 | Text7 | Text8 | Text9 | Text6 |
| --- | --- | --- | --- | --- | --- | --- | --- | --- | --- | --- | --- | --- | --- | --- | --- | --- | --- | --- | --- | --- |
| 921 | 110.3 | **GERAN MS Conformance test for support of IMS** | 400d | 2001-06-11 | 2002-12-20 |  | 2001-06-11 | 2002-12-20 | 400d | 508d |  | GP | 6400h |  | GERIMS-MSconf | Shkumbin Hamiti, Nokia | TSG | Paolo | 2341 |  |
| 922 | 110.3.1 | MS test | 400d | 2001-06-11 | 2002-12-20 |  | 2001-06-11 | 2002-12-20 | 400d | 508d | finish no earlier than 2002-12-20 | G4 | 3200h |  |  |  | TSG |  | 2342 |  |
| 923 | 110.4 | **GERAN BTS Conformance test for support of IMS** | 400d | 2001-06-11 | 2002-12-20 |  | 2001-06-11 | 2002-12-20 | 400d | 508d |  | GP | 6400h |  | GERIMS-BTSconf | Shkumbin Hamiti, Nokia | TSG | Paolo | 2343 |  |
| 924 | 110.4.1 | BTS test | 400d | 2001-06-11 | 2002-12-20 |  | 2001-06-11 | 2002-12-20 | 400d | 508d | finish no earlier than 2002-12-20 | G3 | 3200h |  |  |  | TSG |  | 2344 |  |
| 925 | 116 | MS Conformance Testing of Dual Transfer Mode | 65d? | 2002-11-11 A | 2003-02-07 A | 100% | 2002-11-11 | 2003-02-07 | 65d? |  | finish no earlier than 2003-02-07 | G4; G5 | 1040h | 1040h | MSCTDTM | Dave Fox, Vodafone | TSG |  |  | NA |

Notes:
- 921: TERMINATED - NOT STANDARDIZED
- 922: TERMINATED - NOT STANDARDIZED
- 923: TERMINATED - NOT STANDARDIZED
- 924: TERMINATED - NOT STANDARDIZED
- 925: Needed to complete DTM (R99)
